# 3GPP_Release-2000

Schedule from MS Project, 1999-01-01 to 2018-04-16, A marks actual dates.

| ID | WBS | Task | Duration | Start | Finish | Complete | Baseline start | Baseline finish | Baseline duration | Constraint | Deadline | Resources | Work | Actual work | Acronym | WI rapporteur name | WI rapporteur e-mail | Release | MCC resp | Acronym_3GU_Export | Impacted TSs and TRs | Created at | TSG stopped |
| --- | --- | --- | --- | --- | --- | --- | --- | --- | --- | --- | --- | --- | --- | --- | --- | --- | --- | --- | --- | --- | --- | --- | --- |
| 4706 | 77 | **High Speed Downlink Packet Access** | 1550d? | 2001-04-02 A | 2007-03-09 A | 100% | 2001-04-02 | 2007-03-09 | 1550d? |  |  | R2; R5 | 43888h | 43888h | HSDPA | Motorola | Ravi Kuchibhotla | Rel-5 | Yong-Jun | HSDPA |  |  |  |
| 4707 | 77.1 | Physical Layer for High Speed Downlink Packet Access | 257d | 2001-04-05 A | 2002-03-29 A | 100% | 2001-04-05 | 2002-03-29 | 257d | finish no earlier than 2002-03-29 |  | R1 | 2056h | 2056h | HSDPA-Phys | Motorola | Amitabha Ghosh (qa0047@email.mot.com) | Rel-5 | Patrick | HSDPA-Phys |  |  |  |
| 4708 | 77.2 | Layer 2 and 3 aspects | 257d | 2001-04-05 A | 2002-03-29 A | 100% | 2001-04-05 | 2002-03-29 | 257d | finish no earlier than 2002-03-29 |  | R2 | 2056h | 2056h | HSDPA-L23 | Motorola | Ravi Kuchibhotla | Rel-5 | Yong-Jun | HSDPA-L23 |  |  |  |
| 4709 | 77.3 | Iub/Iur protocol aspects - for High Speed Downlink Packet Access | 260d | 2001-04-02 A | 2002-03-29 A | 100% | 2001-04-02 | 2002-03-29 | 260d | finish no earlier than 2002-03-29 |  | R3 | 2080h | 2080h | HSDPA-IubIur | Motorola | Mike Diesen | Rel-5 | Juha | HSDPA-IubIur |  |  |  |
| 4710 | 77.4 | RF Radio Transmission/ Reception, System Performance Requirements and Conformance Testing | 565d | 2001-04-09 A | 2003-06-06 A | 100% | 2001-04-09 | 2003-06-06 | 565d | finish no earlier than 2003-06-06 |  | R4 | 4520h | 4520h | HSDPA-RF | Motorola | Howard Benn | Rel-5 | Issam | HSDPA-RF |  |  |  |
| 4711 | 1200.5 | Conformance Testing of HSDPA | 786d | 2003-09-19 A | 2006-09-22 A | 100% | 2003-09-19 | 2006-09-22 | 786d | finish no earlier than 2006-09-22 |  | R5 | 6288h | 6288h | HSDPA_Test | Motorola | carolyn.taylor@motorola.com | Rel-5 | Ingbert | HSDPA_Test | 34.108, 34.121, 34.122, 34.123-1, 34.123-2, 34.123-3 | 19/9/2003 |  |
| 4712 | 1200.6 | Conformance Testing of HCR TDD HSDPA | 261d? | 2006-03-10 A | 2007-03-09 A | 100% | 2006-03-10 | 2007-03-09 | 261d? | finish no earlier than 2007-03-09 |  | R5 | 2088h | 2088h | HSDPA_HCRTDD_Test | IPWireless | drichards@ipwireless.com | Rel-5 | Ingbert | HSDPA_HCRTDD_Test | 34.108, 34.122, 34.123-1, 34.123-2, 34.123-3 |  |  |
| 4713 | 78 | **Rel-5 Improvements of Radio Interface** | 535d | 2000-08-14 A | 2002-08-30 A | 100% | 2000-08-14 | 2002-08-30 | 535d |  |  | RP | 30376h | 30376h |  |  |  | Rel-5 |  |  |  |  |  |
| 4714 | 78.1 | **Base station classification for TDD** | 480d | 2000-08-14 A | 2002-06-14 A | 100% | 2000-08-14 | 2002-06-14 | 480d |  |  | R4 | 9208h | 9208h | RInImp-BSClass | Nokia | antti.toskala@nokia.com | Rel-5 | Issam | RInImp-BSClass |  |  |  |
| 4715 | 78.1.1 | TDD Base station classification | 410d | 2000-08-14 A | 2002-03-08 A | 100% | 2000-08-14 | 2002-03-08 | 410d | finish no earlier than 2002-03-08 |  | R4 | 3280h | 3280h | RInImp-BSClass-TDD | Nokia | antti.toskala@nokia.com | Rel-5 | Issam | RInImp-BSClass-TDD |  |  |  |
| 4716 | 78.1.2 | Base Station Classification for 1.28 Mcps TDD option | 261d | 2001-06-15 A | 2002-06-14 A | 100% | 2001-06-15 | 2002-06-14 | 261d | finish no earlier than 2002-06-14 |  | R4 | 2088h | 2088h | RInImp-BSClass-LCRTDD | Siemens | Meik.Kottkamp@siemens.com | Rel-5 | Issam | RInImp-BSClass-LCRTDD |  |  |  |
| 4717 | 78.2 | Enhancement on the DSCH hard split mode | 271d | 2001-03-16 A | 2002-03-29 A | 100% | 2001-03-16 | 2002-03-29 | 271d | finish no earlier than 2002-03-29 |  | R1 | 2168h | 2168h | RInImp-DSCHhsp | Samsung | Jaeyoel KIM | Rel-5 | Patrick | RInImp-DSCHhsp |  |  |  |
| 4718 | 78.3 | Hybrid ARQ II/III | 355d | 2000-08-21 A | 2001-12-28 A | 100% | 2000-08-21 | 2001-12-28 | 355d | finish no earlier than 2001-12-28 |  | R2 | 2840h | 2840h | RInImp-HARQ | Siemens | armin.sitte@siemens.com | Rel-5 | Yong-Jun | RInImp-HARQ |  |  | RP-14 |
| 4719 | 78.4 | FS on USTS | 355d | 2000-08-14 A | 2001-12-21 A | 100% | 2000-08-14 | 2001-12-21 | 355d | finish no earlier than 2001-12-21 |  | R1 | 2840h | 2840h | RInImp-USTS | SK Telecom | D. Kim | Rel-5 | Patrick | RInImp-USTS |  |  |  |
| 4720 | 78.5 | FS on UE antenna efficiency test method performance requirements | 255d | 2000-09-25 A | 2001-09-14 A | 100% | 2000-09-25 | 2001-09-14 | 255d | finish no earlier than 2001-09-14 |  | R4 | 2040h | 2040h | RInImp-UEAnTM | Allgon | O. Edvardsson | Rel-5 | Issam | RInImp-UEAnTM |  |  |  |
| 4721 | 78.6 | FS on the re-introduction of the downlink SIR measurement | 200d | 2001-03-12 A | 2001-12-14 A | 100% | 2001-03-12 | 2001-12-14 | 200d | finish no earlier than 2001-12-14 |  | R4 | 1600h | 1600h | RInImp-SIR | Ericsson | Torgny.Palenius@ericsson.com | Rel-5 | Issam | RInImp-SIR |  |  |  |
| 4722 | 78.7 | FS on mitigating the effect of CPICH interference at the UE | 255d | 2001-03-19 A | 2002-03-08 A | 100% | 2001-03-19 | 2002-03-08 | 255d | finish no earlier than 2002-03-08 |  | R4 | 2040h | 2040h | RInImp-CPICH_Intf | Intel | shimon.moshavi@INTEL.COM | Rel-5 | Issam | RInImp-CPICH_Intf |  |  |  |
| 4723 | 78.8 | **Deleted - Conformance Test Spec. improvements in Radio Interface** | 140d | 2002-02-18 A | 2002-08-30 A | 100% | 2002-02-18 | 2002-08-30 | 140d |  |  | T1 | 3360h | 3360h |  |  |  | Rel-5 | Ingbert |  |  |  | TP-17 |
| 4724 | 78.8.1 | Deleted - Testing improvement of inter-frequency and inter-system measurement | 140d | 2002-02-18 A | 2002-08-30 A | 100% | 2002-02-18 | 2002-08-30 | 140d | finish no earlier than 2002-08-30 |  | T1 | 1120h | 1120h |  |  |  | Rel-5 | Ingbert |  |  |  | TP-17 |
| 4725 | 78.8.2 | Deleted - Testing Hybrid ARQ II/III | 140d | 2002-02-18 A | 2002-08-30 A | 100% | 2002-02-18 | 2002-08-30 | 140d | finish no earlier than 2002-08-30 |  | T1 | 1120h | 1120h |  |  |  | Rel-5 | Ingbert |  |  |  | TP-17 |
| 4726 | 79 | **Rel-5 RAN improvements** | 1561d? | 2001-03-16 A | 2007-03-09 A | 100% | 2001-03-16 | 2007-03-09 | 1561d? |  |  | RP | 49424h | 49424h |  |  |  | Rel-5 |  |  |  |  |  |
| 4727 | 79.1 | **RRM optimization for Iur and Iub** | 318d | 2001-03-16 A | 2002-06-04 A | 100% | 2001-03-16 | 2002-06-04 | 318d |  |  | R3 | 8904h | 8904h | RANimp-RRMopt | Ericsson | Gert-Jan.van.Lieshout@eln.ericsson.se | Rel-5 | Juha | RANimp-RRMopt |  |  |  |
| 4728 | 79.1.1 | Iur common transport channel efficiency optimization | 271d | 2001-03-16 A | 2002-03-29 A | 100% | 2001-03-16 | 2002-03-29 | 271d | finish no earlier than 2002-03-29 |  | R3 | 2168h | 2168h | RANimp-RRMopt-ctc | Ericsson | Shahrokh Amirijoo | Rel-5 | Juha | RANimp-RRMopt-ctc |  |  |  |
| 4729 | 79.1.2 | Iur neighbouring cell reporting efficiency optimization | 271d | 2001-03-16 A | 2002-03-29 A | 100% | 2001-03-16 | 2002-03-29 | 271d | finish no earlier than 2002-03-29 |  | R3 | 2168h | 2168h | RANimp-RRMopt-ncr | Ericsson | Shahrokh Amirijoo | Rel-5 | Juha | RANimp-RRMopt-ncr |  |  |  |
| 4730 | 79.1.3 | FS Introduction of direct transport bearers between SRNC and Node-B | 253d | 2001-06-15 A | 2002-06-04 A | 100% | 2001-06-15 | 2002-06-04 | 253d | finish no earlier than 2002-06-28 |  | R3 | 2024h | 2024h | RAN-imp-RRMopt-DTB | Ericsson | Risto Sepponen | Rel-5 | Juha | RAN-imp-RRMopt-DTB |  |  |  |
| 4731 | 79.2 | RL Timing Adjustment | 271d | 2001-03-16 A | 2002-03-29 A | 100% | 2001-03-16 | 2002-03-29 | 271d | finish no earlier than 2002-03-29 |  | R3 | 2168h | 2168h | RANimp-RLTA | Ericsson | Elena Voltolina | Rel-5 | Juha | RANimp-RLTA |  |  |  |
| 4732 | 79.3 | Separation of resource reservation and radio link activation | 271d | 2001-03-16 A | 2002-03-29 A | 100% | 2001-03-16 | 2002-03-29 | 271d | finish no earlier than 2002-03-29 |  | R3 | 2168h | 2168h | RANimp-SepRR | Ericsson | Gert-Jan.van.Lieshout@eln.ericsson.se | Rel-5 | Juha | RANimp-SepRR |  |  |  |
| 4733 | 79.4 | FS SRNS Relocation Procedure Enhancement | 318d | 2001-06-15 A | 2002-09-03 A | 100% | 2001-06-15 | 2002-09-03 | 318d | finish no earlier than 2002-09-06 |  | R3 | 2544h | 2544h | RANimp-SRNS | Nokia | Olivier Guyot | Rel-5 | Juha | RANimp-SRNS |  |  |  |
| 4734 | 79.5 | FS Improvement of Radio Resource Management across RNS and RNS/PSS | 201d | 2001-03-16 A | 2001-12-21 A | 100% | 2001-03-16 | 2001-12-21 | 201d | finish no earlier than 2001-12-21 |  | R3 | 1608h | 1608h | RANimp-ImpRRM | Nokia | antti.toskala@nokia.com | Rel-5 | Juha | RANimp-ImpRRM |  |  |  |
| 4735 | 79.6 | Re-arrangements of Iub transport bearers | 271d | 2001-03-16 A | 2002-03-29 A | 100% | 2001-03-16 | 2002-03-29 | 271d | finish no earlier than 2002-03-29 |  | R3 | 2168h | 2168h | RANimp-TTPS | Nokia | antti.toskala@nokia.com | Rel-5 | Juha | RANimp-TTPS |  |  |  |
| 4736 | 79.7 | RAB support enhancement for Rel-5 | 325d | 2001-04-02 A | 2002-06-28 A | 100% | 2001-04-02 | 2002-06-28 | 325d |  |  | R2 | 2600h | 2600h | RANimp-RABSE5 | Nokia | Juha Mikola | Rel-5 | Yong-Jun | RANimp-RABSE5 |  |  |  |
| 4737 | 16.5.1 | Testing of ROHC performance | 391d | 2005-09-09 A | 2007-03-09 A | 100% | 2005-09-09 | 2007-03-09 | 391d | finish no earlier than 2007-03-09 | 2006-06-02 | R5 | 3128h | 3128h | RANimp-RABSE5_Test | Nokia | jarkko.hellsten@nokia.com | Rel-5 | Ingbert | RANimp-RABSE5_Test | 34.108, 34.123-1, 34.123-2, 34.123-3 | Fri 11/03/05 |  |
| 4738 | 79.8 | Beamforming requirements for UE | 61d | 2001-09-21 A | 2001-12-14 A | 100% | 2001-09-21 | 2001-12-14 | 61d | finish no earlier than 2001-12-14 |  | R1 | 488h | 488h | RANimp-BFR-UE | Nokia | Jussi Kähtävä (juha.mikola@nokia.com) | Rel-5 | Patrick | RANimp-BFR-UE |  |  |  |
| 4739 | 79.9 | Support of Site Selection Diversity Transmission in UTRAN | 123d | 2001-12-14 A | 2002-06-04 A | 100% | 2001-12-14 | 2002-06-04 | 123d | finish no earlier than 2002-06-04 |  | R1 | 984h | 984h | RANimp-SSDT | NEC |  | Rel-5 | Patrick | RANimp-SSDT |  |  |  |
| 4740 | 79.10 | Node B Synchronisation for 1.28 Mcps TDD | 271d | 2001-03-16 A | 2002-03-29 A | 100% | 2001-03-16 | 2002-03-29 | 271d | finish no earlier than 2002-03-29 |  | R1 | 2168h | 2168h | RANimp-NBSLCR | CATT | Jinling HU | Rel-5 | Patrick | RANimp-NBSLCR |  |  |  |

Notes:
- 4706: -
- 4707: -
- 4708: -
- 4709: -
- 4710: -
- 4711: -
- 4712: -
- 4713: -
- 4714: -
- 4715: -
- 4716: -
- 4717: -
- 4718: Stopped at RP#14; work on this task was performed as part of High Speed Downlink Packet Access feature
- 4719: -
- 4720: -
- 4721: -
- 4722: -
- 4723: Marked as stopped 12/2008
- 4724: Marked as stopped 12/2008
- 4725: Marked as stopped 12/2008
- 4726: -
- 4727: -
- 4728: -
- 4729: -
- 4730: FS was closed and introduction of WI not agreed at RAN #16
- 4731: -
- 4732: -
- 4733: -
- 4734: FS was closed and WI was introduced at RAN #14
- 4735: -
- 4736: RFC 3095 context relocation
- 4737: -
- 4738: -
- 4739: RP-020356
- 4740: -

| ID | WBS | Task | Duration | Start | Finish | Complete | Baseline start | Baseline finish | Baseline duration | Constraint | Deadline | Resources | Work | Actual work | Release | MCC resp | TSG stopped | Acronym | Impacted TSs and TRs | Acronym_3GU_Export | WI rapporteur name | WI rapporteur e-mail | Created at |
| --- | --- | --- | --- | --- | --- | --- | --- | --- | --- | --- | --- | --- | --- | --- | --- | --- | --- | --- | --- | --- | --- | --- | --- |
| 4741 | 79.12 | **Deleted - Conformance Test Aspects - RAN Improvements** | 565d? | 2002-01-01 A | 2004-03-01 A | 100% | 2002-01-01 | 2004-03-01 | 565d? |  |  | T1 | 8008h | 8008h | Rel-5 | Ingbert | TP-23 |  |  |  |  |  |  |
| 4742 | 79.12.1 | Deleted - Testing Radio access bearer support enhancements | 175d | 2002-01-01 A | 2002-09-02 A | 100% | 2002-01-01 | 2002-09-02 | 175d | finish no earlier than 2002-09-02 |  | T1 | 1400h | 1400h | Rel-5 | Ingbert | TP-17 |  |  |  |  |  |  |
| 4743 | 1202.12.2 | Deleted - General changes to TS34.121 and TS34.122 corresponding to release 5 | 261d? | 2003-03-03 A | 2004-03-01 A | 100% | 2003-03-03 | 2004-03-01 | 261d? | finish no earlier than 2004-03-01 |  | T1 | 2088h | 2088h | Rel-5 | Ingbert | TP-23 | RANimp-test,TEI5 | 34.108, 34.121, 34.122 | RANimp-test, TEI5 |  |  |  |
| 4744 | 80 | UTRAN Sharing in Connected Mode | 197d | 2001-12-03 A | 2002-09-03 A | 100% | 2001-12-03 | 2002-09-03 | 197d | finish no earlier than 2002-09-06 |  | R3 | 1576h | 1576h | Rel-5 | Juha |  | NETSHARE |  | NETSHARE | Ericsson | Martin Israelsson |  |
| 4745 | 81 | **Provisioning of IP-based multimedia services** | 1806d | 2000-01-03 A | 2006-12-01 A | 100% | 2000-01-03 | 2006-12-01 | 1806d |  |  | S1; S2; S3; S5; NP; T3; T1; R5 | 325092h | 325092h | Rel-5 | Alain |  | IMS |  | IMS | Openwave | Mark Cataldo |  |
| 4746 | 81.1 | **Call control and roaming to support IMS in UMTS** | 1806d | 2000-01-03 A | 2006-12-01 A | 100% | 2000-01-03 | 2006-12-01 | 1806d |  |  | S2; R5 | 109760h | 109760h | Rel-5 | Maurice |  | IMS-CCR |  | IMS-CCR | Lucent | Liz Daniel |  |
| 4747 | 81.1.1 | Stage 1 for Call control and roaming to support IMS in UMTS | 215d | 2000-02-21 A | 2000-12-15 A | 100% | 2000-02-21 | 2000-12-15 | 215d | finish no earlier than 2000-09-21 |  | S1 | 1720h | 1720h | Rel-5 | Alain |  |  | 22.228 |  | Motorola | Mark Cataldo |  |
| 4748 | 81.1.2 | Stage 2 (Architecture and Main flows) | 246d | 2000-04-14 A | 2001-03-23 A | 100% | 2000-04-14 | 2001-03-23 | 246d | finish no earlier than 2001-03-23 |  | S2 | 1968h | 1968h | Rel-5 | Maurice |  |  | 23.228 |  | Lucent | Liz Daniel |  |
| 4749 | 81.1.3 | Impact on MM/CC/SM | 400d | 2000-08-28 A | 2002-03-08 A | 100% | 2000-08-28 | 2002-03-08 | 400d | finish no earlier than 2002-03-08 |  | N1 | 3200h | 3200h | Rel-5 | Frederic |  | IMS-CCR-IWMM |  | IMS-CCR-IWMM | Lucent | Keith Drage (drage@alcatel-lucent.com) |  |
| 4750 | 81.1.4 | **SIP Call Control protocol for the IMS** | 385d | 2000-10-02 A | 2002-03-22 A | 100% | 2000-10-02 | 2002-03-22 | 385d |  |  | N1 | 12320h | 12320h | Rel-5 | Frederic |  |  | 24.228, 24.229, 23.218 |  | Lucent | Keith Drage (drage@alcatel-lucent.com) |  |
| 4751 | 81.1.4.1 | IMS signalling flows | 385d | 2000-10-02 A | 2002-03-22 A | 100% | 2000-10-02 | 2002-03-22 | 385d | finish no earlier than 2002-03-22 |  | N1 | 3080h | 3080h | Rel-5 | Frederic |  |  | 24.228 |  |  |  |  |
| 4752 | 81.1.4.2 | IMS stage 3 | 385d | 2000-10-02 A | 2002-03-22 A | 100% | 2000-10-02 | 2002-03-22 | 385d | finish no earlier than 2002-03-22 |  | N1 | 3080h | 3080h | Rel-5 | Frederic |  |  | 24.229 |  |  |  |  |
| 4753 | 81.1.4.3 | IMS Session Handling; stage 2 | 385d | 2000-10-02 A | 2002-03-22 A | 100% | 2000-10-02 | 2002-03-22 | 385d | finish no earlier than 2002-03-22 |  | N1 | 3080h | 3080h | Rel-5 | Frederic |  |  | 23.218 |  |  |  |  |
| 4754 | 16.5.1 | Conformance Test Aspects – IMS Call Control | 451d | 2005-03-11 A | 2006-12-01 A | 100% | 2005-03-11 | 2006-12-01 | 451d |  | 2006-06-02 | R5 | 3608h | 3608h | Rel-5 | Ingbert |  | IMS-CCR_Test | 34.108, 34.229-1, 34.229-2, 34.229-3 | IMS-CCR_Test | Motorola | Jacob.John@motorola.com | Fri 11/03/05 |
| 4755 | 81.1.4.4 | **Main IETF dependencies** | 641d | 2000-01-03 A | 2002-06-14 A | 100% | 2000-01-03 | 2002-06-14 | 641d |  |  | NP | 58048h | 58048h | Rel-5 | Kimmo |  |  |  |  | Lucent |  |  |
| 4756 | 81.1.4.4.1 | IETF: RFC 3261 (Session Initiation Protocol) | 346d | 2000-11-24 A | 2002-03-22 A | 100% | 2000-11-24 | 2002-03-22 | 346d | finish no earlier than 2002-03-22 |  | N1 | 2768h | 2768h | Rel-5 | Frederic |  |  |  |  | Lucent |  |  |
| 4757 | 81.1.4.4.2 | IETF: RFC 3262 (Reliability of provisional responses) | 346d | 2000-11-24 A | 2002-03-22 A | 100% | 2000-11-24 | 2002-03-22 | 346d | finish no earlier than 2002-03-22 |  | N1 | 2768h | 2768h | Rel-5 | Frederic |  |  |  |  | Lucent |  |  |
| 4758 | 81.1.4.4.3 | IETF: RFC 3312 (Without COMET)(Integration of resource management and SIP) | 382d | 2000-11-24 A | 2002-05-13 A | 100% | 2000-11-24 | 2002-05-13 | 382d | finish no earlier than 2002-05-13 |  | N1 | 3056h | 3056h | Rel-5 | Frederic |  |  |  |  | Lucent |  |  |
| 4759 | 81.1.4.4.4 | IETF: RFC 3323 (SIP extensions for caller identity and privacy) | 382d | 2000-11-24 A | 2002-05-13 A | 100% | 2000-11-24 | 2002-05-13 | 382d | finish no earlier than 2002-05-13 |  | N1 | 3056h | 3056h | Rel-5 | Frederic |  |  |  |  | Lucent |  |  |
| 4760 | 81.1.4.4.5 | IETF: RFC 3313 (SIP extensions for media authorization) | 382d | 2000-11-24 A | 2002-05-13 A | 100% | 2000-11-24 | 2002-05-13 | 382d | finish no earlier than 2002-05-13 |  | N1 | 3056h | 3056h | Rel-5 | Frederic |  |  |  |  | Lucent |  |  |
| 4761 | 81.1.4.4.6 | IETF: RFC 3265 (specific event notification) | 346d | 2000-11-24 A | 2002-03-22 A | 100% | 2000-11-24 | 2002-03-22 | 346d | finish no earlier than 2002-03-22 |  | N1 | 2768h | 2768h | Rel-5 | Frederic |  |  |  |  | Lucent |  |  |
| 4762 | 81.1.4.4.7 | IETF: RFC editor Queue (refer method) | 401d | 2000-11-24 A | 2002-06-07 A | 100% | 2000-11-24 | 2002-06-07 | 401d | finish no earlier than 2002-06-07 |  | N1 | 3208h | 3208h | Rel-5 | Frederic |  |  |  |  | Lucent |  |  |
| 4763 | 81.1.4.4.8 | IETF: RFC editor Queue (DHCP options for SIP servers) | 382d | 2000-11-24 A | 2002-05-13 A | 100% | 2000-11-24 | 2002-05-13 | 382d | finish no earlier than 2002-05-13 |  | N1 | 3056h | 3056h | Rel-5 | Frederic |  |  |  |  | Lucent |  |  |
| 4764 | 81.1.4.4.10 | IETF: RFC 3267 (AMR and AMR WB RTP and SDP) | 346d | 2000-11-24 A | 2002-03-22 A | 100% | 2000-11-24 | 2002-03-22 | 346d | finish no earlier than 2002-03-22 |  | N1 | 2768h | 2768h | Rel-5 | Frederic |  |  |  |  | Lucent |  |  |
| 4765 | 81.1.4.4.11 | IETF: RFC 3266 (IPv6 support within SDP) | 581d | 2000-01-03 A | 2002-03-22 A | 100% | 2000-01-03 | 2002-03-22 | 581d | finish no earlier than 2002-03-22 |  | N1 | 4640h | 4640h | Rel-5 | Frederic |  |  |  |  | Lucent |  |  |
| 4766 | 81.1.4.4.12 | IETF: RFC 3311 (The Update method) | 382d | 2000-11-24 A | 2002-05-13 A | 100% | 2000-11-24 | 2002-05-13 | 382d | finish no earlier than 2002-05-13 |  | N1 | 3056h | 3056h | Rel-5 | Frederic |  |  |  |  | Lucent |  |  |
| 4767 | 81.1.4.4.13 | IETF: RFC 3324 (Network Asserted Identity) | 382d | 2000-11-24 A | 2002-05-13 A | 100% | 2000-11-24 | 2002-05-13 | 382d | finish no earlier than 2002-05-13 |  | N1 | 3056h | 3056h | Rel-5 | Frederic |  |  |  |  | Lucent |  |  |
| 4768 | 81.1.4.4.14 | IETF: RFC editor Queue (Various 3GPP Private Extensions) | 382d | 2000-11-24 A | 2002-05-13 A | 100% | 2000-11-24 | 2002-05-13 | 382d | finish no earlier than 2002-05-13 |  | N1 | 3056h | 3056h | Rel-5 | Frederic |  |  |  |  | Lucent |  |  |

Notes:
- 4741: Marked as stopped 12/2008
- 4742: Marked as stopped 12/2008
- 4743: Marked as stopped 12/2008
- 4744: Formerly 'Shared Network support in connected mode', renamed at RAN #16.
- 4745: -
- 4746: -
- 4747: Issues include e.g.: Roaming requirements, Requirements on supplementary services, Interworking requirements
- 4748: Issues include e.g.: Mobile IP, RAB selection principles, Optimized VoIP bearer mechanisms, SIP multimedia protocol
- 4749: Per 26/2-02: This is understood to be the PCO & TFT CRs which CN1 provides to TSGN #15 for approval. If this is correct understanding, then the task is 100 % complete.
- 4750: TSGN_10 approved the change:CN1 - SA2 SIP joint meeting spotted one more place for improvement: work tasks with ID 1998 and 1278 are actually subtasks under of single CN1 WT. One WI has been approved for the CN1 WT with title "SIP Call Control protocol
- 4751: 24.228
- 4752: 24.229
- 4753: 23.218
- 4754: -
- 4755: -
- 4756: -
- 4757: -
- 4758: -
- 4759: -
- 4760: -
- 4761: -
- 4762: -
- 4763: -
- 4764: -
- 4765: -
- 4766: -
- 4767: -
- 4768: -

| ID | WBS | Task | Duration | Start | Finish | Complete | Baseline start | Baseline finish | Baseline duration | Constraint | Resources | Work | Actual work | Release | MCC resp | Acronym | Impacted TSs and TRs | WI rapporteur name | WI rapporteur e-mail | Acronym_3GU_Export | TSG stopped |
| --- | --- | --- | --- | --- | --- | --- | --- | --- | --- | --- | --- | --- | --- | --- | --- | --- | --- | --- | --- | --- | --- |
| 4769 | 81.1.4.5 | **Addressing** | 380d | 2000-10-09 A | 2002-03-22 A | 100% | 2000-10-09 | 2002-03-22 | 380d |  | S2 | 7744h | 7744h | Rel-5 | Maurice |  |  |  |  |  |  |
| 4770 | 81.1.4.5.1 | Architectural issues | 235d | 2000-10-09 A | 2001-08-31 A | 100% | 2000-10-09 | 2001-08-31 | 235d | finish no earlier than 2001-03-16 | S2 | 1880h | 1880h | Rel-5 | Maurice |  |  |  |  |  |  |
| 4771 | 81.1.4.5.2 | Impact on HSS | 353d | 2000-11-15 A | 2002-03-22 A | 100% | 2000-11-15 | 2002-03-22 | 353d | finish no earlier than 2002-03-22 | N4 | 2824h | 2824h | Rel-5 | Kimmo |  |  |  |  |  |  |
| 4772 | 81.1.4.6 | **Service Examples (Work stopped)** | 304d | 2001-04-17 A | 2002-06-14 A | 100% | 2001-04-17 | 2002-06-14 | 304d |  | S1 | 4864h | 4864h | Rel-5 | Alain | IMS-Sex | 22.928 | Motorola | Mark Cataldo | IMS-Sex |  |
| 4773 | 81.1.4.6.1 | IMS Framework Report (work stopped) | 304d | 2001-04-17 A | 2002-06-14 A | 100% | 2001-04-17 | 2002-06-14 | 304d | finish no earlier than 2002-06-14 | S1 | 2432h | 2432h | Rel-5 | Alain | IMS-FrWk | 22.941 | SBC | Randolph Wohlert (rwohlert@tri.sbc.com) | IMS-FrWk |  |
| 4774 | 81.2 | **Access Security for IMS** | 190d | 2001-10-08 A | 2002-06-28 A | 100% | 2001-10-08 | 2002-06-28 | 190d |  | S3; T3 | 5640h | 5640h | Rel-5 | Mirko | IMS-ASEC |  | Ericsson | krister.boman@emw.ericsson.se | IMS-ASEC |  |
| 4775 | 81.2.2 | IMS impacts on UICC (ISIM application) | 185d | 2001-10-08 A | 2002-06-21 A | 100% | 2001-10-08 | 2002-06-21 | 185d | finish no earlier than 2002-06-21 | T3 | 1480h | 1480h | Rel-5 | Xavier |  | 33.102, New TS 31.103 | Vodafone | Jeremy Norris |  |  |
| 4776 | 81.2.3 | Deleted - SIP extensions for Integrity protection | 140d | 2001-12-17 A | 2002-06-28 A | 100% | 2001-12-17 | 2002-06-28 | 140d | finish no earlier than 2002-06-28 | N1 | 1120h | 1120h | Rel-5 | Frederic |  |  |  |  |  | SP-69 |
| 4777 | 81.3 | Security Aspects of Requirement for Network Configuration Independence | 130d | 2001-07-02 A | 2001-12-28 A | 100% | 2001-07-02 | 2001-12-28 | 130d | finish no earlier than 2001-12-28 | S3 | 1040h | 1040h | Rel-5 | Mirko | SEC1-NCI | 33.203 | AT&T Wireless | hugh.shieh@attws.com | SEC1-NCI |  |
| 4778 | 81.4 | IMS Lawful Interception | 410d | 2000-09-04 A | 2002-03-29 A | 100% | 2000-09-04 | 2002-03-29 | 410d | finish no earlier than 2002-03-29 | S3 | 3280h | 3280h | Rel-5 | Mirko | IMS-LI | 33.106, 33.107, New 33.108 | Reg TP | berthold.wilhelm@regtp.de | IMS-LI |  |
| 4779 | 81.5 | Charging and OAM&P for IMS | 383d | 2000-12-25 A | 2002-06-12 A | 100% | 2000-12-25 | 2002-06-12 | 383d | finish no earlier than 2002-06-12 | S5 | 3064h | 3064h | Rel-5 | Mirko | IMS-OAM | 32-series |  |  | IMS-OAM |  |
| 4780 | 81.6 | **Multimedia codecs and protocols for conversational PS services** | 568d | 2000-07-26 A | 2002-09-27 A | 100% | 2000-07-26 | 2002-09-27 | 568d |  | S4 | 15640h | 15640h | Rel-5 | Paolo | IMS-CODEC | 26.235, 26.236 | Toshiba, Nokia | B. Aronson (Toshiba), pasi.s.ojala@nokia.com | IMS-CODEC |  |
| 4781 | 81.6.1 | Codecs | 427d | 2000-07-26 A | 2002-03-14 A | 100% | 2000-07-26 | 2002-03-14 | 427d | finish no earlier than 2001-03-21 | S4 | 3416h | 3416h | Rel-5 | Paolo |  | 26.235, 26.236 |  |  |  |  |
| 4782 | 81.6.2 | Transport protocols | 1d | 2002-03-12 A | 2002-03-12 A | 100% | 2002-03-12 | 2002-03-12 | 1d | finish no earlier than 2002-03-12 | S4 | 8h | 8h | Rel-5 | Paolo |  | 26.236 | Nokia | P. Ojala |  |  |
| 4783 | 81.6.4 | recommendation for QoS parameter values for various media types | 195d | 2001-12-31 A | 2002-09-27 A | 100% | 2001-12-31 | 2002-09-27 | 195d | finish no earlier than 2002-09-27 | S4 | 1560h | 1560h | Rel-5 | Paolo |  |  |  |  |  |  |
| 4784 | 81.6.5 | IETF: RFC 3310 (HTTP Digest Authentication using AKA) | 382d | 2000-11-24 A | 2002-05-13 A | 100% | 2000-11-24 | 2002-05-13 | 382d | finish no earlier than 2002-05-13 | N1 | 3056h | 3056h | Rel-5 | Frederic |  |  |  |  |  |  |
| 4785 | 81.6.6 | IETF: RFC 3329 (Security mechanism agreement for SIP connections) | 382d | 2000-11-24 A | 2002-05-13 A | 100% | 2000-11-24 | 2002-05-13 | 382d | finish no earlier than 2002-05-13 | N1 | 3056h | 3056h | Rel-5 | Frederic |  |  |  |  |  |  |
| 4786 | 81.7 | **SIP message compression** | 185d | 2001-09-24 A | 2002-06-07 A | 100% | 2001-09-24 | 2002-06-07 | 185d |  | S2 | 3128h | 3128h | Rel-5 | Maurice |  |  |  |  |  |  |
| 4787 | 81.7.1 | Stage 2 for SIP message compression | 25d | 2001-09-24 A | 2001-10-26 A | 100% | 2001-09-24 | 2001-10-26 | 25d | finish no earlier than 2001-10-26 | S2 | 200h | 200h | Rel-5 | Maurice |  |  |  |  |  |  |
| 4788 | 81.7.2 | Compression signalling | 181d | 2001-09-28 A | 2002-06-07 A | 100% | 2001-09-28 | 2002-06-07 | 181d | finish no earlier than 2002-06-07 | N1 | 1448h | 1448h | Rel-5 | Frederic |  |  |  |  |  |  |
| 4789 | 81.8 | **Stage 3 description of IMS interfaces** | 383d | 2001-03-14 A | 2002-08-30 A | 100% | 2001-03-14 | 2002-08-30 | 383d |  | NP | 29531.6h | 29531.6h | Rel-5 | Kimmo |  |  |  |  |  |  |
| 4790 | 81.8.1 | Cx interface (HSS to CSCF) | 135.95d | 2001-03-14 A | 2002-06-07 A | 100% | 2001-03-14 | 2002-06-07 | 135.95d | finish no earlier than 2002-06-07 | N4 | 1087.58h | 1087.58h | Rel-5 | Kimmo |  |  |  |  |  |  |
| 4791 | 81.8.2 | Mp interface (MRFC - MRFP) enhancements | 258d | 2001-03-14 A | 2002-03-08 A | 100% | 2001-03-14 | 2002-03-08 | 258d | finish no earlier than 2002-06-07 | N4 | 2064h | 2064h | Rel-5 | Kimmo |  |  |  |  |  |  |
| 4792 | 81.8.3 | Mw interface (CSCF to P-CSCF) | 323d | 2001-03-14 A | 2002-06-07 A | 100% | 2001-03-14 | 2002-06-07 | 323d | finish no earlier than 2002-06-07 | N1 | 2584h | 2584h | Rel-5 | Frederic |  |  |  |  |  |  |
| 4793 | 81.8.4 | Mr interface (CSCF to MRF) | 273d | 2001-03-14 A | 2002-03-29 A | 100% | 2001-03-14 | 2002-03-29 | 273d | finish no earlier than 2002-03-29 | N1 | 2184h | 2184h | Rel-5 | Frederic |  |  |  |  |  |  |
| 4794 | 81.8.5 | Dx interface (I-CSCF to SLF) | 323d | 2001-03-14 A | 2002-06-07 A | 100% | 2001-03-14 | 2002-06-07 | 323d | finish no earlier than 2002-06-07 | N4 | 2584h | 2584h | Rel-5 | Kimmo |  |  |  |  |  |  |
| 4795 | 81.8.6 | Go interface (GGSN to PCF) | 323d | 2001-03-14 A | 2002-06-07 A | 100% | 2001-03-14 | 2002-06-07 | 323d | finish no earlier than 2002-06-07 | N3 | 2584h | 2584h | Rel-5 | Gwiho |  |  |  |  |  |  |
| 4796 | 81.8.7 | ISC (IMS Service Control) Interface | 323d | 2001-03-14 A | 2002-06-07 A | 100% | 2001-03-14 | 2002-06-07 | 323d | finish no earlier than 2002-06-07 | N1 | 2584h | 2584h | Rel-5 | Frederic |  |  |  |  |  |  |
| 4797 | 81.8.8 | Sh interface (HSS to AS) | 82d | 2002-02-14 A | 2002-06-07 A | 100% | 2002-02-14 | 2002-06-07 | 82d | finish no earlier than 2002-06-07 | N4 | 656h | 656h | Rel-5 | Kimmo |  |  |  |  |  |  |
| 4798 | 81.8.9 | Si interface (HSS to IM-SSF) | 162.5d | 2002-01-16 A | 2002-08-30 A | 100% | 2002-01-16 | 2002-08-30 | 162.5d | finish no earlier than 2002-06-07 | N4 | 1300h | 1300h | Rel-5 | Kimmo |  |  |  |  |  |  |
| 4799 | 81.8.10 | Gm interface (UE to CSCF) | 323d | 2001-03-14 A | 2002-06-07 A | 100% | 2001-03-14 | 2002-06-07 | 323d | finish no earlier than 2002-06-07 | N1 | 2584h | 2584h | Rel-5 | Frederic |  |  |  |  |  |  |
| 4800 | 81.8.11 | Mi interface (CSCF to BGCF) | 323d | 2001-03-14 A | 2002-06-07 A | 100% | 2001-03-14 | 2002-06-07 | 323d | finish no earlier than 2002-06-07 | N1 | 2584h | 2584h | Rel-5 | Frederic |  |  |  |  |  |  |
| 4801 | 81.8.12 | Mj interface (BGCF to MGCF) | 323d | 2001-03-14 A | 2002-06-07 A | 100% | 2001-03-14 | 2002-06-07 | 323d | finish no earlier than 2002-06-07 | N1 | 2584h | 2584h | Rel-5 | Frederic |  |  |  |  |  |  |
| 4802 | 81.8.13 | Mk interface (BGCF to BGCF) | 323d | 2001-03-14 A | 2002-06-07 A | 100% | 2001-03-14 | 2002-06-07 | 323d | finish no earlier than 2002-06-07 | N1 | 2584h | 2584h | Rel-5 | Frederic |  |  |  |  |  |  |
| 4803 | 81.9 | Support of VHE/OSA by entities and protocols of the IMS (e.g. CSCF) | 186d | 2001-09-21 A | 2002-06-07 A | 100% | 2001-09-21 | 2002-06-07 | 186d | finish no earlier than 2002-06-07 | N5 | 1488h | 1488h | Rel-5 | Kimmo | IMS-ONOSA | 29.198, 29.998 | Ericsson | Ard.Jan.Moerdijk@eln.ericsson.se | IMS-ONOSA |  |

Notes:
- 4769: -
- 4770: -
- 4771: Covered by 29.228 & 29228
- 4772: -
- 4773: -
- 4774: -
- 4775: -
- 4776: CN1 is not aware of any requirements and is not doing anything on this task
- 4777: Consider security aspects in SA2 TS 23.228 clause 4.4 & annex C
- 4778: SP#17 completed
- 4779: -
- 4780: -
- 4781: -
- 4782: -
- 4783: -
- 4784: -
- 4785: -
- 4786: -
- 4787: -
- 4788: -
- 4789: -
- 4790: -
- 4791: [DAB 08-03-02] - No work required in CN4
- 4792: -
- 4793: -
- 4794: CN4#11 30/11/01: No inputs received in CN4 / 14/02/02 Completed(introduced in 29.228)
- 4795: [DAB - 23/05/03] - 100 % complete
- 4796: -
- 4797: CN4#11 30/11/01: No inputs received in CN4 / CN4#12bis 14/02/02: WID approved / 17th May 100% complete. 3GPP TS 29.329 will be sent for approval in CN#16
- 4798: SA16: Part of Rel5 only if completed in September 02. Marked as closed 12/2008 (was marked 72% complete)
- 4799: -
- 4800: -
- 4801: -
- 4802: -
- 4803: -

| ID | WBS | Task | Duration | Start | Finish | Predecessors | Complete | Baseline start | Baseline finish | Baseline duration | Constraint | Resources | Work | Actual work | Acronym | WI rapporteur name | WI rapporteur e-mail | Release | MCC resp | Acronym_3GU_Export | TSG stopped | Impacted TSs and TRs |
| --- | --- | --- | --- | --- | --- | --- | --- | --- | --- | --- | --- | --- | --- | --- | --- | --- | --- | --- | --- | --- | --- | --- |
| 4804 | 81.10 | **CAMEL control of IMS services** | 365d | 2001-04-16 A | 2002-09-06 A |  | 100% | 2001-04-16 | 2002-09-06 | 365d |  | N2 | 9952h | 9952h | IMS-CAMEL | Lucent | Angelica Remoquillo | Rel-5 | Kimmo | IMS-CAMEL |  |  |
| 4805 | 81.10.1 | Stage2 work 'general' | 365d | 2001-04-16 A | 2002-09-06 A |  | 100% | 2001-04-16 | 2002-09-06 | 365d | finish no earlier than 2002-09-06 | N2 | 2920h | 2920h |  |  |  | Rel-5 | Kimmo |  |  |  |
| 4806 | 81.10.2 | Stage3 work 'CAP' | 175d | 2002-01-07 A | 2002-09-06 A |  | 100% | 2002-01-07 | 2002-09-06 | 175d | finish no earlier than 2002-09-06 | N2 | 1400h | 1400h |  |  |  | Rel-5 | Kimmo |  |  |  |
| 4807 | 81.10.3 | Stage2 work 'Si interface' | 175d | 2002-01-07 A | 2002-09-06 A |  | 100% | 2002-01-07 | 2002-09-06 | 175d | finish no earlier than 2002-09-06 | N2 | 1400h | 1400h |  |  |  | Rel-5 | Kimmo |  |  |  |
| 4808 | 81.10.4 | Stage3 work 'Si interface' | 82d | 2002-02-14 A | 2002-06-07 A |  | 100% | 2002-02-14 | 2002-06-07 | 82d | finish no earlier than 2002-06-07 | N4 | 656h | 656h |  |  |  | Rel-5 | Kimmo |  |  |  |
| 4809 | 81.10.5 | Deleted - SDM issues for CAMEL control of IMS | 82d | 2002-02-14 A | 2002-06-07 A |  | 100% | 2002-02-14 | 2002-06-07 | 82d | finish no earlier than 2002-06-07 | N4 | 656h | 656h |  |  |  | Rel-5 | Kimmo |  | NP-17 |  |
| 4810 | 81.11 | Pre-pay/real-time charging in IMS | 196d | 2001-06-15 A | 2002-03-15 A |  | 100% | 2001-06-15 | 2002-03-15 | 196d | finish no earlier than 2002-03-15 | S1 | 1568h | 1568h |  |  |  | Rel-5 | Alain |  |  |  |
| 4811 | 81.12 | **IMS Charging** | 289d | 2001-08-06 A | 2002-09-12 A |  | 100% | 2001-08-06 | 2002-09-12 | 289d |  | S2; S5 | 8944h | 8944h | OAM-CH | T-Mobile | karl-heinz.nenner@t-mobile.de | Rel-5 | Mirko | OAM-CH |  | 32.225 |
| 4812 | 81.12.1 | Charging Implications of IMS architecture | 75d | 2001-08-06 A | 2001-11-16 A |  | 100% | 2001-08-06 | 2001-11-16 | 75d | finish no earlier than 2001-11-16 | S2 | 600h | 600h |  |  |  | Rel-5 | Maurice |  |  |  |
| 4813 | 81.12.2 | Charging management for IMS (off-line & on-line) | 214d | 2001-11-19 A | 2002-09-12 A | 4812 | 100% | 2001-11-19 | 2002-09-12 | 214d | finish no earlier than 2002-09-12 | S5 | 1712h | 1712h |  |  |  | Rel-5 | Mirko |  |  | 32.225 |
| 4814 | 86.1.6.10 | Billing, accounting and call detail record aspects | 251d | 2001-09-27 A | 2002-09-12 A |  | 100% | 2001-09-27 | 2002-09-12 | 251d | finish no earlier than 2002-09-12 | S5 | 2008h | 2008h |  | T-Mobile | Karl-Heinz.Nenner@T-MOBILE.DE | Rel-5 | Mirko |  |  | 32.225 |
| 4815 | 81.13 | **Other IETF dependencies** | 401d | 2000-11-24 A | 2002-06-07 A |  | 100% | 2000-11-24 | 2002-06-07 | 401d |  | NP | 9624h | 9624h |  |  |  | Rel-5 |  |  |  |  |
| 4816 | 81.13.1 | IETF: draft-ietf-aaa-diameter - should be CN4 | 401d | 2000-11-24 A | 2002-06-07 A |  | 100% | 2000-11-24 | 2002-06-07 | 401d | finish no earlier than 2002-06-07 | NP | 3208h | 3208h |  |  |  | Rel-5 |  |  |  |  |
| 4817 | 81.13.2 | IETF: draft-johansson-aaa-diameter-mm-app - should be CN4 | 401d | 2000-11-24 A | 2002-06-07 A |  | 100% | 2000-11-24 | 2002-06-07 | 401d | finish no earlier than 2002-06-07 | NP | 3208h | 3208h |  |  |  | Rel-5 |  |  |  |  |
| 4818 | 81.15 | Conformance Test Aspects - Provisioning of IMS | 205d | 2002-03-18 A | 2002-12-27 A |  | 100% | 2002-03-18 | 2002-12-27 | 205d | finish no earlier than 2002-12-27 | T1 | 1640h | 1640h | IMS-TEST |  |  | Rel-5 | Ingbert | IMS-TEST |  |  |
| 4819 | 81.16 | Testing of support for IMS - prose | 270d | 2002-09-18 A | 2003-09-30 A |  | 100% | 2002-09-18 | 2003-09-30 | 270d | finish no earlier than 2003-09-30 | T1 | 2160h | 2160h |  | Anritsu | dan.fox@eu.anritsu.com | Rel-5 | Ingbert |  |  | 34.108, 34.123 |
| 4820 | 81.17 | Testing of support for IMS - TTCN | 381d | 2002-09-18 A | 2004-03-03 A |  | 100% | 2002-09-18 | 2004-03-03 | 381d | finish no earlier than 2004-03-03 | T1 | 3048h | 3048h |  | Anritsu | dan.fox@eu.anritsu.com | Rel-5 | Ingbert |  |  | 34.108, 34.123 |
| 4821 | 82 | **Extended Transparent End-to-End PS Streaming Service** | 313d? | 2002-01-03 A | 2003-03-17 A |  | 100% | 2002-01-03 | 2003-03-17 | 313d? |  | S4 | 6224h | 6224h | PSS-E | Ericsson | olle.franceschi@ericsson.com | Rel-5 | Paolo | PSS-E |  | 26.233, 26.234 |
| 4822 | 82.1 | **Stage 1 for Extended Transparent End-to-End PS Streaming Service** | 86d? | 2002-11-18 A | 2003-03-17 A |  | 100% | 2002-11-18 | 2003-03-17 | 86d? |  | S1 | 1376h | 1376h |  | Vodafone | stephen.wolak@vodafone.com | Rel-5 | Alain |  |  | 22.233 |
| 4823 | 1205.1.1 | Interaction with other services | 86d? | 2002-11-18 A | 2003-03-17 A |  | 100% | 2002-11-18 | 2003-03-17 | 86d? | finish no earlier than 2003-03-17 | S1 | 688h | 688h |  | Vodafone | stephen.wolak@vodafone.com | Rel-5 | Alain |  |  | 22.233 |
| 4824 | 82.2 | Stage 2 (version Rel-5 of TS 26.234) | 51d | 2002-01-03 A | 2002-03-14 A |  | 100% | 2002-01-03 | 2002-03-14 | 51d | finish no earlier than 2002-03-26 | S4 | 408h | 408h |  |  |  | Rel-5 | Paolo |  |  | 26.234 |
| 4825 | 82.3 | RTP usage model | 242d | 2002-01-03 A | 2002-12-06 A |  | 100% | 2002-01-03 | 2002-12-06 | 242d | finish no earlier than 2002-12-06 | S4 | 1936h | 1936h |  |  |  | Rel-5 | Paolo |  |  | 26.937 |
| 4826 | 83 | **Rel-5 Open Service Access (OSA) enhancements** | 955d | 1999-04-27 A | 2002-12-20 A |  | 100% | 1999-04-27 | 2002-12-20 | 955d |  | S1; S3 | 72648h | 72648h | OSA1 | Siemens | joerg.swetina@neclab.eu | Rel-5 | Alain | OSA1 |  | 22.127, 23.127, 29.198-x, 29.998-x |
| 4827 | 83.1 | General Stage 2 for Rel-5 | 194d | 2001-09-11 A | 2002-06-07 A |  | 100% | 2001-09-11 | 2002-06-07 | 194d |  | S2 | 1232h | 1232h |  |  |  | Rel-5 | Maurice |  |  |  |

Notes:
- 4804: -
- 4805: DAB 12.12.01 split into cn4 and cn2 parts
- 4806: DAB 12.12.01 split into cn4 and cn2 parts
- 4807: DAB 12.12.01 split into cn4 and cn2 parts
- 4808: [DAB 08-03-02] - UID 12004 is MASTER of UID 14998 / 17 May need to be recearch possible impact on 23.008 & 23.016, changes to 29.002 are done.
- 4809: Marked as stopped 12/2008
- 4810: Marked as closed 12/2008 (was marked 60% complete)
- 4811: -
- 4812: -
- 4813: -
- 4814: -
- 4815: Was introduced at SP#13 by Ileana Leuca (exact position in the WP and related WG have to be defined)
- 4816: Marked as closed 12/2008 (was marked 90% complete)
- 4817: Marked as closed 12/2008 (was marked 50% complete)
- 4818: The task is a BB, individual work items were considered but are constrained by lack of supporting companies. Marked as stopped 12/2008
- 4819: Marked as stopped 12/2008
- 4820: Marked as stopped 12/2008
- 4821: -
- 4822: 2nd resp SA4
- 4823: 2nd resp SA4. Marked as closed 12/2008 (was marked 65% complete)
- 4824: 2nd resp SA2
- 4825: Marked as closed 12/2008 (was marked 90% complete)
- 4826: -
- 4827: Marked as closed 12/2008 (was marked 47% complete)

| ID | WBS | Task | Duration | Start | Finish | Predecessors | Complete | Baseline start | Baseline finish | Baseline duration | Constraint | Resources | Work | Actual work | Acronym | Release | MCC resp | Acronym_3GU_Export | Impacted TSs and TRs | WI rapporteur name | WI rapporteur e-mail |
| --- | --- | --- | --- | --- | --- | --- | --- | --- | --- | --- | --- | --- | --- | --- | --- | --- | --- | --- | --- | --- | --- |
| 4828 | 83.2 | **OSA APIs for Multimedia Call Control** | 499d | 2000-07-11 A | 2002-06-07 A |  | 100% | 2000-07-11 | 2002-06-07 | 499d |  | S2 | 5960h | 5960h | OSA1-CSCF | Rel-5 | Maurice | OSA1-CSCF |  |  |  |
| 4829 | 83.2.1 | Stage 1 for OSA APIs for Multimedia Call Control | 438d | 2000-07-11 A | 2002-03-14 A |  | 100% | 2000-07-11 | 2002-03-14 | 438d | finish no earlier than 2002-03-14 | S1 | 3504h | 3504h |  | Rel-5 | Alain |  | 22.127 | Siemens | Manfred.leitgeb@siemens.at |
| 4830 | 83.2.2 | Stages 2 and 3 for Multimedia Call Control | 194d | 2001-09-11 A | 2002-06-07 A |  | 100% | 2001-09-11 | 2002-06-07 | 194d | finish no earlier than 2002-06-07 | N5 | 1552h | 1552h |  | Rel-5 | Kimmo |  | 29.198-04 |  |  |
| 4831 | 83.3 | Generic user interaction - Stage 3 | 194d | 2001-09-11 A | 2002-06-07 A |  | 100% | 2001-09-11 | 2002-06-07 | 194d | finish no earlier than 2002-06-07 | N5 | 1552h | 1552h |  | Rel-5 | Kimmo |  | 29.198-05 |  |  |
| 4832 | 83.4 | OSA Charging - Stage 3 | 194d | 2001-09-11 A | 2002-06-07 A |  | 100% | 2001-09-11 | 2002-06-07 | 194d | finish no earlier than 2002-06-07 | N5 | 1552h | 1552h |  | Rel-5 | Kimmo |  | 29.198-12 |  |  |
| 4833 | 83.5 | Call Control Service Mapping; Multiparty Call Control SIP - Stage 3 | 194d | 2001-09-11 A | 2002-06-07 A |  | 100% | 2001-09-11 | 2002-06-07 | 194d | finish no earlier than 2002-06-07 | N5 | 1552h | 1552h |  | Rel-5 | Kimmo |  | 29.998-04-4 |  |  |
| 4834 | 83.6 | WSDL APIs for SOAP/HTTP - Stage 3 | 455d | 2000-09-11 A | 2002-06-07 A |  | 100% | 2000-09-11 | 2002-06-07 | 455d | finish no earlier than 2002-06-07 | N5 | 3640h | 3640h |  | Rel-5 | Kimmo |  | 29.198, 29.998 |  |  |
| 4835 | 83.7 | **OSA Security** | 639d | 2000-07-11 A | 2002-12-20 A |  | 100% | 2000-07-11 | 2002-12-20 | 639d |  | S3 | 15000h | 15000h | OSA1-SEC | Rel-5 | Mirko | OSA1-SEC | 33.102 | Ericsson | colin.blanchard@bt.com |
| 4836 | 83.7.1 | Stage 1 for OSA Security | 349d | 2000-07-11 A | 2001-11-09 A |  | 100% | 2000-07-11 | 2001-11-09 | 349d | finish no earlier than 2001-11-09 | S1 | 2792h | 2792h |  | Rel-5 | Alain |  | 22.127 | Siemens | Manfred.leitgeb@siemens.at |
| 4837 | 83.7.2 | OSA Stage 3 | 430d | 2000-10-23 A | 2002-06-14 A |  | 100% | 2000-10-23 | 2002-06-14 | 430d | finish no earlier than 2002-06-14 | S3 | 3440h | 3440h |  | Rel-5 | Mirko |  | 33.102 | BT, Ericsson | colin.blanchard@bt.com |
| 4838 | 83.7.3 | security related SCF(s) definition | 186d | 2001-09-21 A | 2002-06-07 A |  | 100% | 2001-09-21 | 2002-06-07 | 186d | finish no earlier than 2002-06-07 | N5 | 1488h | 1488h |  | Rel-5 | Kimmo |  | 29.198, 29.998 | Ericsson | Ard.Jan.Moerdijk@eln.ericsson.se |
| 4839 | 83.7.4 | OSA changes required from supporting platforms, e.g. gsmSCF, HLR | 69d | 2000-09-11 A | 2000-12-14 A |  | 100% | 2000-09-11 | 2000-12-14 | 69d | finish no earlier than 2000-12-14 | S3 | 552h | 552h |  | Rel-5 | Mirko |  | 33.102 | BT, Ericsson | colin.blanchard@bt.com |
| 4840 | 1206.7.5 | OSA Security (moved from Rel-6) | 202d | 2002-03-14 A | 2002-12-20 A |  | 100% | 2002-03-14 | 2002-12-20 | 202d | finish no earlier than 2002-12-20 | S3 | 1616h | 1616h |  | Rel-5 | Mirko |  | 33.102 | BT, Ericsson | colin.blanchard@bt.com |
| 4841 | 83.8 | **Interactions OSA - e-commerce** | 815d | 1999-04-27 A | 2002-06-07 A |  | 100% | 1999-04-27 | 2002-06-07 | 815d |  | S2 | 6152h | 6152h | OSA1-ECOM | Rel-5 | Maurice | OSA1-ECOM |  |  |  |
| 4842 | 83.8.1 | Stage 1 for Interactions OSA - e-commerce | 439d | 1999-04-27 A | 2000-12-28 A |  | 100% | 1999-04-27 | 2000-12-28 | 439d | finish no earlier than 2000-12-28 | S1 | 3504h | 3504h |  | Rel-5 | Alain |  | 22.127 | Siemens | joerg.swetina@neclab.eu |
| 4843 | 83.8.2 | Stages 2 and 3 for Interactions OSA - e-commerce | 186d | 2001-09-21 A | 2002-06-07 A |  | 100% | 2001-09-21 | 2002-06-07 | 186d | finish no earlier than 2002-06-07 | N5 | 1488h | 1488h |  | Rel-5 | Kimmo |  | 29.198, 29.998 | Ericsson | Ard.Jan.Moerdijk@eln.ericsson.se |
| 4844 | 83.9 | Policy Management - Stage 3 | 194d | 2001-09-11 A | 2002-06-07 A |  | 100% | 2001-09-11 | 2002-06-07 | 194d | finish no earlier than 2002-06-07 | N5 | 1552h | 1552h |  | Rel-5 | Kimmo |  | 29.198-13 |  |  |
| 4845 | 83.10 | Presence and Availability Management (PAM) - Stage 3 | 194d | 2001-09-11 A | 2002-06-07 A |  | 100% | 2001-09-11 | 2002-06-07 | 194d | finish no earlier than 2002-06-07 | N5 | 1552h | 1552h |  | Rel-5 | Kimmo |  | 29.198-14 |  |  |
| 4846 | 83.11 | **LCS - OSA interfaces** | 455d | 2000-09-11 A | 2002-06-07 A |  | 100% | 2000-09-11 | 2002-06-07 | 455d |  | S1 | 5656h | 5656h | OSA1-LCSI | Rel-5 | Alain | OSA1-LCSI |  | Siemens | joerg.swetina@neclab.eu |
| 4847 | 83.11.1 | Stage 1 for LCS - OSA interfaces | 65d | 2000-09-11 A | 2000-12-08 A |  | 100% | 2000-09-11 | 2000-12-08 | 65d | finish no earlier than 2000-12-08 | S1 | 520h | 520h |  | Rel-5 | Alain |  | 22.127 | Siemens | joerg.swetina@neclab.eu |
| 4848 | 83.11.2 | Stage 2 for LCS - OSA interfaces | 1d | 2000-12-11 A | 2000-12-11 A | 4847 | 100% | 2000-12-11 | 2000-12-11 | 1d | finish no earlier than 2000-12-11 | S2 | 8h | 8h |  | Rel-5 | Maurice |  | 23.127 | Ericsson | Christophe GOURRAUD |
| 4849 | 83.11.3 | Stage 3 for LCS - OSA interfaces | 186d | 2001-09-21 A | 2002-06-07 A | 4848 | 100% | 2001-09-21 | 2002-06-07 | 186d | finish no earlier than 2002-06-07 | N5 | 1488h | 1488h |  | Rel-5 | Kimmo |  | 29.198, 29.998 | Ericsson | Ard.Jan.Moerdijk@eln.ericsson.se |
| 4850 | 1206.12 | Access to User Profile | 145d | 2001-06-01 A | 2001-12-20 A |  | 100% | 2001-06-01 | 2001-12-20 | 145d | finish no earlier than 2001-12-20 | S1 | 1160h | 1160h | OSA2-UP | Rel-5 | Alain | OSA2-UP |  |  |  |
| 4851 | 1206.13 | **Retrieval of Terminal capabilities** | 634d | 2000-07-11 A | 2002-12-13 A |  | 100% | 2000-07-11 | 2002-12-13 | 634d |  | S2 | 10808h | 10808h | OSA2-TC | Rel-5 | Maurice | OSA2-TC |  |  |  |
| 4852 | 1206.13.1 | Stage 1 for Retrieval of Terminal capabilities | 132d | 2000-07-11 A | 2001-01-10 A |  | 100% | 2000-07-11 | 2001-01-10 | 132d | finish no earlier than 2001-01-10 | S1 | 1056h | 1056h |  | Rel-5 | Alain |  | 22.127 | Siemens | joerg.swetina@neclab.eu |
| 4853 | 1206.13.2 | Stages 2 and 3 for Retrieval of Terminal capabilities | 321d | 2001-09-21 A | 2002-12-13 A | 4852 | 100% | 2001-09-21 | 2002-12-13 | 321d | finish no earlier than 2002-12-13 | N5 | 2568h | 2568h |  | Rel-5 | Kimmo |  | 29.198, 29.998 | Ericsson | Ard.Jan.Moerdijk@eln.ericsson.se |
| 4854 | 1206.13.3 | Provisioning of the terminal capabilities | 445d | 2001-04-02 A | 2002-12-13 A |  | 100% | 2001-04-02 | 2002-12-13 | 445d | finish no earlier than 2002-12-13 | T2 | 3560h | 3560h |  | Rel-5 |  |  | 23.057 |  |  |

Notes:
- 4828: For Rel5 even if completed by March
- 4829: -
- 4830: -
- 4831: -
- 4832: -
- 4833: -
- 4834: -
- 4835: SP#8 approved WID
- 4836: -
- 4837: SP#8 approved WID
- 4838: -
- 4839: SP#8 approved WID
- 4840: SP#8 approved WID
- 4841: -
- 4842: Marked as closed 12/2008 (was marked 95% complete)
- 4843: -
- 4844: -
- 4845: -
- 4846: az: CN#13 - changed to Rel5
- 4847: -
- 4848: az 24/05/01: Rel4 completion 90->100%.
- 4849: -
- 4850: -
- 4851: -
- 4852: -
- 4853: -
- 4854: According to T2 SWG1 M. Cataldo this is automatically supported by the MExE support of UAProf therefore 100% complete

| ID | WBS | Task | Duration | Start | Finish | Predecessors | Complete | Baseline start | Baseline finish | Baseline duration | Constraint | Resources | Work | Actual work | Acronym | WI rapporteur name | WI rapporteur e-mail | Release | MCC resp | Acronym_3GU_Export | Impacted TSs and TRs |
| --- | --- | --- | --- | --- | --- | --- | --- | --- | --- | --- | --- | --- | --- | --- | --- | --- | --- | --- | --- | --- | --- |
| 4855 | 84 | **CAMEL phase 4** | 625d | 2000-04-17 A | 2002-09-06 A |  | 100% | 2000-04-17 | 2002-09-06 | 625d |  | S1 | 41104h | 41104h | CAMEL4 | Nokia | keijo.palviainen@nokia.com | Rel-5 | Alain | CAMEL4 |  |
| 4856 | 84.1 | Service requirements | 565d | 2000-04-17 A | 2002-06-14 A |  | 100% | 2000-04-17 | 2002-06-14 | 565d | finish no earlier than 2002-06-14 | S1 | 4520h | 4520h |  |  |  | Rel-5 | Alain |  |  |
| 4857 | 84.2 | Call Party Handling | 500d | 2000-07-10 A | 2002-06-07 A |  | 100% | 2000-07-10 | 2002-06-07 | 500d | finish no earlier than 2002-06-07 | N2 | 4000h | 4000h | CAMEL4-CPH |  |  | Rel-5 | Kimmo | CAMEL4-CPH |  |
| 4858 | 84.3 | Mid call procedure for MO and MT calls | 495d | 2000-07-17 A | 2002-06-07 A |  | 100% | 2000-07-17 | 2002-06-07 | 495d | finish no earlier than 2002-06-07 | N2 | 3960h | 3960h | CAMEL4-MCP |  |  | Rel-5 | Kimmo | CAMEL4-MCP |  |
| 4859 | 84.4 | Interactions with Optimal Routing | 430d | 2000-07-17 A | 2002-03-08 A |  | 100% | 2000-07-17 | 2002-03-08 | 430d | finish no earlier than 2002-03-08 | N2 | 3440h | 3440h | CAMEL4-IOR |  |  | Rel-5 | Kimmo | CAMEL4-IOR |  |
| 4860 | 84.5 | Inclusion of flexible tone injection | 430d | 2000-07-17 A | 2002-03-08 A |  | 100% | 2000-07-17 | 2002-03-08 | 430d | finish no earlier than 2002-03-08 | N2 | 3440h | 3440h | CAMEL4-IFTI |  |  | Rel-5 | Kimmo | CAMEL4-IFTI |  |
| 4861 | 84.6 | CSE control over MT SMS | 430d | 2000-07-17 A | 2002-03-08 A |  | 100% | 2000-07-17 | 2002-03-08 | 430d | finish no earlier than 2002-03-08 | N2 | 3440h | 3440h | CAMEL4-CCSMS |  |  | Rel-5 | Kimmo | CAMEL4-CCSMS |  |
| 4862 | 84.7 | Notification of GPRS mobility management to CSE | 331d | 2001-03-02 A | 2002-06-07 A |  | 100% | 2001-03-02 | 2002-06-07 | 331d | finish no earlier than 2002-06-07 | N2 | 2648h | 2648h | CAMEL4-NMM |  |  | Rel-5 | Kimmo | CAMEL4-NMM |  |
| 4863 | 84.8 | Provision of location information of called subscriber | 266d | 2001-03-02 A | 2002-03-08 A |  | 100% | 2001-03-02 | 2002-03-08 | 266d | finish no earlier than 2002-03-08 | N2 | 2128h | 2128h | CAMEL4-LOCB |  |  | Rel-5 | Kimmo | CAMEL4-LOCB |  |
| 4864 | 84.9 | Inclusion of ODB data in the CSE_HLR interface | 175d | 2001-07-09 A | 2002-03-08 A |  | 100% | 2001-07-09 | 2002-03-08 | 175d | finish no earlier than 2002-03-08 | N2 | 1400h | 1400h | CAMEL4-ODB |  |  | Rel-5 | Kimmo | CAMEL4-ODB |  |
| 4865 | 84.10 | Location information during an ongoing call (Handover DP) | 280d | 2001-05-14 A | 2002-06-07 A |  | 100% | 2001-05-14 | 2002-06-07 | 280d | finish no earlier than 2002-06-07 | N2 | 2240h | 2240h | CAMEL4-HODP |  |  | Rel-5 | Kimmo | CAMEL4-HODP |  |
| 4866 | 84.11 | GPRS Any Time Interrogation | 240d | 2001-07-09 A | 2002-06-07 A |  | 100% | 2001-07-09 | 2002-06-07 | 240d | finish no earlier than 2002-06-07 | N2 | 1920h | 1920h | CAMEL4-ATI |  |  | Rel-5 | Kimmo | CAMEL4-ATI |  |
| 4867 | 84.12 | Transfer of IMEI (with SW version) to CSE (CAMEL4-ATI) | 240d | 2001-07-09 A | 2002-06-07 A |  | 100% | 2001-07-09 | 2002-06-07 | 240d | finish no earlier than 2002-06-07 | N2 | 1920h | 1920h |  |  |  | Rel-5 | Kimmo |  |  |
| 4868 | 84.13 | Handling of partial implementations of CAMEL4 | 131d | 2002-03-08 A | 2002-09-06 A |  | 100% | 2002-03-08 | 2002-09-06 | 131d | finish no earlier than 2002-06-07 | N2 | 1048h | 1048h | CAMEL4-SUB |  |  | Rel-5 | Kimmo | CAMEL4-SUB |  |
| 4869 | 85 | **Rel-5 MExE enhancements** | 250d | 2001-03-26 A | 2002-03-08 A |  | 100% | 2001-03-26 | 2002-03-08 | 250d |  | T2 | 2880h | 2880h | MEXE5 |  |  | Rel-5 | Kimmo | MEXE5 |  |
| 4870 | 85.1 | MExE Rel-5 Improvements and Investigations | 110d | 2001-03-26 A | 2002-03-08 A |  | 100% | 2001-03-26 | 2002-03-08 | 110d | finish no earlier than 2001-12-17 | T2 | 880h | 880h | MEXE5-ENHANC | Motorola | Mark Cataldo | Rel-5 | Kimmo | MEXE5-ENHANC | 22.057, 23.057 |
| 4871 | 86 | **Wideband Telephony Service - AMR** | 1036d | 2000-01-01 A | 2003-12-19 A |  | 100% | 2000-01-01 | 2003-12-19 | 1036d |  | S4 | 75408h | 75408h | AMRWB | Siemens | Imre.Varga@mch.siemens.de | Rel-5 | Paolo | AMRWB |  |
| 4872 | 86.1 | **Specification** | 636d | 2000-01-01 A | 2002-06-07 A |  | 100% | 2000-01-01 | 2002-06-07 | 636d |  | S4 | 19984h | 19984h |  |  |  | Rel-5 | Paolo |  |  |
| 4873 | 86.1.1 | Stage 1 for Wideband Telephony Service - AMR | 125d | 2001-10-01 A | 2002-03-22 A |  | 100% | 2001-10-01 | 2002-03-22 | 125d | finish no earlier than 2002-03-22 | S1 | 1000h | 1000h |  |  |  | Rel-5 | Alain |  |  |
| 4874 | 86.1.2 | **Stage 2 for Wideband Telephony Service - AMR** | 77d | 2000-01-03 A | 2000-04-17 A |  | 100% | 2000-01-03 | 2000-04-17 | 77d |  | S4 | 1232h | 1232h |  |  |  | Rel-5 | Paolo |  |  |
| 4875 | 86.1.2.1 | Design Constraints for Wideband Telephony Service - AMR | 27d | 2000-01-03 A | 2000-02-07 A |  | 100% | 2000-01-03 | 2000-02-07 | 27d |  | S4 | 208h | 208h |  |  |  | Rel-5 | Paolo |  |  |
| 4876 | 86.1.2.2 | General Description for Wideband Telephony Service - AMR | 51d | 2000-02-07 A | 2000-04-17 A | 4875 | 100% | 2000-02-07 | 2000-04-17 | 51d | start no earlier than 2000-09-25 | S4 | 408h | 408h |  |  |  | Rel-5 | Paolo |  |  |
| 4877 | 86.1.3 | Feasibility Study for Wideband Telephony Service - AMR | 26d | 2000-04-28 A | 2000-06-02 A | 4876 | 100% | 2000-04-28 | 2000-06-02 | 26d | finish no earlier than 2000-06-02 | S4 | 208h | 208h |  |  |  | Rel-5 | Paolo |  | 26.901 |
| 4878 | 86.1.4 | N1 Aspects for Wideband Telephony Service - AMR | 66d | 2001-09-21 A | 2001-12-21 A |  | 100% | 2001-09-21 | 2001-12-21 | 66d | finish no earlier than 2001-12-21 | N1 | 528h | 528h |  |  |  | Rel-5 | Frederic |  |  |
| 4879 | 86.1.5 | N4 work for Wideband Telephony Service - AMR | 83d | 2002-02-13 A | 2002-06-07 A |  | 100% | 2002-02-13 | 2002-06-07 | 83d | finish no earlier than 2002-06-07 | N4 | 664h | 664h |  |  |  | Rel-5 | Kimmo |  |  |

Notes:
- 4855: -
- 4856: -
- 4857: -
- 4858: -
- 4859: -
- 4860: -
- 4861: -
- 4862: -
- 4863: -
- 4864: Added on May 29, 2001
- 4865: -
- 4866: -
- 4867: -
- 4868: stage2 and stage3 CRs for approval at CN#17
- 4869: -
- 4870: -
- 4871: -
- 4872: -
- 4873: -
- 4874: -
- 4875: -
- 4876: -
- 4877: S4,TD SP-000024: TR 26.901 v.4.0.0
- 4878: Some of N1 tasks: Indication of supported codecs by the MS, Bearer cap negociation, codec indication to MS... / One common set of codec negotiation procedures will be specified as in ID1657.
- 4879: CN4#11 30/11/01: No inputs to CN4 at this meeting / 14/02/02 work started 50% reached / 17 May work is done 100%

| ID | WBS | Task | Duration | Start | Finish | Predecessors | Complete | Baseline start | Baseline finish | Baseline duration | Constraint | Resources | Work | Actual work | Release | MCC resp | Acronym | Acronym_3GU_Export | Impacted TSs and TRs | TSG stopped | WI rapporteur name | WI rapporteur e-mail |
| --- | --- | --- | --- | --- | --- | --- | --- | --- | --- | --- | --- | --- | --- | --- | --- | --- | --- | --- | --- | --- | --- | --- |
| 4880 | 86.1.6 | **Codec issues** | 636d | 2000-01-03 A | 2002-06-07 A |  | 100% | 2000-01-03 | 2002-06-07 | 636d |  | S4 | 9496h | 9496h | Rel-5 | Paolo |  |  |  |  |  |  |
| 4881 | 86.1.6.1 | Codec qualification | 86d | 2000-02-02 A | 2000-05-31 A |  | 100% | 2000-02-02 | 2000-05-31 | 86d | finish no earlier than 2000-05-31 | S4 | 688h | 688h | Rel-5 | Paolo |  |  |  |  |  |  |
| 4882 | 86.1.6.2 | Codec selection tests | 102d | 2000-06-01 A | 2000-10-20 A | 4881 | 100% | 2000-06-01 | 2000-10-20 | 102d | finish no earlier than 2000-10-20 | S4 | 816h | 816h | Rel-5 | Paolo |  |  |  |  |  |  |
| 4883 | 86.1.6.3 | Codec selection | 5d | 2000-10-23 A | 2000-10-27 A | 4882 | 100% | 2000-10-23 | 2000-10-27 | 5d | finish no earlier than 2000-10-27 | S4 | 40h | 40h | Rel-5 | Paolo |  |  |  |  |  |  |
| 4884 | 86.1.6.4 | TFO AMR-WB | 63d | 2001-12-18 A | 2002-03-14 A |  | 100% | 2001-12-18 | 2002-03-14 | 63d | finish no earlier than 2002-03-14 | S4 | 504h | 504h | Rel-5 | Paolo | AMRWB-TFO | AMRWB-TFO |  |  |  |  |
| 4885 | 86.1.6.5 | Other codec issues (verif., characterization) | 441d | 2000-09-29 A | 2002-06-07 A |  | 100% | 2000-09-29 | 2002-06-07 | 441d | finish no earlier than 2002-06-07 | S4 | 3528h | 3528h | Rel-5 | Paolo |  |  | 26.976 |  |  |  |
| 4886 | 86.1.6.6 | AMR-WB and narrrowband interworking | 121d | 2001-09-27 A | 2002-03-14 A |  | 100% | 2001-09-27 | 2002-03-14 | 121d | finish no earlier than 2002-03-14 | S4 | 968h | 968h | Rel-5 | Paolo | AMRWB-IWG | AMRWB-IWG |  |  |  |  |
| 4887 | 86.1.6.7 | Interworking with fixed broadband networks | 121d | 2001-09-27 A | 2002-03-14 A |  | 100% | 2001-09-27 | 2002-03-14 | 121d | finish no earlier than 2002-03-14 | S4 | 968h | 968h | Rel-5 | Paolo |  |  |  |  |  |  |
| 4888 | 86.1.6.8 | Tones and announcements | 121d | 2001-09-27 A | 2002-03-14 A |  | 100% | 2001-09-27 | 2002-03-14 | 121d | finish no earlier than 2002-03-14 | S4 | 968h | 968h | Rel-5 | Paolo |  |  |  |  |  |  |
| 4889 | 86.1.6.9 | Deleted - WB Conferencing and WB Voice Group calls | 1d | 2000-01-03 A | 2000-01-03 A |  | 100% | 2000-01-03 | 2000-01-03 | 1d | finish no earlier than 2000-01-03 | S1 | 8h | 8h | Rel-5 | Alain |  |  |  | SP-07 |  |  |
| 4890 | 86.1.8 | **Conformance tests (CRs to 34 series)** | 74d | 2000-01-01 A | 2000-04-12 A |  | 100% | 2000-01-01 | 2000-04-12 | 74d |  | T1 | 1768h | 1768h | Rel-5 | Ingbert |  |  |  |  |  |  |
| 4891 | 86.1.8.1 | **Terminal Acoustic Characteristics** | 74d | 2000-01-01 A | 2000-04-12 A |  | 100% | 2000-01-01 | 2000-04-12 | 74d |  | S4 | 1176h | 1176h | Rel-5 | Paolo |  |  |  |  |  |  |
| 4892 | 86.1.8.1.1 | Definition for Terminal Acoustic Characteristics | 22d | 2000-01-01 A | 2000-01-31 A |  | 100% | 2000-01-01 | 2000-01-31 | 22d | finish no earlier than 2000-01-28 | S4 | 168h | 168h | Rel-5 | Paolo |  |  | 26.131 |  |  |  |
| 4893 | 86.1.8.1.2 | Test specification for Terminal Acoustic Characteristics | 52d | 2000-02-01 A | 2000-04-12 A | 4892 | 100% | 2000-02-01 | 2000-04-12 | 52d | finish no earlier than 2000-03-13 | S4 | 416h | 416h | Rel-5 | Paolo |  |  | 26.132 |  |  |  |
| 4894 | 86.2 | Floating-point ANSI-C code for the AMR-WB speech codec | 123d | 2001-09-25 A | 2002-03-14 A |  | 100% | 2001-09-25 | 2002-03-14 | 123d | finish no earlier than 2002-03-14 | S4 | 984h | 984h | Rel-5 | Paolo | AMRWB-FP | AMRWB-FP | 26.204 |  | Nokia | janne.m.vainio@nokia.com |
| 4895 | 86.3 | **Support of AMR-WB in GERAN: GMSK and 8PSK WB FR / HR** | 651d | 2000-01-03 A | 2002-06-28 A |  | 100% | 2000-01-03 | 2002-06-28 | 651d |  | GP | 23488h | 23488h | Rel-5 | Paolo | GAMRWB | GAMRWB |  |  |  |  |
| 4896 | 86.3.1 | Channel coding in 45.003 for Support of AMR-WB in GERAN: GMSK and 8PSK WB FR / HR | 591d | 2000-01-03 A | 2002-04-05 A |  | 100% | 2000-01-03 | 2002-04-05 | 591d |  | GP | 4720h | 4720h | Rel-5 | Paolo |  |  |  |  |  |  |
| 4897 | 86.3.2 | Signalling for the A interface | 391d | 2000-01-03 A | 2001-06-29 A |  | 100% | 2000-01-03 | 2001-06-29 | 391d | finish no earlier than 2001-06-29 | GP | 3120h | 3120h | Rel-5 | Paolo |  |  |  |  |  |  |
| 4898 | 86.3.3 | Signalling for Iu | 651d | 2000-01-03 A | 2002-06-28 A |  | 100% | 2000-01-03 | 2002-06-28 | 651d | finish no earlier than 2002-06-28 | GP | 5200h | 5200h | Rel-5 | Paolo |  |  |  |  |  |  |
| 4899 | 86.3.4 | Receiver performance in TS 45.005 | 325d | 2001-04-02 A | 2002-06-28 A |  | 100% | 2001-04-02 | 2002-06-28 | 325d | finish no earlier than 2002-06-28 | GP | 2600h | 2600h | Rel-5 | Paolo |  |  |  |  |  |  |
| 4900 | 86.3.5 | Link Adaptation in 45.009 | 330d | 2001-03-26 A | 2002-06-28 A |  | 100% | 2001-03-26 | 2002-06-28 | 330d | finish no earlier than 2002-06-28 | GP | 2640h | 2640h | Rel-5 | Paolo |  |  |  |  |  |  |
| 4901 | 86.4 | **Deleted - GERAN MS conformance test for AMR-WB** | 1036d | 2000-01-03 A | 2003-12-19 A |  | 100% | 2000-01-03 | 2003-12-19 | 1036d |  | GP | 16568h | 16568h | Rel-5 | Paolo |  |  |  | SP-69 |  |  |
| 4902 | 86.4.1 | Deleted - MS test for AMR-WB | 1036d | 2000-01-03 A | 2003-12-19 A |  | 100% | 2000-01-03 | 2003-12-19 | 1036d | finish no earlier than 2003-12-19 | GP | 8280h | 8280h | Rel-5 | Paolo |  |  |  | GP-17 |  |  |
| 4903 | 86.5 | GERAN BTS conformance test for AMR-WB | 762d | 2000-01-03 A | 2002-12-02 A |  | 100% | 2000-01-03 | 2002-12-02 | 762d |  | GP | 6096h | 6096h | Rel-5 | Paolo |  |  |  |  |  |  |

Notes:
- 4880: -
- 4881: -
- 4882: -
- 4883: -
- 4884: -
- 4885: ANSI C-Code , Test Sequences, Speech Transcoding Functions, Error Concealment of lost frames, Source Controlled Bit-Rate Operation, Voice Activity Detector, Frame Structure
- 4886: -
- 4887: -
- 4888: -
- 4889: -
- 4890: -
- 4891: -
- 4892: -
- 4893: -
- 4894: -
- 4895: -
- 4896: 50098 -> 50298
- 4897: -
- 4898: -
- 4899: -
- 4900: -
- 4901: Not started 02/2003. Marked as stopped 12/2008
- 4902: Marked as stopped 12/2008
- 4903: -

| ID | WBS | Task | Duration | Start | Finish | Complete | Baseline start | Baseline finish | Baseline duration | Constraint | Resources | Work | Actual work | Acronym | Release | MCC resp | Acronym_3GU_Export | WI rapporteur name | WI rapporteur e-mail |
| --- | --- | --- | --- | --- | --- | --- | --- | --- | --- | --- | --- | --- | --- | --- | --- | --- | --- | --- | --- |
| 4904 | 11 | **Rel-5 Terminal interfaces** | 223d | 2001-05-14 A | 2002-03-20 A | 100% | 2001-05-14 | 2002-03-20 | 223d |  | T2 | 3568h | 3568h | TLM5 | Rel-5 | Kimmo | TI, TLM5 |  |  |
| 4905 | 87 | Terminal local model enhancements | 223d | 2001-05-14 A | 2002-03-20 A | 100% | 2001-05-14 | 2002-03-20 | 223d | finish no earlier than 2002-03-20 | T2 | 1784h | 1784h | TLM5 | Rel-5 |  | TLM5 |  |  |
| 4906 | 88 | **Rel-5 Location Services enhancements** | 845d | 2000-04-03 A | 2003-06-27 A | 100% | 2000-04-03 | 2003-06-27 | 845d |  | S2; S1; S3; S5; N4; R2; R3; GP | 237560h | 237560h | LCS1 | Rel-5 | Maurice | LCS1, Rel-5 | Nokia | Jan Kall |
| 4907 | 88.1 | **UE positioning for Rel-5 Location Services enhancements** | 315d | 2001-01-15 A | 2002-03-29 A | 100% | 2001-01-15 | 2002-03-29 | 315d |  | R2 | 6120h | 6120h | LCS1-Uepos | Rel-5 | Issam | LCS1-Uepos, Rel-5 |  |  |
| 4908 | 88.1.1 | UE positioning enhancements for 1.28 Mcps TDD | 255d | 2001-04-09 A | 2002-03-29 A | 100% | 2001-04-09 | 2002-03-29 | 255d | finish no earlier than 2002-03-29 | R2 | 2040h | 2040h | LCS-128Pos | Rel-5 | Yong-Jun | LCS-128Pos | CATT | Xiaohua Mei |
| 4909 | 88.1.2 | Open SMLC-SRNC Interface within the UTRAN to support A-GPS Positioning | 195d | 2001-01-15 A | 2001-10-12 A | 100% | 2001-01-15 | 2001-10-12 | 195d |  | R2 | 1560h | 1560h | LCS-INTF | Rel-5 | Yong-Jun | LCS-INTF | Qualcomm | Kirk Burroughs |
| 4910 | 88.2 | **Event Based and Periodic LCS** | 535d | 2000-05-22 A | 2002-06-07 A | 100% | 2000-05-22 | 2002-06-07 | 535d |  | S1; S2; N4 | 14848h | 14848h | LCS1-EBP | Rel-5 | Alain | LCS1-EBP | Pacific Bell Wireless | Randolph Wohlert (rwohlert@tri.sbc.com) |
| 4911 | 88.2.1 | Stage 1 for Event based and Periodic LCS | 130d | 2000-05-22 A | 2000-11-17 A | 100% | 2000-05-22 | 2000-11-17 | 130d | finish no earlier than 2000-07-21 | S1 | 1040h | 1040h |  | Rel-5 | Alain |  | Pacific Bell Wireless | Randolph Wohlert (rwohlert@tri.sbc.com) |
| 4912 | 88.2.2 | Stage 2 for Event based and Periodic LCS | 60d | 2000-11-06 A | 2001-01-26 A | 100% | 2000-11-06 | 2001-01-26 | 60d | finish no earlier than 2001-01-26 | S2 | 480h | 480h |  | Rel-5 | Maurice |  |  |  |
| 4913 | 88.2.3 | Impact on MAP | 61d | 2002-03-15 A | 2002-06-07 A | 100% | 2002-03-15 | 2002-06-07 | 61d | finish no earlier than 2002-06-07 | N4 | 488h | 488h |  | Rel-5 | Kimmo |  |  |  |
| 4914 | 88.3 | **Location Services for GERAN in A/Gb Mode** | 485d | 2000-04-03 A | 2002-02-08 A | 100% | 2000-04-03 | 2002-02-08 | 485d |  | GP | 26400h | 26400h | LCS-GERAN | Rel-5 | Paolo | LCS-GERAN | Nokia | Margaret Livingston |
| 4915 | 88.3.1 | GERAN LCS Stage 2 (first release) | 485d | 2000-04-03 A | 2002-02-08 A | 100% | 2000-04-03 | 2002-02-08 | 485d | finish no earlier than 2002-02-08 | GP; S2; G1; G2 | 15520h | 15520h |  | Rel-5 | Paolo |  | Nokia | Margaret Livingston |
| 4916 | 88.3.2 | Gb interface support for LCS | 370d | 2000-04-03 A | 2001-08-31 A | 100% | 2000-04-03 | 2001-08-31 | 370d | finish no earlier than 2001-08-31 | GP | 2960h | 2960h |  | Rel-5 | Paolo |  | Nokia | Margaret Livingston |
| 4917 | 88.3.3 | L3 protocol support for LCS | 305d | 2000-04-03 A | 2001-06-01 A | 100% | 2000-04-03 | 2001-06-01 | 305d | finish no earlier than 2001-06-01 | GP | 2440h | 2440h |  | Rel-5 | Paolo |  | Nokia | Margaret Livingston |
| 4918 | 88.3.4 | Stage 3 for Location Services for GERAN in A/Gb Mode | 305d | 2000-04-03 A | 2001-06-01 A | 100% | 2000-04-03 | 2001-06-01 | 305d | finish no earlier than 2001-06-01 | GP | 2440h | 2440h |  | Rel-5 | Paolo |  | Nokia | Margaret Livingston |
| 4919 | 88.4 | **Location Services for GERAN in Iu Mode** | 585d | 2000-04-03 A | 2002-06-28 A | 100% | 2000-04-03 | 2002-06-28 | 585d |  | S2; G1; G2; R2; R3 | 64264h | 64264h |  | Rel-5 | Paolo |  | Nokia | Margaret Livingston |
| 4920 | 88.4.1 | GERAN LCS Stage 2 | 585d | 2000-04-03 A | 2002-06-28 A | 100% | 2000-04-03 | 2002-06-28 | 585d | finish no earlier than 2002-06-28 | S2; G1; G2 | 14040h | 14040h |  | Rel-5 | Paolo |  | Nokia | Margaret Livingston |
| 4921 | 88.4.2 | Iu-ps interface support for LCS | 585d | 2000-04-03 A | 2002-06-28 A | 100% | 2000-04-03 | 2002-06-28 | 585d | finish no earlier than 2002-06-28 | R2; R3 | 9360h | 9360h |  | Rel-5 | Paolo |  | Nokia | Margaret Livingston |
| 4922 | 88.4.3 | Iu-cs interface support for LCS | 585d | 2000-04-03 A | 2002-06-28 A | 100% | 2000-04-03 | 2002-06-28 | 585d | finish no earlier than 2002-06-28 | R2; R3 | 9360h | 9360h |  | Rel-5 | Paolo |  | Nokia | Margaret Livingston |
| 4923 | 88.4.4 | Iur-g interface support for LCS | 62.5d | 2002-01-23 A | 2002-04-19 A | 100% | 2002-01-23 | 2002-04-19 | 62.5d | finish no earlier than 2002-04-19 | G1; G2 | 1000h | 1000h |  | Rel-5 | Paolo |  | Nokia | Margaret Livingston |
| 4924 | 88.4.5 | RRC protocol support for LCS | 75d | 2001-08-20 A | 2001-11-30 A | 100% | 2001-08-20 | 2001-11-30 | 75d | finish no earlier than 2001-11-30 | G1; G2; R2; R3 | 2400h | 2400h |  | Rel-5 | Paolo |  | Nokia | Margaret Livingston |
| 4925 | 88.4.6 | Additional impacts on Broadcast of LCS data on packet channels | 77.5d | 2001-08-20 A | 2001-12-05 A | 100% | 2001-08-20 | 2001-12-05 | 77.5d | finish no earlier than 2001-12-05 | G1; G2; R2; R3 | 2480h | 2480h |  | Rel-5 | Paolo |  | Nokia | Margaret Livingston |
| 4926 | 88.4.7 | Stage 3 for Location Services for GERAN in Iu Mode | 69.5d | 2002-03-25 A | 2002-06-28 A | 100% | 2002-03-25 | 2002-06-28 | 69.5d | finish no earlier than 2002-06-28 | G1; G2; R2; R3 | 2224h | 2224h |  | Rel-5 | Paolo |  | Nokia | Margaret Livingston |
| 4927 | 88.5 | **GERAN MS Conformance test for LCS** | 280d | 2002-06-03 A | 2003-06-27 A | 100% | 2002-06-03 | 2003-06-27 | 280d |  | GP | 11200h | 11200h | LCS-GERAN-MSconf | Rel-5 | Paolo | LCS-GERAN-MSconf |  |  |
| 4928 | 88.5.1 | LCS MS test case work plan (Release 98/99/4) | 280d | 2002-06-03 A | 2003-06-27 A | 100% | 2002-06-03 | 2003-06-27 | 280d | finish no earlier than 2003-06-27 | G4; G5 | 4480h | 4480h |  | Rel-5 | Paolo |  |  |  |
| 4929 | 88.5.2 | LCS MS test cases | 280d | 2002-06-03 A | 2003-06-27 A | 100% | 2002-06-03 | 2003-06-27 | 280d | finish no earlier than 2003-06-27 | G4; G5 | 4480h | 4480h |  | Rel-5 | Paolo |  |  |  |

Notes:
- 4904: Acronym changed from "TI, TLMN5"
- 4905: - / Impacted TSs and TRs: 23.227
- 4906: . Acronym changed from "LCS1, Rel-5"
- 4907: Acronym changed from "LCS1-Uepos, Rel-5"
- 4908: - / Impacted TSs and TRs: 25.123, 25.224, 25.225, 25.302, 25.303, 25.304, 25.305, 25.331, 25.420, 25.423, 25.430, 25.433, New TR 25.859
- 4909: RP#13 completed
- 4910: -
- 4911: Evaluate Event based and Periodic LCS to be included in R00, corresponding Stage 1 description / Impacted TSs and TRs: 22.071
- 4912: Marked as closed 12/2008 (was marked 51% complete)
- 4913: Possible impact on UTRAN of LCS quality level request / 17 May No stage 2 for event-based & periodic LCS. Work 100% completefor current stage 2
- 4914: -
- 4915: -
- 4916: -
- 4917: -
- 4918: -
- 4919: -
- 4920: -
- 4921: -
- 4922: -
- 4923: FFS
- 4924: -
- 4925: -
- 4926: -
- 4927: -
- 4928: Marked as closed 12/2008 (was marked 60% complete)
- 4929: Marked as closed 12/2008 (was marked 60% complete)

| ID | WBS | Task | Duration | Start | Finish | Predecessors | Complete | Baseline start | Baseline finish | Baseline duration | Constraint | Resources | Work | Actual work | Acronym | Release | MCC resp | TSG stopped | Acronym_3GU_Export | Impacted TSs and TRs | WI rapporteur name | WI rapporteur e-mail |
| --- | --- | --- | --- | --- | --- | --- | --- | --- | --- | --- | --- | --- | --- | --- | --- | --- | --- | --- | --- | --- | --- | --- |
| 4930 | 88.6 | **Deleted - GERAN BTS Conformance test for LCS** | 280d | 2002-06-03 A | 2003-06-27 A |  | 100% | 2002-06-03 | 2003-06-27 | 280d |  | GP | 11200h | 11200h | LCS-GERAN-BTSconf | Rel-5 | Paolo | GP-15 | LCS-GERAN-BTSconf |  |  |  |
| 4931 | 88.6.1 | Deleted - LCS BTS test case work plan (Release 98/99/4) | 280d | 2002-06-03 A | 2003-06-27 A |  | 100% | 2002-06-03 | 2003-06-27 | 280d | finish no earlier than 2003-06-27 | G4; G5 | 4480h | 4480h |  | Rel-5 | Paolo | GP-15 |  |  |  |  |
| 4932 | 88.6.2 | Deleted - LCS BTS test cases | 280d | 2002-06-03 A | 2003-06-27 A |  | 100% | 2002-06-03 | 2003-06-27 | 280d | finish no earlier than 2003-06-27 | G4; G5 | 4480h | 4480h |  | Rel-5 | Paolo | GP-15 |  |  |  |  |
| 4933 | 88.7 | LCS interoperation stage 2 aspects | 480d | 2000-08-28 A | 2002-06-28 A |  | 100% | 2000-08-28 | 2002-06-28 | 480d |  | S2 | 3840h | 3840h |  | Rel-5 | Maurice |  |  |  |  |  |
| 4934 | 88.8 | **LCS interoperability aspects to GERAN (LCS-GERAN)** | 480d | 2000-08-28 A | 2002-06-28 A |  | 100% | 2000-08-28 | 2002-06-28 | 480d |  | GP; S5 | 34560h | 34560h |  | Rel-5 | Paolo |  |  |  |  |  |
| 4935 | 88.8.1 | Co-ordinated development of GSM LCS Phase 2 and UMTS LCS, S2 and GERAN | 480d | 2000-08-28 A | 2002-06-28 A |  | 100% | 2000-08-28 | 2002-06-28 | 480d | finish no earlier than 2002-06-28 | GP; S2; S5; R2; R3; G2; G1 | 26880h | 26880h |  | Rel-5 | Paolo |  |  |  |  |  |
| 4936 | 88.9 | FS on LCS support in the IMS | 90d | 2001-02-12 A | 2002-01-18 A |  | 100% | 2001-02-12 | 2002-01-18 | 90d | start no earlier than 2001-02-12 | S1 | 720h | 720h |  | Rel-5 | Alain |  |  |  |  |  |
| 4937 | 88.10 | Charging and OAM&P for LCS enhancements | 201d | 2001-09-21 A | 2002-06-28 A |  | 100% | 2001-09-21 | 2002-06-28 | 201d | finish no earlier than 2002-06-28 | S5 | 1608h | 1608h | LCS1-OAM | Rel-5 | Mirko |  | LCS1-OAM | 32.200-series |  |  |
| 4938 | 88.11 | New security aspects of LCS | 446d | 2000-04-14 A | 2001-12-28 A |  | 100% | 2000-04-14 | 2001-12-28 | 446d | finish no earlier than 2001-12-28 | S3; S2 | 7136h | 7136h | LCS1-SEC | Rel-5 | Mirko |  | LCS1-SEC | 23.271, 43.059 | Nokia | valtteri.niemi@nokia.com |
| 4939 | 88.12 | Specification for the Le interface | 45d | 2002-01-14 A | 2002-03-15 A |  | 100% | 2002-01-14 | 2002-03-15 | 45d | start no earlier than 2002-01-14 | S2 | 360h | 360h | LCS1-Le | Rel-5 | Maurice |  | LCS1-Le |  |  |  |
| 4940 | 88.13 | Deleted - CHECK STATUS - Inter-GMLC interface | 153d | 2002-05-30 A | 2002-12-30 A |  | 100% | 2002-05-30 | 2002-12-30 | 153d | finish no earlier than 2002-12-30 | S2 | 1224h | 1224h |  | Rel-5 | Maurice | SP-10 |  |  |  |  |
| 4941 | 89 | **Rel-5 Security enhancements (SEC1)** | 615d | 2000-02-21 A | 2002-06-28 A |  | 100% | 2000-02-21 | 2002-06-28 | 615d |  | S3 | 29974.9h | 29974.9h |  | Rel-5 | Mirko |  |  |  | Vodafone | Peter.Howard@vodafone.com |
| 4942 | 89.1 | **Rel-5 Network Domain Security (SEC1-NDS)** | 615d | 2000-02-21 A | 2002-06-28 A |  | 100% | 2000-02-21 | 2002-06-28 | 615d |  | S3 | 25054.9h | 25054.9h |  | Rel-5 | Mirko |  |  | New 33.200 (exists also for Rel-4) | Telenor | Geir-myrdahl.koien@telenor.com |
| 4943 | 89.1.3 | Rel-5 IP network layer security (NDS/IP) (SEC1-NDS-IP) | 457d | 2000-06-15 A | 2002-03-15 A |  | 100% | 2000-06-15 | 2002-03-15 | 457d | finish no earlier than 2002-03-15 | S3 | 3656h | 3656h |  | Rel-5 | Mirko |  |  | New 33.210 | Telenor | Geir-myrdahl.koien@telenor.com |
| 4944 | 89.1.1 | **Deleted - Control plane protection in core network (e.g., GTP, CAP, MAP/IP, provided by IPsec)** | 541d | 2000-05-12 A | 2002-06-07 A |  | 100% | 2000-05-12 | 2002-06-07 | 541d |  | S3 | 7118.9h | 7118.9h |  | Rel-5 | Mirko | SP-16 |  |  |  |  |
| 4945 | 89.1.1.1 | Deleted - Main aspects of User plane protection in core network (e.g., provided by IPsec) | 290d | 2000-05-12 A | 2001-06-21 A |  | 100% | 2000-05-12 | 2001-06-21 | 290d | finish no earlier than 2001-06-21 | S3 | 2320h | 2320h |  | Rel-5 | Mirko | SP-12 |  |  |  |  |
| 4946 | 89.1.1.2 | Deleted - Integration of GTP signalling security architecture - for User plane protection in core network (e.g., provided by IPsec) | 191d | 2001-09-14 A | 2002-06-07 A |  | 100% | 2001-09-14 | 2002-06-07 | 191d | finish no earlier than 2002-06-07 | N4 | 1528h | 1528h |  | Rel-5 | Kimmo | NP-16 |  |  |  |  |
| 4947 | 89.1.2 | **Deleted - User plane protection in core network (e.g., provided by IPsec)** | 615d | 2000-02-21 A | 2002-06-28 A |  | 100% | 2000-02-21 | 2002-06-28 | 615d |  | S3 | 9360h | 9360h |  | Rel-5 | Mirko | SP-16 |  |  |  |  |
| 4948 | 89.1.2.1 | Deleted -Main aspects of User plane protection in core network (e.g., provided by IPsec) | 349d | 2000-02-21 A | 2001-06-21 A |  | 100% | 2000-02-21 | 2001-06-21 | 349d | finish no earlier than 2001-06-21 | S3 | 2792h | 2792h |  | Rel-5 | Mirko | SP-12 |  |  |  |  |
| 4949 | 89.1.2.2 | Deleted - Integration of GTP signalling security architecture - for User plane protection in core network (e.g., provided by IPsec) | 206d | 2001-09-14 A | 2002-06-28 A |  | 100% | 2001-09-14 | 2002-06-28 | 206d | finish no earlier than 2002-06-28 | N4 | 1648h | 1648h |  | Rel-5 | Kimmo | NP-16 |  |  |  |  |
| 4950 | 90 | **Intra Domain Connection of RAN Nodes to Multiple CN Nodes** | 455d | 2000-10-02 A | 2002-06-28 A |  | 100% | 2000-10-02 | 2002-06-28 | 455d |  | S2; N1; N4; R3; GP | 30232h | 30232h | IUFLEX | Rel-5 | Alain |  | IUFLEX | 23.236 | Ericsson | stephen.terrill@ericsson.com |
| 4951 | 90.1 | Overall System Architecture for Intra Domain Connection of RAN Nodes to Multiple CN Nodes | 188d | 2001-01-03 A | 2001-09-21 A |  | 100% | 2001-01-03 | 2001-09-21 | 188d | finish no earlier than 2001-06-01 | S2 | 1504h | 1504h |  | Rel-5 | Maurice |  |  |  |  |  |
| 4952 | 90.2 | Stage 3: RAN node selecting CN node | 130d | 2001-09-24 A | 2002-03-22 A | 4951 | 100% | 2001-09-24 | 2002-03-22 | 130d | finish no earlier than 2002-03-22 | R3 | 1040h | 1040h |  | Rel-5 | Juha |  |  |  | Vodafone | Brendan.McWilliams@gb.vodafone.co.uk |
| 4953 | 90.3 | N1 work for Intra Domain Connection of RAN Nodes to Multiple CN Nodes | 205d | 2001-09-17 A | 2002-06-28 A |  | 100% | 2001-09-17 | 2002-06-28 | 205d | start no earlier than 2001-09-17 | N1 | 1640h | 1640h |  | Rel-5 | Frederic |  |  | 24.008 and check 29.018 |  |  |
| 4954 | 90.4 | N4 work for Intra Domain Connection of RAN Nodes to Multiple CN Nodes | 375d | 2000-10-02 A | 2002-03-08 A |  | 100% | 2000-10-02 | 2002-03-08 | 375d | finish no earlier than 2002-03-15 | N4 | 3000h | 3000h |  | Rel-5 | Kimmo |  |  |  |  |  |

Notes:
- 4930: Not started 02/3003. Marked as stopped 12/2008
- 4931: Marked as stopped 12/2008
- 4932: Marked as stopped 12/2008
- 4933: Marked as closed 12/2008 (was marked 17% complete)
- 4934: -
- 4935: -
- 4936: Marked as closed 12/2008 (was marked 75% complete)
- 4937: -
- 4938: SP#9 updated WID S3-000609 (Location services security)
- 4939: -
- 4940: Marked as stopped 12/2008
- 4941: Added BB UE authentication and rapporteur added. TO BE DELETED
- 4942: SP#9 approved WID SP-000420 (S3-000606 Network domain security). S3#17: All due in Rel5. (WI Update at S3#18). Replaced by NDS-IP and NDS-MAP. TO BE DELETED OR MOVED TO HISTORY FILE
- 4943: SP#12 WID updated SP-000420 (S3-000606) =>SP-010326 (S3-010286)
- 4944: Marked as stopped 12/2008
- 4945: TO BE DELETED. Marked as stopped 12/2008
- 4946: Waiting for input from SA3!.... Marked as stopped 12/2008
- 4947: TO BE DELETED. Marked as stopped 12/2008
- 4948: -
- 4949: 14/02/2002 requirements are not clear/not received...Marked as closed 12/2008 (was marked 95 complete)
- 4950: No clear indication on the end date. Put to Rel5 by AS.
- 4951: -
- 4952: Not identified
- 4953: -
- 4954: DAB 12.12.01 - % complete to 66% / 14/02/02 Work completed

| ID | WBS | Task | Duration | Start | Finish | Complete | Baseline start | Baseline finish | Baseline duration | Constraint | Resources | Work | Actual work | Acronym | WI rapporteur name | WI rapporteur e-mail | Release | MCC resp | Acronym_3GU_Export | TSG stopped | Impacted TSs and TRs |
| --- | --- | --- | --- | --- | --- | --- | --- | --- | --- | --- | --- | --- | --- | --- | --- | --- | --- | --- | --- | --- | --- |
| 4955 | 90.5 | **GERAN work for Intra Domain Connection of RAN Nodes to Multiple CN Nodes** | 101d | 2002-02-08 A | 2002-06-28 A | 100% | 2002-02-08 | 2002-06-28 | 101d |  | GP | 4848h | 4848h | IDCRAN-GERAN | Ericsson | ingemar.backlund@era.ericsson.se | Rel-5 | Paolo | IDCRAN-GERAN |  |  |
| 4956 | 90.5.1 | Stage 2 (changes to ) | 101d | 2002-02-08 A | 2002-06-28 A | 100% | 2002-02-08 | 2002-06-28 | 101d | finish no earlier than 2002-06-28 | G1 | 808h | 808h |  |  |  | Rel-5 | Paolo |  |  |  |
| 4957 | 90.5.2 | 43.051 Introduction of support for IDNNS in GERAN Iu mode | 101d | 2002-02-08 A | 2002-06-28 A | 100% | 2002-02-08 | 2002-06-28 | 101d | finish no earlier than 2002-06-28 | G1 | 808h | 808h |  |  |  | Rel-5 | Paolo |  |  |  |
| 4958 | 90.5.3 | Stage 3 (changes to ) | 101d | 2002-02-08 A | 2002-06-28 A | 100% | 2002-02-08 | 2002-06-28 | 101d | finish no earlier than 2002-06-28 | G2 | 808h | 808h |  |  |  | Rel-5 | Gert |  |  |  |
| 4959 | 90.5.4 | 48.016 Use of Gb interface concepts when a network applies IDNNS | 101d | 2002-02-08 A | 2002-06-28 A | 100% | 2002-02-08 | 2002-06-28 | 101d | finish no earlier than 2002-06-28 | G2 | 808h | 808h |  |  |  | Rel-5 | Gert |  |  |  |
| 4960 | 90.5.5 | 48.018 Include MSC/VLR identity in CS IMSI paging | 101d | 2002-02-08 A | 2002-06-28 A | 100% | 2002-02-08 | 2002-06-28 | 101d | finish no earlier than 2002-06-28 | G2 | 808h | 808h |  |  |  | Rel-5 | Gert |  |  |  |
| 4961 | 91 | **Deleted - GERAN improvements 3 (new transport layer on interface A)** | 446d | 2001-04-06 A | 2002-12-20 A | 100% | 2001-04-06 | 2002-12-20 | 446d |  | GP | 14272h | 14272h | GEIMP3 |  |  | Rel-5 | Paolo | GEIMP3 | SP-69 |  |
| 4962 | 91.1 | **Deleted - Evolution of the transport for A** | 446d | 2001-04-06 A | 2002-12-20 A | 100% | 2001-04-06 | 2002-12-20 | 446d |  | GP | 10704h | 10704h | GEIMP3-EtA |  |  | Rel-5 | Paolo | GEIMP3-EtA | GP-12 |  |
| 4963 | 91.1.1 | Deleted - Definition of a new A/Ater interface Transport Layer option based on the Iu Interface Transport Layer | 446d | 2001-04-06 A | 2002-12-20 A | 100% | 2001-04-06 | 2002-12-20 | 446d | finish no earlier than 2002-12-20 | GP | 3568h | 3568h |  |  |  | Rel-5 | Paolo |  | GP-12 |  |
| 4964 | 91.1.2 | Deleted - Adaptation of the Layer 3 BSSMAP procedures as required | 446d | 2001-04-06 A | 2002-12-20 A | 100% | 2001-04-06 | 2002-12-20 | 446d | finish no earlier than 2002-12-20 | GP | 3568h | 3568h |  |  |  | Rel-5 | Paolo |  | GP-12 |  |
| 4965 | 92 | **Rel-5 Charging Management & Operations, Administration, Maintenance and Provisioning (OAM&P)** | 264d | 2001-09-10 A | 2002-09-12 A | 100% | 2001-09-10 | 2002-09-12 | 264d |  | S5 | 9976h | 9976h | OAM5 |  |  | Rel-5 | Mirko | OAM5 |  |  |
| 4966 | 92.1 | Rel-5 Principles, high level Requirements and Architecture | 205d | 2001-09-17 A | 2002-06-28 A | 100% | 2001-09-17 | 2002-06-28 | 205d | finish no earlier than 2002-06-28 | S5 | 1640h | 1640h |  | Motorola |  | Rel-5 | Mirko |  |  | 32.101, 32.102 |
| 4967 | 92.2 | Rel-5 Performance Management | 259d | 2001-09-17 A | 2002-09-12 A | 100% | 2001-09-17 | 2002-09-12 | 259d | finish no earlier than 2002-09-12 | S5 | 2072h | 2072h |  | Nortel |  | Rel-5 | Mirko |  |  | 32.4xy, 52.402 |
| 4968 | 92.3 | Rel-5 Charging Management | 264d | 2001-09-10 A | 2002-09-12 A | 100% | 2001-09-10 | 2002-09-12 | 264d | finish no earlier than 2002-09-12 | S5 | 2112h | 2112h |  | T-Mobile | Karl-Heinz.Nenner@T-MOBILE.DE | Rel-5 | Mirko |  |  | 32.200, 32.205, 32.215, 32.225, 32.235 |
| 4969 | 92.4 | Rel-5 Network Infrastructure Management | 255d | 2001-09-21 A | 2002-09-12 A | 100% | 2001-09-21 | 2002-09-12 | 255d | finish no earlier than 2002-09-12 | S5 | 2040h | 2040h |  | Ericsson | thomas.tovinger@ericsson.com | Rel-5 | Mirko |  |  | 32.6xy, 32.3xy |
| 4970 | 93 | **GERAN enhancements for streaming services 1 (RLC enhancements)** | 430d | 2000-11-06 A | 2002-06-28 A | 100% | 2000-11-06 | 2002-06-28 | 430d |  | GP | 8944h | 8944h |  |  |  | Rel-5 | Paolo |  |  |  |
| 4971 | 93.1 | Concept for GERAN enhancements for streaming services 1 (RLC enhancements) | 258d | 2000-11-06 A | 2001-10-31 A | 100% | 2000-11-06 | 2001-10-31 | 258d | finish no earlier than 2001-10-31 | GP | 2064h | 2064h |  |  |  | Rel-5 | Paolo |  |  |  |
| 4972 | 93.2 | RLC protocol enhancement (SDU Discard) | 430d | 2000-11-06 A | 2002-06-28 A | 100% | 2000-11-06 | 2002-06-28 | 430d | finish no earlier than 2002-06-28 | GP | 3440h | 3440h |  |  |  | Rel-5 | Paolo |  |  |  |
| 4973 | 94 | **GERAN enhancements for streaming services 2 (usage of ECSD)** | 430d | 2000-11-06 A | 2002-06-28 A | 100% | 2000-11-06 | 2002-06-28 | 430d |  | GP | 19840h | 19840h |  | Ericsson | Frank Muller | Rel-5 | Paolo |  |  |  |
| 4974 | 94.1 | Usage of ECSD Concept | 380d | 2000-11-06 A | 2002-04-19 A | 100% | 2000-11-06 | 2002-04-19 | 380d | finish no earlier than 2002-04-19 | GP | 3040h | 3040h |  |  |  | Rel-5 | Paolo |  |  |  |
| 4975 | 94.2 | Stage 2 for GERAN enhancements for streaming services 2 (usage of ECSD) | 380d | 2000-11-06 A | 2002-04-19 A | 100% | 2000-11-06 | 2002-04-19 | 380d | finish no earlier than 2002-04-19 | GP | 3040h | 3040h |  |  |  | Rel-5 | Paolo |  |  |  |
| 4976 | 94.3 | Stage 3 for GERAN enhancements for streaming services 2 (usage of ECSD) | 430d | 2000-11-06 A | 2002-06-28 A | 100% | 2000-11-06 | 2002-06-28 | 430d | finish no earlier than 2002-06-28 | GP | 3440h | 3440h |  |  |  | Rel-5 | Paolo |  |  |  |
| 4977 | 94.4 | RLC PDU formats | 430d | 2000-11-06 A | 2002-06-28 A | 100% | 2000-11-06 | 2002-06-28 | 430d | finish no earlier than 2002-06-28 | GP | 3440h | 3440h |  |  |  | Rel-5 | Paolo |  |  |  |
| 4978 | 94.5 | MAC header | 430d | 2000-11-06 A | 2002-06-28 A | 100% | 2000-11-06 | 2002-06-28 | 430d | finish no earlier than 2002-06-28 | GP | 3440h | 3440h |  |  |  | Rel-5 | Paolo |  |  |  |

Notes:
- 4955: Accept changes Gb over IP
- 4956: -
- 4957: -
- 4958: -
- 4959: Closed, accept changes for Gb over IP
- 4960: -
- 4961: Terminated - not standardized. Marked as stopped 12/2008
- 4962: TERMINATED - NOT STANDARDIZED. Marked as stopped 12/2008
- 4963: TERMINATED - NOT STANDARDIZED. Marked as stopped 12/2008
- 4964: TERMINATED - NOT STANDARDIZED. Marked as stopped 12/2008
- 4965: -
- 4966: -
- 4967: -
- 4968: -
- 4969: -
- 4970: -
- 4971: -
- 4972: -
- 4973: AWS, Nokia, Ericsson, Nortel, Siemens, Motorola, Vodafone
- 4974: -
- 4975: -
- 4976: -
- 4977: -
- 4978: -

| ID | WBS | Task | Duration | Start | Finish | Predecessors | Complete | Baseline start | Baseline finish | Baseline duration | Constraint | Resources | Work | Actual work | Acronym | WI rapporteur name | WI rapporteur e-mail | Release | MCC resp | Acronym_3GU_Export |
| --- | --- | --- | --- | --- | --- | --- | --- | --- | --- | --- | --- | --- | --- | --- | --- | --- | --- | --- | --- | --- |
| 4979 | 95 | **GERAN/UTRAN interface evolution 1 (evolution of Iu PS)** | 476d | 2000-09-01 A | 2002-06-28 A |  | 100% | 2000-09-01 | 2002-06-28 | 476d |  | GP; R3 | 22848h | 22848h | GERUEV1 | SBC | Marc Grant | Rel-5 | Paolo | GERUEV1 |
| 4980 | 95.1 | **Evolution of Iu ps** | 476d | 2000-09-01 A | 2002-06-28 A |  | 100% | 2000-09-01 | 2002-06-28 | 476d |  | GP; R3 | 15232h | 15232h | GERUEV1-IuPS |  |  | Rel-5 | Paolo | GERUEV1-IuPS |
| 4981 | 95.1.1 | Identification of GERAN requirements on Iu ps | 326d | 2000-09-01 A | 2001-11-30 A |  | 100% | 2000-09-01 | 2001-11-30 | 326d | finish no earlier than 2001-11-30 | GP; R3 | 5216h | 5216h |  |  |  | Rel-5 | Paolo |  |
| 4982 | 95.1.2 | Update of Evolution of Iu ps specifications | 150d | 2001-12-03 A | 2002-06-28 A | 4981 | 100% | 2001-12-03 | 2002-06-28 | 150d | finish no earlier than 2002-06-28 | GP; R3 | 2400h | 2400h |  |  |  | Rel-5 | Paolo |  |
| 4983 | 96 | **GERAN/UTRAN interface evolution 2 (evolution of Iu CS)** | 522d | 2000-06-29 A | 2002-06-28 A |  | 100% | 2000-06-29 | 2002-06-28 | 522d |  | GP; R3 | 31872h | 31872h | GERUEV2 |  |  | Rel-5 | Paolo | GERUEV2 |
| 4984 | 96.1 | **Evolution of Iu cs** | 522d | 2000-06-29 A | 2002-06-28 A |  | 100% | 2000-06-29 | 2002-06-28 | 522d |  | GP; R3 | 23520h | 23520h | GERUEV2-IuCS | Lucent | Krishna Balachandran | Rel-5 | Paolo | GERUEV2-IuCS |
| 4985 | 96.1.1 | Identification of GERAN requirements on Iu cs | 472d | 2000-06-29 A | 2002-04-19 A |  | 100% | 2000-06-29 | 2002-04-19 | 472d | finish no earlier than 2002-04-19 | GP; R3 | 7552h | 7552h |  |  |  | Rel-5 | Paolo |  |
| 4986 | 96.1.2 | Update of Evolution of Iu cs specifications | 476d | 2000-09-01 A | 2002-06-28 A |  | 100% | 2000-09-01 | 2002-06-28 | 476d | finish no earlier than 2002-06-28 | GP; R3 | 7616h | 7616h |  |  |  | Rel-5 | Paolo |  |
| 4987 | 97 | **End to End QoS for PS Domain including IMS** | 480d | 2000-08-28 A | 2002-06-28 A |  | 100% | 2000-08-28 | 2002-06-28 | 480d |  | S2; S5; N3 | 18272h | 18272h | E2EQoS | Ericsson | Johnson.oyama@era.ericcson.se | Rel-5 | Maurice | E2EQoS, Rel-5 |
| 4988 | 97.1 | E2E QoSConcept and Architecture | 178d | 2001-01-03 A | 2001-09-07 A |  | 100% | 2001-01-03 | 2001-09-07 | 178d | finish no earlier than 2001-09-07 | S2 | 1424h | 1424h |  |  |  | Rel-5 | Maurice |  |
| 4989 | 97.2 | E2E QoS interworking | 465d | 2000-08-28 A | 2002-06-07 A |  | 100% | 2000-08-28 | 2002-06-07 | 465d | finish no earlier than 2002-06-07 | N3 | 3720h | 3720h | E2EQoS-IW | Lucent | Daisuke Yokota (yokota@lucent.com) | Rel-5 | Gwiho | E2EQoS-IW |
| 4990 | 97.3 | QoS Management (Provisioning and Monitoring) | 201d | 2001-09-21 A | 2002-06-28 A |  | 100% | 2001-09-21 | 2002-06-28 | 201d | finish no earlier than 2002-06-28 | S5 | 1608h | 1608h | E2EQoS-OAM |  |  | Rel-5 | Mirko | E2EQoS-OAM |
| 4991 | 98 | **Rel-5 Messaging enhancements** | 467d | 2001-06-15 A | 2003-03-31 A |  | 100% | 2001-06-15 | 2003-03-31 | 467d |  | T2 | 19000h | 19000h | MESS5 |  |  | Rel-5 | Kimmo | MESS5 |
| 4992 | 98.1 | **Rel-5 Multimedia Messaging (MMS) enhancements** | 467d | 2001-06-15 A | 2003-03-31 A |  | 100% | 2001-06-15 | 2003-03-31 | 467d |  | T2 | 11688h | 11688h | MESS5-MMS | Siemens | Josef.Laumen@SAL.SIEMENS.DE | Rel-5 | Alain | MESS5-MMS |
| 4993 | 98.1.1 | Definition of service requirements for MESS5-MMS | 196d | 2001-06-15 A | 2002-03-15 A |  | 100% | 2001-06-15 | 2002-03-15 | 196d | finish no earlier than 2002-03-15 | S1 | 1568h | 1568h | MESS5-SR | Siemens | Josef.Laumen@SAL.SIEMENS.DE | Rel-5 | Alain | MESS5-SR |
| 4994 | 98.1.2 | Technical realization of MESS5-MMS | 256d | 2001-06-15 A | 2002-06-07 A |  | 100% | 2001-06-15 | 2002-06-07 | 256d | finish no earlier than 2002-06-07 | T2 | 2048h | 2048h |  | Siemens | Josef.Laumen@SAL.SIEMENS.DE | Rel-5 |  |  |
| 4995 | 98.1.3 | WAP Forum dependency: MM1 stage 3 | 467d | 2001-06-15 A | 2003-03-31 A |  | 100% | 2001-06-15 | 2003-03-31 | 467d | finish no earlier than 2003-03-31 | T2 | 3736h | 3736h |  |  |  | Rel-5 |  |  |
| 4996 | 98.1.4 | MMS formats and codecs for MESS5-MMS | 75d | 2001-12-03 A | 2002-03-15 A |  | 100% | 2001-12-03 | 2002-03-15 | 75d | finish no earlier than 2002-03-15 | S4 | 600h | 600h |  |  |  | Rel-5 | Paolo |  |
| 4997 | 98.2 | **Enhanced Messaging Service (EMS) enhancements** | 191d | 2001-06-15 A | 2002-03-08 A |  | 100% | 2001-06-15 | 2002-03-08 | 191d |  | T2 | 3584h | 3584h | MESS5-EMS | Ericsson | Alan.Baldwin@EML.ERICSSON.SE | Rel-5 | Kimmo | MESS5-EMS |
| 4998 | 98.2.1 | Definition of service requirements for Enhanced Messaging Service (EMS) enhancements | 66d | 2001-06-15 A | 2001-09-14 A |  | 100% | 2001-06-15 | 2001-09-14 | 66d | finish no earlier than 2001-09-14 | S1 | 528h | 528h |  | Ericsson | Alan.Baldwin@EML.ERICSSON.SE | Rel-5 | Alain |  |
| 4999 | 98.2.2 | Technical realization of Enhanced Messaging Service (EMS) enhancements | 191d | 2001-06-15 A | 2002-03-08 A |  | 100% | 2001-06-15 | 2002-03-08 | 191d | finish no earlier than 2002-03-08 | T2 | 1528h | 1528h |  | Ericsson | Alan.Baldwin@EML.ERICSSON.SE | Rel-5 | Kimmo |  |
| 5000 | 99 | **GERAN Inter BSC NACC improvements over the Gb Interface** | 215d | 2001-09-03 A | 2002-06-28 A |  | 100% | 2001-09-03 | 2002-06-28 | 215d |  | GP | 11184h | 11184h | GERNACC |  |  | Rel-5 | Paolo | GERNACC |
| 5001 | 99.1 | **Modification of core network protocols for GERAN Inter BSC NACC over Gb Interface** | 165d | 2001-09-03 A | 2002-04-19 A |  | 100% | 2001-09-03 | 2002-04-19 | 165d |  | N4; S2 | 7048h | 7048h | GERNACC-Cnmod |  |  | Rel-5 | Kimmo | GERNACC-Cnmod |
| 5002 | 99.1.1 | Stage 2 - Concept | 43d | 2001-09-03 A | 2001-10-31 A |  | 100% | 2001-09-03 | 2001-10-31 | 43d | finish no earlier than 2001-10-31 | N4; S2 | 688h | 688h |  |  |  | Rel-5 | Kimmo |  |
| 5003 | 99.1.2 | Stage 2 - 23.060 change - Definition of Inter BSC NACC | 165d | 2001-09-03 A | 2002-04-19 A |  | 100% | 2001-09-03 | 2002-04-19 | 165d | finish no earlier than 2002-04-19 | N4; S2 | 2640h | 2640h |  |  |  | Rel-5 | Kimmo |  |
| 5004 | 99.1.3 | Stage 3 (changes to TS 29.060) | 135d | 2001-09-03 A | 2002-03-08 A |  | 100% | 2001-09-03 | 2002-03-08 | 135d | finish no earlier than 2002-03-08 | N4 | 1080h | 1080h |  |  |  | Rel-5 | Kimmo |  |

Notes:
- 4979: SBC, Motorola, Nokia, Ericsson, Nortel
- 4980: -
- 4981: -
- 4982: -
- 4983: -
- 4984: Lucent, Ericsson, AWS, Nortel
- 4985: -
- 4986: -
- 4987: Acronym changed from "E2EQoS, Rel-5"
- 4988: - / Impacted TSs and TRs: 23.207
- 4989: [DAB - 30/07/02] - % complete to 95% (if we exclude Diffserv). Marked as closed 12/2008 (was marked 95% complete) / Impacted TSs and TRs: 29.208, 29.207, 27.060, 29.061, 24.008, 24.228, , 24.229, 29.060, 29.163
- 4990: - / Impacted TSs and TRs: 32-series
- 4991: support of UAProf, so this in my opinion is 100% complete
- 4992: -
- 4993: - / Impacted TSs and TRs: 22.140
- 4994: stage 3 MM7 is missing / Impacted TSs and TRs: 23.140
- 4995: Marked as closed 12/2008 (was marked 80% complete)
- 4996: - / Impacted TSs and TRs: 26.140
- 4997: - / Impacted TSs and TRs: 23.040
- 4998: -
- 4999: - / Impacted TSs and TRs: 23.040
- 5000: -
- 5001: -
- 5002: -
- 5003: -
- 5004: IP 30/11/01: Input awaited from GERAN2 to CN4 / 17 May Work complete 100%

| ID | WBS | Task | Duration | Start | Finish | Complete | Baseline start | Baseline finish | Baseline duration | Constraint | Resources | Work | Actual work | Acronym | Release | MCC resp | Acronym_3GU_Export | TSG stopped | WI rapporteur name | WI rapporteur e-mail |
| --- | --- | --- | --- | --- | --- | --- | --- | --- | --- | --- | --- | --- | --- | --- | --- | --- | --- | --- | --- | --- |
| 5005 | 99.2 | **Modification of Gb protocols for GERAN Inter BSC NACC over Gb Interface** | 151d | 2001-11-30 A | 2002-06-28 A | 100% | 2001-11-30 | 2002-06-28 | 151d |  | GP | 2416h | 2416h | GERNACC-Gbmod | Rel-5 | Paolo | GERNACC-Gbmod |  |  |  |
| 5006 | 99.2.1 | Stage 3 (changes to TS 48.018) | 151d | 2001-11-30 A | 2002-06-28 A | 100% | 2001-11-30 | 2002-06-28 | 151d | finish no earlier than 2002-06-28 | GP | 1208h | 1208h |  | Rel-5 | Paolo |  |  |  |  |
| 5007 | 100 | **Enhanced Power Control** | 540d | 2001-11-26 A | 2003-12-19 A | 100% | 2001-11-26 | 2003-12-19 | 540d |  | GP | 12840h | 12840h | EPC | Rel-5 | Paolo | EPC |  |  |  |
| 5008 | 100.1 | Realization of Enhanced power control and signalling support | 5d | 2001-11-26 A | 2001-11-30 A | 100% | 2001-11-26 | 2001-11-30 | 5d | finish no earlier than 2001-11-30 | GP | 40h | 40h |  | Rel-5 | Paolo |  |  |  |  |
| 5009 | 100.2 | Deleted - GERAN MS Conformance test for Enhanced Power Control | 530d | 2001-12-10 A | 2003-12-19 A | 100% | 2001-12-10 | 2003-12-19 | 530d | finish no earlier than 2003-12-19 | GP | 4240h | 4240h |  | Rel-5 | Paolo |  | GP-17 |  |  |
| 5010 | 100.3 | Deleted - GERAN BTS Conformance test for Enhanced Power Control | 530d | 2001-12-10 A | 2003-12-19 A | 100% | 2001-12-10 | 2003-12-19 | 530d | finish no earlier than 2003-12-19 | GP | 4240h | 4240h |  | Rel-5 | Paolo |  | GP-17 |  |  |
| 5011 | 101 | **8PSK AMR HR** | 530d | 2001-12-10 A | 2003-12-19 A | 100% | 2001-12-10 | 2003-12-19 | 530d |  | GP | 21080h | 21080h | 8PSK-AH | Rel-5 | Paolo | 8PSK-AH |  |  |  |
| 5012 | 101.1 | **Definition of channel coding, performance requirements and signalling support** | 145d | 2001-12-10 A | 2002-06-28 A | 100% | 2001-12-10 | 2002-06-28 | 145d |  | GP | 10440h | 10440h |  | Rel-5 | Paolo |  |  |  |  |
| 5013 | 101.1.1 | Concept | 145d | 2001-12-10 A | 2002-06-28 A | 100% | 2001-12-10 | 2002-06-28 | 145d | finish no earlier than 2002-06-28 | GP | 1160h | 1160h |  | Rel-5 | Paolo |  |  |  |  |
| 5014 | 101.1.2 | Changes to 44.018 | 145d | 2001-12-10 A | 2002-06-28 A | 100% | 2001-12-10 | 2002-06-28 | 145d | finish no earlier than 2002-06-28 | G2 | 1160h | 1160h |  | Rel-5 | Gert |  |  |  |  |
| 5015 | 101.1.3 | Changes to 45.001 | 145d | 2001-12-10 A | 2002-06-28 A | 100% | 2001-12-10 | 2002-06-28 | 145d | finish no earlier than 2002-06-28 | G1 | 1160h | 1160h |  | Rel-5 | Paolo |  |  |  |  |
| 5016 | 101.1.4 | Changes to 45.002 | 145d | 2001-12-10 A | 2002-06-28 A | 100% | 2001-12-10 | 2002-06-28 | 145d | finish no earlier than 2002-06-28 | G1 | 1160h | 1160h |  | Rel-5 | Paolo |  |  |  |  |
| 5017 | 101.1.5 | Changes to 45.003 | 145d | 2001-12-10 A | 2002-06-28 A | 100% | 2001-12-10 | 2002-06-28 | 145d | finish no earlier than 2002-06-28 | G1 | 1160h | 1160h |  | Rel-5 | Paolo |  |  |  |  |
| 5018 | 101.1.6 | Changes to 45.005 | 145d | 2001-12-10 A | 2002-06-28 A | 100% | 2001-12-10 | 2002-06-28 | 145d | finish no earlier than 2002-06-28 | G1 | 1160h | 1160h |  | Rel-5 | Paolo |  |  |  |  |
| 5019 | 101.1.7 | Changes to 24.008 | 145d | 2001-12-10 A | 2002-06-28 A | 100% | 2001-12-10 | 2002-06-28 | 145d | finish no earlier than 2002-06-28 | G2 | 1160h | 1160h |  | Rel-5 | Gert |  |  |  |  |
| 5020 | 101.1.8 | Changes to 48.058 | 145d | 2001-12-10 A | 2002-06-28 A | 100% | 2001-12-10 | 2002-06-28 | 145d | finish no earlier than 2002-06-28 | G2 | 1160h | 1160h |  | Rel-5 | Gert |  |  |  |  |
| 5021 | 101.2 | Deleted - GERAN MS Conformance test for 8PSK HR | 530d | 2001-12-10 A | 2003-12-19 A | 100% | 2001-12-10 | 2003-12-19 | 530d | finish no earlier than 2003-12-19 | GP | 4240h | 4240h |  | Rel-5 | Paolo |  | GP-17 |  |  |
| 5022 | 101.3 | GERAN BTS Conformance test for 8PSK HR | 270d | 2001-12-10 A | 2002-12-20 A | 100% | 2001-12-10 | 2002-12-20 | 270d | finish no earlier than 2002-12-20 | GP | 2160h | 2160h |  | Rel-5 | Paolo |  |  |  |  |
| 5023 | 102 | Service Change and UDI Fallback | 175d | 2001-10-08 A | 2002-06-07 A | 100% | 2001-10-08 | 2002-06-07 | 175d | finish no earlier than 2002-06-07 | N3 | 1400h | 1400h | SCUDIF | Rel-5 | Gwiho | SCUDIF |  | Ericsson | Rune.Werner.Wiik@ericsson.no |
| 5024 | 103 | **Rel-5 USIM toolkit enhancements** | 865d | 2000-06-05 A | 2003-09-26 A | 100% | 2000-06-05 | 2003-09-26 | 865d |  | T3; S1 | 36776h | 36776h | USAT5 | Rel-5 | Xavier | USAT1, USAT1-Interpr, USAT1LocLnk |  | G & D | Michael Meyer |
| 5025 | 103.1 | Deleted - Test specification for USIM toolkit security mechanisms | 349d | 2002-05-28 A | 2003-09-26 A | 100% | 2002-05-28 | 2003-09-26 | 349d | finish no earlier than 2003-09-26 | T3 | 2792h | 2792h |  | Rel-5 | Xavier |  | TP-21 | Gemplus | Sophie Viallet |
| 5026 | 103.2 | **Protocol Standardisation of a SIM Toolkit Interpreter** | 688d | 2000-06-05 A | 2003-01-22 A | 100% | 2000-06-05 | 2003-01-22 | 688d |  | T3; T2 | 18016h | 18016h |  | Rel-5 | Xavier |  |  | G & D | Michael Meyer |
| 5027 | 103.2.1 | Stage 1 for Protocol Standardisation of a SIM Toolkit Interpreter | 205d | 2000-06-05 A | 2001-03-16 A | 100% | 2000-06-05 | 2001-03-16 | 205d | finish no earlier than 2001-03-16 | T3 | 1640h | 1640h |  | Rel-5 | Xavier |  |  |  |  |
| 5028 | 103.2.2 | Stage 2 and 3 | 308d | 2001-01-03 A | 2002-03-08 A | 100% | 2001-01-03 | 2002-03-08 | 308d | finish no earlier than 2002-03-08 | T3 | 2464h | 2464h |  | Rel-5 | Xavier |  |  |  |  |
| 5029 | 103.2.3 | Test specification for Protocol Standardisation of a SIM Toolkit Interpreter | 363d | 2001-09-03 A | 2003-01-22 A | 100% | 2001-09-03 | 2003-01-22 | 363d | finish no earlier than 2003-01-22 | T3 | 2904h | 2904h |  | Rel-5 | Xavier |  |  | Gemplus | Gérald MAUNIER |

Notes:
- 5005: -
- 5006: -
- 5007: -
- 5008: Completed 11/2001
- 5009: Not started. Marked as stopped 12/2008
- 5010: Not started. Marked as stopped 12/2008
- 5011: Completed for Rel-5
- 5012: -
- 5013: -
- 5014: -
- 5015: -
- 5016: -
- 5017: -
- 5018: -
- 5019: -
- 5020: -
- 5021: Marked as stopped 12/2008
- 5022: -
- 5023: - / Impacted TSs and TRs: 29.007, 27.001, 24.008
- 5024: Acronym changed from USAT1, USAT1-Interpr, USAT1LocLnk / Impacted TSs and TRs: 22.038, 31.111 (USAT1), 22.038, 03.19, 03.48 (USAT1LocLnk), 23.048 (USAT1SM), 43.019 (USAT1APIJAVA)
- 5025: Marked as stopped 12/2008
- 5026: 28/5/2001: T3-19 proposed that since the stage 2 and 3 will not be presented to TP-12 for approval as expected, the WI will be moved to rel-5, with completion expected at TP-13. / Impacted TSs and TRs: T2 27.103
- 5027: 5/10/2001: Stage one comepeted at TP-12. / Impacted TSs and TRs: 31.112, 31.113, 31.114
- 5028: 5/10/2001: TS 31.112 and 31.113 approved at TP-13. TS 31.114 to be presented to TP-14. / Impacted TSs and TRs: 31.112, 31.113, 31.114
- 5029: 5/10/2001: Work started on test specification. Marked as closed 12/2008 (was marked 12% complete)

| ID | WBS | Task | Type | Duration | Start | Finish | Complete | Baseline start | Baseline finish | Baseline duration | Constraint | Resources | Work | Actual work | Acronym | WI rapporteur name | WI rapporteur e-mail | Release | MCC resp | Acronym_3GU_Export | TSG stopped |
| --- | --- | --- | --- | --- | --- | --- | --- | --- | --- | --- | --- | --- | --- | --- | --- | --- | --- | --- | --- | --- | --- |
| 5030 | 103.4 | **(U)SIM API** |  | 133d | 2002-03-20 A | 2002-09-20 A | 100% | 2002-03-20 | 2002-09-20 | 133d |  | T3 | 2128h | 2128h | USAT5-API | Microelectrónica Española | Mario Pérez | Rel-5 | Xavier | USAT1-API, TEI4 |  |
| 5031 | 103.4.1 | Rel-5 Java API Test specification |  | 133d | 2002-03-20 A | 2002-09-20 A | 100% | 2002-03-20 | 2002-09-20 | 133d | finish no earlier than 2002-09-20 | T3 | 1064h | 1064h |  | Microelectrónica Española | Mario Pérez | Rel-5 | Xavier |  |  |
| 5032 | 104 | (Small) Technical Enhancements and Improvements for Rel-5 | milestone | 0d? | 2000-01-03 A | 2000-01-03 A | 100% | 2000-01-03 | 2000-01-03 | 0d? |  | SP; CP; RP; GP |  |  | TEI5 |  |  | Rel-5 | all | TEI5 |  |
| 5033 | 1228 | Test - (Small) Technical Enhancements and Improvements for Rel-5 |  | 2349d? | 2000-01-03 A | 2008-12-31 A | 100% | 2000-01-03 | 2008-12-31 | 2349d? | finish no earlier than 2008-12-31 | R5; T1 | 37584h | 37584h | TEI5_Test |  |  | Rel-5 | Ingbert | TEI5_Test |  |
| 5034 | 105 | Technical Report on UE Functionality Split |  | 87d | 2000-01-03 A | 2000-05-01 A | 100% | 2000-01-03 | 2000-05-01 | 87d |  | S1 | 688h | 688h | UESPLIT | Motorola | jian.j.wu@motorola.com | Rel-5 | Alain | UESPLIT |  |
| 5035 | 106 | **User Equipment Management** |  | 267d | 2001-06-21 A | 2002-06-28 A | 100% | 2001-06-21 | 2002-06-28 | 267d |  | S5 | 3752h | 3752h | UEM | Vodafone | john.mudge@vf.vodafone.co.uk | Rel-5 | Mirko | UEM |  |
| 5036 | 106.1 | FS on User Equipment (UE) Management |  | 267d | 2001-06-21 A | 2002-06-28 A | 100% | 2001-06-21 | 2002-06-28 | 267d | finish no earlier than 2002-06-28 | S5 | 2136h | 2136h | OAM-UEM | Vodafone | john.mudge@vf.vodafone.co.uk | Rel-5 | Mirko | OAM-UEM |  |
| 5037 | 107 | **Flow control supporting an MS with multiple data flows with different QoS over the Gb interface** |  | 50d | 2002-06-24 A | 2002-08-30 A | 100% | 2002-06-24 | 2002-08-30 | 50d |  | GP | 1288h | 1288h | FlowCon | Ericsson | ingemar.backlund@era.ericsson.se | Rel-5 | Paolo | FlowCon |  |
| 5038 | 107.1 | **Update of stage 2 specifications** |  | 50d | 2002-06-24 A | 2002-08-30 A | 100% | 2002-06-24 | 2002-08-30 | 50d |  | GP | 808h | 808h |  |  |  | Rel-5 | Paolo |  |  |
| 5039 | 107.1.1 | Concept document 23.060 (changes to) |  | 46d | 2002-06-28 A | 2002-08-30 A | 100% | 2002-06-28 | 2002-08-30 | 46d | finish no earlier than 2002-08-30 | S2 | 368h | 368h |  |  |  | Rel-5 | Maurice |  |  |
| 5040 | 107.1.2 | Flow Control |  | 5d | 2002-06-24 A | 2002-06-28 A | 100% | 2002-06-24 | 2002-06-28 | 5d | finish no earlier than 2002-06-28 | GP | 40h | 40h |  |  |  | Rel-5 | Paolo |  |  |
| 5041 | 107.2 | **Modification of BSSGP protocol** |  | 5d | 2002-06-24 A | 2002-06-28 A | 100% | 2002-06-24 | 2002-06-28 | 5d |  | GP | 80h | 80h |  | Ericsson | ingemar.backlund@era.ericsson.se | Rel-5 | Paolo |  |  |
| 5042 | 107.2.1 | Stage 3 (changes to 48.018) |  | 5d | 2002-06-24 A | 2002-06-28 A | 100% | 2002-06-24 | 2002-06-28 | 5d | finish no earlier than 2002-06-28 | G2 | 40h | 40h |  |  |  | Rel-5 | Gert |  |  |
| 5043 | 108 | **Deleted - Multiple TBF in A/Gb mode - Phase 1 (MULTBF)** |  | 421d | 2002-04-19 A | 2003-11-28 A | 100% | 2002-04-19 | 2003-11-28 | 421d |  | GP | 17480h | 17480h |  | Ericsson | gunnar.mildh@era.ericsson.se | Rel-5 | Paolo |  | GP-17 |
| 5044 | 108.1 | **Deleted - Multiple TBF in A/Gb mode - Core (MULTBF-Agbmode)** |  | 351d | 2002-04-19 A | 2003-08-22 A | 100% | 2002-04-19 | 2003-08-22 | 351d |  | GP | 8112h | 8112h |  |  |  | Rel-5 | Paolo |  | GP-17 |
| 5045 | 108.1.1 | Deleted - Multiple TBF Concept paper |  | 351d | 2002-04-19 A | 2003-08-22 A | 100% | 2002-04-19 | 2003-08-22 | 351d | finish no earlier than 2003-08-22 | GP | 2808h | 2808h |  |  |  | Rel-5 | Paolo |  | GP-17 |
| 5046 | 108.1.2 | Deleted - Multiple TBF Stage 2 (43.064) CRs |  | 156d | 2002-04-19 A | 2002-11-22 A | 100% | 2002-04-19 | 2002-11-22 | 156d | finish no earlier than 2002-11-22 | G1 | 1248h | 1248h |  |  |  | Rel-5 | Paolo |  | GP-12 |
| 5047 | 108.1.3 | Deleted - Multiple TBF Stage 3 (44.060) CRs |  | 156d | 2002-04-19 A | 2002-11-22 A | 100% | 2002-04-19 | 2002-11-22 | 156d | finish no earlier than 2002-11-22 | G2 | 1248h | 1248h |  |  |  | Rel-5 | Gert |  | GP-12 |
| 5048 | 108.2 | **Deleted - Multiple TBF in A/Gb mode - Phase 1 – MS testing** |  | 375d | 2002-06-24 A | 2003-11-28 A | 100% | 2002-06-24 | 2003-11-28 | 375d |  | GP | 6000h | 6000h |  | Ericsson | ingemar.backlund@era.ericsson.se | Rel-5 | Paolo |  | GP-17 |
| 5049 | 108.2.1 | Deleted - MS conformance tests for Multiple TBF in A/Gb mode |  | 375d | 2002-06-24 A | 2003-11-28 A | 100% | 2002-06-24 | 2003-11-28 | 375d | finish no earlier than 2003-11-28 | G4 | 3000h | 3000h |  |  |  | Rel-5 | Paolo |  | GP-17 |
| 5050 | 109 | **Alignment of 3G functional split and Iu** |  | 922d | 2000-06-08 A | 2003-12-19 A | 100% | 2000-06-08 | 2003-12-19 | 922d |  | GP | 165704h | 165704h | GER3GAL | Ericsson | Frank Muller | Rel-5 | Paolo | GER3GAL |  |
| 5051 | 109.1 | **GERAN user / control plane** |  | 540d | 2000-08-07 A | 2002-08-30 A | 100% | 2000-08-07 | 2002-08-30 | 540d |  | GP | 36232h | 36232h | GER3GAL-GUCOPL | Ericsson | Frank Muller | Rel-5 | Paolo | GER3GAL-GUCOPL |  |
| 5052 | 109.1.1 | **Alignment with UMTS bearer concept** |  | 540d | 2000-08-07 A | 2002-08-30 A | 100% | 2000-08-07 | 2002-08-30 | 540d |  | GP | 24952h | 24952h |  |  |  | Rel-5 | Paolo |  |  |
| 5053 | 109.1.1.1 | Enhanced power control - for Alignment with UMTS bearer concept |  | 1d | 2001-08-31 A | 2001-08-31 A | 100% | 2001-08-31 | 2001-08-31 | 1d | finish no earlier than 2001-08-31 | GP | 8h | 8h |  |  |  | Rel-5 | Paolo |  |  |
| 5054 | 109.1.1.2 | Stage 2 - for Alignment with UMTS bearer concept |  | 235d | 2000-08-07 A | 2001-06-29 A | 100% | 2000-08-07 | 2001-06-29 | 235d | finish no earlier than 2001-06-29 | GP | 1880h | 1880h |  |  |  | Rel-5 | Paolo |  |  |
| 5055 | 109.1.1.3 | Adoption of the UTRAN PDCP |  | 295d | 2000-11-06 A | 2001-12-21 A | 100% | 2000-11-06 | 2001-12-21 | 295d | finish no earlier than 2001-12-21 | GP | 2360h | 2360h |  |  |  | Rel-5 | Paolo |  |  |
| 5056 | 109.1.1.4 | Development of RLC / MAC |  | 261d | 2001-08-31 A | 2002-08-30 A | 100% | 2001-08-31 | 2002-08-30 | 261d | finish no earlier than 2002-08-30 | GP | 2088h | 2088h |  |  |  | Rel-5 | Paolo |  |  |
| 5057 | 109.1.1.5 | Development of GERAN RRC |  | 266d | 2001-06-22 A | 2002-06-28 A | 100% | 2001-06-22 | 2002-06-28 | 266d | finish no earlier than 2002-06-28 | GP | 2128h | 2128h |  |  |  | Rel-5 | Paolo |  |  |
| 5058 | 109.1.1.6 | Ciphering and integrity protection concept paper |  | 166d | 2001-08-31 A | 2002-04-19 A | 100% | 2001-08-31 | 2002-04-19 | 166d | finish no earlier than 2002-04-19 | GP | 1328h | 1328h |  |  |  | Rel-5 | Paolo |  |  |
| 5059 | 109.1.1.7 | Multiple TBF or equivalent Concept paper |  | 116d | 2001-08-31 A | 2002-02-08 A | 100% | 2001-08-31 | 2002-02-08 | 116d | finish no earlier than 2002-02-08 | GP | 928h | 928h |  |  |  | Rel-5 | Paolo |  |  |
| 5060 | 109.1.1.8 | Paging concept |  | 166d | 2001-08-31 A | 2002-04-19 A | 100% | 2001-08-31 | 2002-04-19 | 166d | finish no earlier than 2002-04-19 | GP | 1328h | 1328h |  |  |  | Rel-5 | Paolo |  |  |
| 5061 | 109.1.1.9 | Dedicated Physical subchannels, includes traffic and control channels |  | 66d | 2001-08-31 A | 2001-11-30 A | 100% | 2001-08-31 | 2001-11-30 | 66d | finish no earlier than 2001-11-30 | GP | 528h | 528h |  |  |  | Rel-5 | Paolo |  |  |
| 5062 | 109.1.1.10 | Iu support and broadcast concept |  | 166d | 2001-08-31 A | 2002-04-19 A | 100% | 2001-08-31 | 2002-04-19 | 166d | finish no earlier than 2002-04-19 | GP | 1328h | 1328h |  |  |  | Rel-5 | Paolo |  |  |
| 5063 | 109.1.1.11 | Impact of using RLC instead of LAPDm concept |  | 116d | 2001-08-31 A | 2002-02-08 A | 100% | 2001-08-31 | 2002-02-08 | 116d | finish no earlier than 2002-02-08 | GP | 928h | 928h |  |  |  | Rel-5 | Paolo |  |  |
| 5064 | 109.1.1.12 | Contention resolution, mobile station identity, and access concept |  | 66d | 2001-08-31 A | 2001-11-30 A | 100% | 2001-08-31 | 2001-11-30 | 66d | finish no earlier than 2001-11-30 | GP | 528h | 528h |  |  |  | Rel-5 | Paolo |  |  |
| 5065 | 109.1.1.13 | PDCP concept |  | 166d | 2001-08-31 A | 2002-04-19 A | 100% | 2001-08-31 | 2002-04-19 | 166d | finish no earlier than 2002-04-19 | GP | 1328h | 1328h |  |  |  | Rel-5 | Paolo |  |  |
| 5066 | 109.1.1.14 | Downlink delayed TBF release |  | 261d | 2001-08-31 A | 2002-08-30 A | 100% | 2001-08-31 | 2002-08-30 | 261d | finish no earlier than 2002-08-30 | GP | 2088h | 2088h |  |  |  | Rel-5 | Paolo |  |  |
| 5067 | 109.1.1.15 | Add transparent RLC Concept |  | 116d | 2001-08-31 A | 2002-02-08 A | 100% | 2001-08-31 | 2002-02-08 | 116d | finish no earlier than 2002-02-08 | GP | 928h | 928h |  |  |  | Rel-5 | Paolo |  |  |
| 5068 | 109.1.1.16 | Handover concept |  | 116d | 2001-08-31 A | 2002-02-08 A | 100% | 2001-08-31 | 2002-02-08 | 116d | finish no earlier than 2002-02-08 | GP | 928h | 928h |  |  |  | Rel-5 | Paolo |  |  |

Notes:
- 5030: 8/3/2001: test spec is based on R99 core spec, so deleted from Workplan. Acronym changed from USAT1-API, TEI4
- 5031: - / Impacted TSs and TRs: 51.013
- 5032: "Joker" WI, to be used for a Rel 5 CR not related to any feature and with very limited impact on the system
- 5033: "Joker" WI, to be used for small modifications applicable to Rel 5 conformance testing. Moved in from Stoyan/testing WP. / Impacted TSs and TRs: 34.108, 34.109, 34.121-1, 34.121-2, 34.122, 34.123-1, 34.123-2, 34.123-3, 34.171, 34.229-1, 34.229-2, 34.229-3
- 5034: - / Impacted TSs and TRs: New TR 22.944
- 5035: - / Impacted TSs and TRs: 32.802
- 5036: - / Impacted TSs and TRs: 32.802
- 5037: 50101 -> 50201
- 5038: 50102 -> 50202
- 5039: -
- 5040: 50103 -> 50203
- 5041: 50104 -> 50204
- 5042: -
- 5043: GP#17 Nov 2003 Moved to Rel-6 as UID_50600 MULTBF (Only Multiple TBF Concept paper produced in Rel-5)
- 5044: Marked as closed 12/2008 (was marked 26% complete)
- 5045: Marked as closed 12/2008 (was marked 50% complete)
- 5046: Marked as stopped 12/2008
- 5047: Marked as stopped 12/2008
- 5048: 08/08: duplicate UID_50106=-> 50206. Marked as stopped 12/2008
- 5049: Not started. Marked as stopped 12/2008
- 5050: AWS, Nokia, Ericsson, Nortel, Siemens, Vodafone
- 5051: AWS, Nokia, Ericsson, Nortel, Siemens, Vodafone
- 5052: -
- 5053: -
- 5054: -
- 5055: Responsible is GERAN; RAN WG2 help may be needed.
- 5056: -
- 5057: -
- 5058: -
- 5059: -
- 5060: -
- 5061: -
- 5062: -
- 5063: -
- 5064: -
- 5065: -
- 5066: -
- 5067: -
- 5068: -

| ID | WBS | Task | Duration | Start | Finish | Complete | Baseline start | Baseline finish | Baseline duration | Constraint | Resources | Work | Actual work | Release | MCC resp | Acronym | WI rapporteur name | WI rapporteur e-mail | Acronym_3GU_Export |
| --- | --- | --- | --- | --- | --- | --- | --- | --- | --- | --- | --- | --- | --- | --- | --- | --- | --- | --- | --- |
| 5069 | 109.1.2 | **Physical layer alignment with UMTS bearer concept** | 280d | 2000-11-06 A | 2001-11-30 A | 100% | 2000-11-06 | 2001-11-30 | 280d |  | GP | 6960h | 6960h | Rel-5 | Paolo |  |  |  |  |
| 5070 | 109.1.2.1 | PDTCH/TCH in 45.003 | 155d | 2000-11-06 A | 2001-06-08 A | 100% | 2000-11-06 | 2001-06-08 | 155d | finish no earlier than 2001-06-08 | GP | 1240h | 1240h | Rel-5 | Paolo |  |  |  |  |
| 5071 | 109.1.2.2 | Control channels in 45.003 | 155d | 2000-11-06 A | 2001-06-08 A | 100% | 2000-11-06 | 2001-06-08 | 155d | finish no earlier than 2001-06-08 | GP | 1240h | 1240h | Rel-5 | Paolo |  |  |  |  |
| 5072 | 109.1.2.3 | Receiver performance in 45.005 for PDTCH/TCH and control channels | 280d | 2000-11-06 A | 2001-11-30 A | 100% | 2000-11-06 | 2001-11-30 | 280d | finish no earlier than 2001-11-30 | GP | 2240h | 2240h | Rel-5 | Paolo |  |  |  |  |
| 5073 | 109.2 | **Iu rg interface** | 430d | 2000-11-06 A | 2002-06-28 A | 100% | 2000-11-06 | 2002-06-28 | 430d |  | GP; RP | 61920h | 61920h | Rel-5 | Paolo | GER3GAL-Iurg | Ericsson | Frank Muller | GER3GAL-Iurg |
| 5074 | 109.2.1 | **Inter BSS interface** | 430d | 2000-11-06 A | 2002-06-28 A | 100% | 2000-11-06 | 2002-06-28 | 430d |  | GP; RP | 24080h | 24080h | Rel-5 | Paolo |  |  |  |  |
| 5075 | 109.2.1.1 | Identification of requirements for Inter BSS interface | 430d | 2000-11-06 A | 2002-06-28 A | 100% | 2000-11-06 | 2002-06-28 | 430d | finish no earlier than 2002-06-28 | GP | 3440h | 3440h | Rel-5 | Paolo |  |  |  |  |
| 5076 | 109.2.1.2 | Stage 2 for Inter BSS interface | 430d | 2000-11-06 A | 2002-06-28 A | 100% | 2000-11-06 | 2002-06-28 | 430d | finish no earlier than 2002-06-28 | GP | 3440h | 3440h | Rel-5 | Paolo |  |  |  |  |
| 5077 | 109.2.1.3 | Adoption of relevant parts from Iur - for Inter BSS interface | 430d | 2000-11-06 A | 2002-06-28 A | 100% | 2000-11-06 | 2002-06-28 | 430d | finish no earlier than 2002-06-28 | GP | 3440h | 3440h | Rel-5 | Paolo |  |  |  |  |
| 5078 | 109.2.1.4 | Complementation with GERAN specifics - for Inter BSS interface | 430d | 2000-11-06 A | 2002-06-28 A | 100% | 2000-11-06 | 2002-06-28 | 430d | finish no earlier than 2002-06-28 | GP | 3440h | 3440h | Rel-5 | Paolo |  |  |  |  |
| 5079 | 109.2.1.5 | Stage 3 for Inter BSS interface | 430d | 2000-11-06 A | 2002-06-28 A | 100% | 2000-11-06 | 2002-06-28 | 430d | finish no earlier than 2002-06-28 | GP | 3440h | 3440h | Rel-5 | Paolo |  |  |  |  |
| 5080 | 109.2.2 | **Inter BSS-RNS interface** | 430d | 2000-11-06 A | 2002-06-28 A | 100% | 2000-11-06 | 2002-06-28 | 430d |  | GP; RP | 30960h | 30960h | Rel-5 | Paolo |  |  |  |  |
| 5081 | 109.2.2.1 | Identification of requirements for Inter BSS-RNS interface | 430d | 2000-11-06 A | 2002-06-28 A | 100% | 2000-11-06 | 2002-06-28 | 430d | start no earlier than 2000-11-06 | GP; R3 | 6880h | 6880h | Rel-5 | Paolo |  |  |  |  |
| 5082 | 109.2.2.2 | Stage 2 for Inter BSS-RNS interface | 430d | 2000-11-06 A | 2002-06-28 A | 100% | 2000-11-06 | 2002-06-28 | 430d | finish no earlier than 2002-06-28 | GP; R3 | 6880h | 6880h | Rel-5 | Paolo |  |  |  |  |
| 5083 | 109.2.2.3 | Adoption of relevant parts from Iur - for Inter BSS-RNS interface | 430d | 2000-11-06 A | 2002-06-28 A | 100% | 2000-11-06 | 2002-06-28 | 430d | finish no earlier than 2002-06-28 | GP; R3 | 6880h | 6880h | Rel-5 | Paolo |  |  |  |  |
| 5084 | 109.2.2.4 | Complementation with GERAN specifics - for Inter BSS-RNS interface | 107.5d | 2002-01-30 A | 2002-06-28 A | 100% | 2002-01-30 | 2002-06-28 | 107.5d | finish no earlier than 2002-06-28 | GP; R3 | 1720h | 1720h | Rel-5 | Paolo |  |  |  |  |
| 5085 | 109.2.2.5 | Stage 3 for Inter BSS-RNS interface | 107.5d | 2002-01-30 A | 2002-06-28 A | 100% | 2002-01-30 | 2002-06-28 | 107.5d | finish no earlier than 2002-06-28 | GP; R3 | 1720h | 1720h | Rel-5 | Paolo |  |  |  |  |
| 5086 | 109.3 | **Voice over GERAN PS and CS concept** | 430d | 2000-11-06 A | 2002-06-28 A | 100% | 2000-11-06 | 2002-06-28 | 430d |  | GP; R3 | 35200h | 35200h | Rel-5 | Paolo |  |  |  |  |
| 5087 | 109.3.1 | Architecture for A, Iu cs and Iu ps | 430d | 2000-11-06 A | 2002-06-28 A | 100% | 2000-11-06 | 2002-06-28 | 430d | finish no earlier than 2002-06-28 | GP; R3 | 6880h | 6880h | Rel-5 | Paolo |  |  |  |  |
| 5088 | 109.3.2 | Transcoder position/operation | 115d | 2000-11-06 A | 2001-04-13 A | 100% | 2000-11-06 | 2001-04-13 | 115d | finish no earlier than 2001-04-13 | GP | 920h | 920h | Rel-5 | Paolo |  |  |  |  |
| 5089 | 109.3.3 | Handover for Voice over GERAN PS and CS | 430d | 2000-11-06 A | 2002-06-28 A | 100% | 2000-11-06 | 2002-06-28 | 430d | finish no earlier than 2002-06-28 | GP; R3 | 6880h | 6880h | Rel-5 | Paolo |  |  |  |  |
| 5090 | 109.3.4 | RTP payload | 430d | 2000-11-06 A | 2002-06-28 A | 100% | 2000-11-06 | 2002-06-28 | 430d | finish no earlier than 2002-06-28 | GP; R3 | 6880h | 6880h | Rel-5 | Paolo |  |  |  |  |
| 5091 | 109.3.5 | Codec renegotiation concept | 365d | 2000-11-06 A | 2002-03-29 A | 100% | 2000-11-06 | 2002-03-29 | 365d | finish no earlier than 2002-03-29 | GP; R3 | 5840h | 5840h | Rel-5 | Paolo |  |  |  |  |
| 5092 | 109.3.6 | LA | 115d | 2000-11-06 A | 2001-04-13 A | 100% | 2000-11-06 | 2001-04-13 | 115d | finish no earlier than 2001-04-13 | GP | 920h | 920h | Rel-5 | Paolo |  |  |  |  |

Notes:
- 5069: -
- 5070: -
- 5071: -
- 5072: -
- 5073: AWS, Nokia, Ericsson, Nortel, Siemens, Vodafone
- 5074: -
- 5075: -
- 5076: -
- 5077: -
- 5078: -
- 5079: -
- 5080: -
- 5081: -
- 5082: -
- 5083: -
- 5084: -
- 5085: -
- 5086: -
- 5087: -
- 5088: -
- 5089: -
- 5090: -
- 5091: -
- 5092: -

| ID | WBS | Task | Duration | Start | Finish | Complete | Baseline start | Baseline finish | Baseline duration | Constraint | Resources | Work | Actual work | Release | MCC resp | TSG stopped | Acronym | WI rapporteur name | WI rapporteur e-mail | Acronym_3GU_Export | Impacted TSs and TRs |
| --- | --- | --- | --- | --- | --- | --- | --- | --- | --- | --- | --- | --- | --- | --- | --- | --- | --- | --- | --- | --- | --- |
| 5093 | 109.4 | **Deleted - GERAN MS Conformance test for GERAN interface evolution** | 660d | 2001-06-11 A | 2003-12-19 A | 100% | 2001-06-11 | 2003-12-19 | 660d |  | GP | 10560h | 10560h | Rel-5 | Paolo | GP-17 |  |  |  |  |  |
| 5094 | 109.4.1 | Deleted - MS test for GERAN interface evolution | 660d | 2001-06-11 A | 2003-12-19 A | 100% | 2001-06-11 | 2003-12-19 | 660d | finish no earlier than 2003-12-19 | GP | 5280h | 5280h | Rel-5 | Paolo | GP-17 |  |  |  |  |  |
| 5095 | 109.5 | **GERAN BSS Conformance test for GERAN interface evolution** | 922d | 2000-06-08 A | 2003-12-19 A | 100% | 2000-06-08 | 2003-12-19 | 922d |  | GP | 14752h | 14752h | Rel-5 | Paolo |  |  |  |  |  |  |
| 5096 | 109.5.1 | Deleted - BSS test | 922d | 2000-06-08 A | 2003-12-19 A | 100% | 2000-06-08 | 2003-12-19 | 922d | finish no earlier than 2003-12-19 | GP | 7376h | 7376h | Rel-5 | Paolo | GP-17 |  |  |  |  |  |
| 5097 | 110 | **GERAN support for IMS** | 690d | 2000-05-01 A | 2002-12-20 A | 100% | 2000-05-01 | 2002-12-20 | 690d |  | GP | 83939.6h | 83939.6h | Rel-5 | Paolo |  | GERIMS | Nokia | Shkumbin Hamiti | GERIMS |  |
| 5098 | 110.1 | **GERAN Header adaptation** | 690d | 2000-05-01 A | 2002-12-20 A | 100% | 2000-05-01 | 2002-12-20 | 690d |  | GP; S2; RP | 40011.6h | 40011.6h | Rel-5 | Paolo |  | GERIMS-HEADAPT | Nokia | Shkumbin Hamiti | GERIMS-HEADAPT |  |
| 5099 | 110.1.1 | Definition of compression and removal modes for PDCP protocol | 29.15d | 2000-07-24 A | 2000-09-01 A | 100% | 2000-07-24 | 2000-09-01 | 29.15d | finish no earlier than 2000-09-01 | GP; S2; RP | 699.6h | 699.6h | Rel-5 | Paolo |  |  |  |  |  |  |
| 5100 | 110.1.2 | Conceptual description in stage 2 | 393d | 2000-05-01 A | 2001-10-31 A | 100% | 2000-05-01 | 2001-10-31 | 393d | finish no earlier than 2001-10-31 | GP; S2; RP | 9432h | 9432h | Rel-5 | Paolo |  |  |  |  |  |  |
| 5101 | 110.1.3 | Necessary changes on stage 3 regarding header removal | 555d | 2000-11-06 A | 2002-12-20 A | 100% | 2000-11-06 | 2002-12-20 | 555d | finish no earlier than 2002-12-20 | GP; S2; RP | 13320h | 13320h | Rel-5 | Paolo |  |  |  |  |  |  |
| 5102 | 110.2 | **Deleted - GERAN Radio access bearer design for IMS** | 430d | 2000-11-06 A | 2002-06-28 A | 100% | 2000-11-06 | 2002-06-28 | 430d |  | GP; S2; RP | 29520h | 29520h | Rel-5 | Paolo | GP-10 | GERIMS-RABDES | Nokia | Shkumbin Hamiti | GERIMS-RABDES |  |
| 5103 | 110.2.1 | **Deleted - MuM control signalling for conversational multimedia services** | 430d | 2000-11-06 A | 2002-06-28 A | 100% | 2000-11-06 | 2002-06-28 | 430d |  | GP; S2; RP | 19200h | 19200h | Rel-5 | Paolo | GP-10 |  |  |  |  |  |
| 5104 | 110.2.1.1 | Deleted - Identification of requirements for MuM control signalling for conversational multimedia services | 330d | 2000-11-06 A | 2002-02-08 A | 100% | 2000-11-06 | 2002-02-08 | 330d | finish no earlier than 2002-02-08 | GP; S2; RP | 7920h | 7920h | Rel-5 | Paolo | GP-08 |  |  |  |  |  |
| 5105 | 110.2.1.2 | Deleted - Necessary modifications due to SIP | 40d | 2002-05-06 A | 2002-06-28 A | 100% | 2002-05-06 | 2002-06-28 | 40d | finish no earlier than 2002-06-28 | GP; S2; RP | 960h | 960h | Rel-5 | Paolo | GP-10 |  |  |  |  |  |
| 5106 | 110.3 | **Deleted - GERAN MS Conformance test for support of IMS** | 400d | 2001-06-11 A | 2002-12-20 A | 100% | 2001-06-11 | 2002-12-20 | 400d |  | GP | 6400h | 6400h | Rel-5 | Paolo | GP-12 | GERIMS-MSconf | Nokia | Shkumbin Hamiti | GERIMS-MSconf |  |
| 5107 | 110.3.1 | Deleted - MS test for support of IMS | 400d | 2001-06-11 A | 2002-12-20 A | 100% | 2001-06-11 | 2002-12-20 | 400d | finish no earlier than 2002-12-20 | G4 | 3200h | 3200h | Rel-5 | Paolo | GP-12 |  |  |  |  |  |
| 5108 | 110.4 | Deleted - GERAN BTS Conformance test for support of IMS | 400d | 2001-06-11 A | 2002-12-20 A | 100% | 2001-06-11 | 2002-12-20 | 400d |  | GP | 3200h | 3200h | Rel-5 | Paolo | GP-12 | GERIMS-BTSconf | Nokia | Shkumbin Hamiti | GERIMS-BTSconf |  |
| 5109 | 1235 | MS Conformance Testing of Dual Transfer Mode | 65d? | 2002-11-11 A | 2003-02-07 A | 100% | 2002-11-11 | 2003-02-07 | 65d? | finish no earlier than 2003-02-07 | G4; G5 | 1040h | 1040h | Rel-5 | Paolo |  | MSCTDTM | Vodafone | Dave Fox | MSCTDTM |  |
| 5110 | 1236 | **Handling of early Ues** | 911d? | 2000-01-03 A | 2003-06-27 A | 100% | 2000-01-03 | 2003-06-27 | 911d? |  | S2 | 4488h | 4488h | Rel-5 | Maurice |  | LATE_UE |  |  | LATE_UE |  |
| 5111 | 1236.1 | Feasibility Study on Handling of early Ues | 50d? | 2002-10-07 A | 2002-12-13 A | 100% | 2002-10-07 | 2002-12-13 | 50d? | finish no earlier than 2002-12-13 | S2 | 400h | 400h | Rel-5 | Maurice |  |  |  |  |  |  |
| 5112 | 1236.2 | Stage 2 for Handling of early Ues | 125d? | 2003-01-06 A | 2003-06-27 A | 100% | 2003-01-06 | 2003-06-27 | 125d? | start no earlier than 2003-01-06 | S2 | 1000h | 1000h | Rel-5 | Maurice |  |  |  |  |  |  |
| 5113 | 1236.3 | FS for the Early Mobile Handling in UTRAN | 195d | 2002-09-09 A | 2003-06-06 A | 100% | 2002-09-09 | 2003-06-06 | 195d | finish no earlier than 2003-06-06 | R2 | 1560h | 1560h | Rel-5 | Yong-Jun |  | FSEarlyUE | Vodafone | alan.law@vodafone.com | FSEarlyUE |  |
| 5114 | 1236.4 | Note: Stage 3 RAN part not shown | 1d | 2000-01-03 A | 2000-01-03 A | 100% | 2000-01-03 | 2000-01-03 | 1d |  | RP | 8h | 8h | Rel-5 |  |  |  |  |  |  |  |
| 5115 | 1237 | Release 4 Features | 326d? | 2000-01-03 A | 2001-03-30 A | 100% | 2000-01-03 | 2001-03-30 | 326d? |  | NP; GP; RP; SP; TP | 13040h | 13040h | Rel-4 | All |  |  |  |  |  |  |
| 5116 | 15 | **Miscellaneous UE Conformance Testing Activities** | 958d | 2001-04-02 A | 2004-12-01 A | 100% | 2001-04-02 | 2004-12-01 | 958d |  | T1 | 36360h | 36360h | Rel-4 | Ingbert |  | MISTST1 |  |  | MISTST1 |  |
| 5117 | 15.1 | Optimization of Test Time, RF Aspects (FDD) | 508d | 2001-09-24 A | 2003-09-03 A | 100% | 2001-09-24 | 2003-09-03 | 508d | finish no earlier than 2003-09-03 | T1 | 4064h | 4064h | Rel-4 | Ingbert |  | MISTST1-OpFDD |  |  | MISTST1-OpFDD | 34.121 |
| 5118 | 15.2 | Optimization of Test Time, RF Aspects (TDD) | 508d | 2001-09-24 A | 2003-09-03 A | 100% | 2001-09-24 | 2003-09-03 | 508d | finish no earlier than 2003-09-03 | T1 | 4064h | 4064h | Rel-4 | Ingbert |  | MISTST1-OpTDD |  |  | MISTST1-OpTDD | 34.122 |
| 5119 | 15.3 | Extensions to R99 Test cases | 139.4w | 2001-04-02 A | 2003-12-02 A | 100% | 2001-04-02 | 2003-12-02 | 139.4w | finish no earlier than 2003-12-02 | T1 | 5576h | 5576h | Rel-4 | Ingbert |  | MISTST1-Ext |  |  | MISTST1-Ext | 34.123 p 1,2 |
| 5120 | 15.4 | Extension to R99 Test cases - TTCN | 439d | 2002-06-28 A | 2004-03-03 A | 100% | 2002-06-28 | 2004-03-03 | 439d | finish no earlier than 2004-03-03 | T1 | 3512h | 3512h | Rel-4 | Ingbert |  |  |  |  |  |  |
| 5121 | 15.5 | Creation of R99 TCs for TDD - prose | 719d | 2001-10-01 A | 2004-07-01 A | 100% | 2001-10-01 | 2004-07-01 | 719d | finish no earlier than 2004-07-01 | T1 | 5752h | 5752h | Rel-4 | Ingbert |  | MISTST1-TDD |  |  | MISTST1-TDD | 34.123-1 |
| 5122 | 15.6 | Deleted - Creation of R99 TCs for TDD - TTCN | 587d | 2002-09-03 A | 2004-12-01 A | 100% | 2002-09-03 | 2004-12-01 | 587d | finish no earlier than 2004-12-01 | T1 | 4696h | 4696h | Rel-4 | Ingbert | TP-26 |  |  |  |  |  |
| 5123 | 15.7 | Deleted - Review all other work items for impact on new or exiting 34 series specs. | 25.8w | 2002-07-02 A | 2002-12-27 A | 100% | 2002-07-02 | 2002-12-27 | 25.8w | finish no earlier than 2002-12-27 | T1 | 1032h | 1032h | Rel-4 | Ingbert | TP-18 |  |  |  |  | 34.121,122,123,125 |

Notes:
- 5093: Not started. Marked as stopped 12/2008
- 5094: Not started. Marked as stopped 12/2008
- 5095: Not started. Marked as stopped 12/2008
- 5096: Not started. Marked as stopped 12/2008
- 5097: AWS, Nokia, Ericsson, Nortel, Siemens, Motorola
- 5098: AWS, Nokia, Ericsson, Nortel, Siemens, Motorola
- 5099: -
- 5100: -
- 5101: -
- 5102: TERMINATED - NOT STANDARDIZED. Marked as stopped 12/2008
- 5103: TERMINATED - NOT STANDARDIZED. Marked as stopped 12/2008
- 5104: TERMINATED - NOT STANDARDIZED
- 5105: TERMINATED - NOT STANDARDIZED
- 5106: TERMINATED - NOT STANDARDIZED. Marked as stopped 12/2008
- 5107: TERMINATED - NOT STANDARDIZED. Marked as stopped 12/2008
- 5108: TERMINATED - NOT STANDARDIZED. Marked as stopped 12/2008
- 5109: Needed to complete DTM (R99)
- 5110: -
- 5111: -
- 5112: -
- 5113: -
- 5114: -
- 5115: -
- 5116: -
- 5117: It is believed that the current R99 test spec. can be optimised for faster overall test times. Marked as stopped 12/2008 (was 70% complete)
- 5118: It is believed that the current R99 test spec. can be optimised for faster overall test times
- 5119: Further test coverage of the R99 specification to cover supplementry services. Marked as stopped 12/2008 (was 70% complete)
- 5120: Marked as closed 12/2008 (was marked 50% complete)
- 5121: Marked as closed 12/2008 (was marked 50% complete)
- 5122: Marked as stopped 12/2008
- 5123: Marked as stopped 12/2008

| ID | WBS | Task | Duration | Start | Finish | Predecessors | Complete | Baseline start | Baseline finish | Baseline duration | Constraint | Resources | Work | Actual work | Acronym | Release | MCC resp | Acronym_3GU_Export | Impacted TSs and TRs | WI rapporteur name | WI rapporteur e-mail |
| --- | --- | --- | --- | --- | --- | --- | --- | --- | --- | --- | --- | --- | --- | --- | --- | --- | --- | --- | --- | --- | --- |
| 5124 | 46 | **Real Time Facsimile** | 89d | 2000-02-22 A | 2000-06-23 A |  | 100% | 2000-02-22 | 2000-06-23 | 89d |  | S1 | 4376h | 4376h | FAX-RT | Rel-4 | Alain | FAX-RT |  |  |  |
| 5125 | 46.1 | **Real Time Fax** | 89d | 2000-02-22 A | 2000-06-23 A |  | 100% | 2000-02-22 | 2000-06-23 | 89d |  | S2 | 3664h | 3664h |  | Rel-4 | Maurice |  |  |  |  |
| 5126 | 46.1.1 | Terminal capabilities, AT commands | 89d | 2000-02-22 A | 2000-06-23 A |  | 100% | 2000-02-22 | 2000-06-23 | 89d | finish no earlier than 2000-06-23 | T2 | 712h | 712h |  | Rel-4 |  |  | 21.904, 27.007 |  |  |
| 5127 | 46.1.2 | Signalling aspects (e.g. ICM) | 89d | 2000-02-22 A | 2000-06-23 A |  | 100% | 2000-02-22 | 2000-06-23 | 89d | start no earlier than 2000-02-22 | N1 | 712h | 712h |  | Rel-4 | Frederic |  |  |  |  |
| 5128 | 46.1.3 | Service provision | 89d | 2000-02-22 A | 2000-06-23 A |  | 100% | 2000-02-22 | 2000-06-23 | 89d | finish no earlier than 2000-06-23 | N3 | 712h | 712h |  | Rel-4 | Gwiho |  | 23.146 |  |  |
| 5129 | 46.1.4 | Review whether service/stage 1 aspects need to be aligned | 51d | 2000-04-14 A | 2000-06-23 A |  | 100% | 2000-04-14 | 2000-06-23 | 51d | finish no earlier than 2000-12-14 | S1 | 408h | 408h |  | Rel-4 | Alain |  |  |  |  |
| 5130 | 46.1.5 | Review whether architecture/stage 2 aspects need to be aligned | 51d | 2000-04-14 A | 2000-06-23 A |  | 100% | 2000-04-14 | 2000-06-23 | 51d | finish no earlier than 2000-12-14 | S2 | 408h | 408h |  | Rel-4 | Maurice |  |  |  |  |
| 5131 | 47 | Transparent End-to-End PS mobile streaming application | 253d | 2000-04-03 A | 2001-03-21 A |  | 100% | 2000-04-03 | 2001-03-21 | 253d | finish no earlier than 2000-12-29 | S4 | 2024h | 2024h | PSTREAM | Rel-4 | Paolo | PSTREAM | 26.233, 26.234 |  |  |
| 5132 | 48 | **Multimedia Messaging** | 277d | 2000-02-22 A | 2001-03-14 A |  | 100% | 2000-02-22 | 2001-03-14 | 277d |  | T2; S1 | 14424h | 14424h | MMS4 | Rel-4 | Kimmo | MMS, Rel-4 | 22.140, 23.140 | Siemens | Josef.Laumen@SAL.SIEMENS.DE |
| 5133 | 48.1 | Definition of service requirements for Multimedia Messaging | 72d | 2000-02-22 A | 2000-05-31 A |  | 100% | 2000-02-22 | 2000-05-31 | 72d | start no earlier than 2000-02-22 | S1 | 576h | 576h |  | Rel-4 | Alain |  |  |  |  |
| 5134 | 48.2 | Review of definition of service requirements | 205d | 2000-06-01 A | 2001-03-14 A | 5133 | 100% | 2000-06-01 | 2001-03-14 | 205d | finish no earlier than 2000-09-08 | T2 | 1640h | 1640h |  | Rel-4 | Kimmo |  | 22.140, 23.140 | Siemens |  |
| 5135 | 48.3 | **Technical Realisation** | 243d | 2000-04-10 A | 2001-03-14 A |  | 100% | 2000-04-10 | 2001-03-14 | 243d |  | T2 | 7776h | 7776h |  | Rel-4 | Kimmo |  | 22.140, 23.140 | Siemens | Josef.Laumen@SAL.SIEMENS.DE |
| 5136 | 48.3.1 | Review of definition of reference Achitecture model | 243d | 2000-04-10 A | 2001-03-14 A |  | 100% | 2000-04-10 | 2001-03-14 | 243d | finish no earlier than 2001-03-14 | T2 | 1944h | 1944h |  | Rel-4 | Kimmo |  | 22.140, 23.140 | Siemens | Josef.Laumen@SAL.SIEMENS.DE |
| 5137 | 48.3.2 | Fulfill Requirements of Stage 1 | 243d | 2000-04-10 A | 2001-03-14 A |  | 100% | 2000-04-10 | 2001-03-14 | 243d | finish no earlier than 2001-03-14 | T2 | 1944h | 1944h |  | Rel-4 | Kimmo |  | 22.140, 23.140 | Siemens | Josef.Laumen@SAL.SIEMENS.DE |
| 5138 | 48.3.3 | Definition of MMS primitives in Stage 2 | 243d | 2000-04-10 A | 2001-03-14 A |  | 100% | 2000-04-10 | 2001-03-14 | 243d | finish no earlier than 2001-03-14 | T2 | 1944h | 1944h |  | Rel-4 | Kimmo |  | 22.140, 23.140 | Siemens | Josef.Laumen@SAL.SIEMENS.DE |
| 5139 | 49 | **Transcoder-Free Operation** | 326d | 2000-01-03 A | 2001-03-30 A |  | 100% | 2000-01-03 | 2001-03-30 | 326d |  | N4; S2; N1 | 18272h | 18272h | TrFO | Rel-4 | Kimmo | TrFO |  |  |  |
| 5140 | 49.1 | **Out-of-Band Transcoder Control solution** | 326d | 2000-01-03 A | 2001-03-30 A |  | 100% | 2000-01-03 | 2001-03-30 | 326d |  | N4 | 8448h | 8448h | TrFO-OoBTC | Rel-4 | Kimmo | TrFO-OoBTC |  | NEC | Toshiyuki Tamura (tamurato@aj.jp.nec.com) |
| 5141 | 49.1.1 | implementation in UTRAN | 145d | 2000-09-11 A | 2001-03-30 A |  | 100% | 2000-09-11 | 2001-03-30 | 145d | finish no earlier than 2001-03-30 | R3 | 1160h | 1160h | TrFO-OoBTC-UTRAN | Rel-4 | Juha | TrFO-OoBTC-UTRAN | 25.401, 25.410, 25.413, 25.415, 23.153 | Siemens | Alexander Vesely |
| 5142 | 49.1.2 | Impact on architecture, Principles and Terminology | 211d | 2000-01-03 A | 2000-10-20 A |  | 100% | 2000-01-03 | 2000-10-20 | 211d | finish no earlier than 2000-10-20 | S2 | 1680h | 1680h |  | Rel-4 | Maurice |  |  |  |  |
| 5143 | 49.1.3 | Codec Negotiation between UE and MSC | 125d | 2000-08-14 A | 2001-02-02 A |  | 100% | 2000-08-14 | 2001-02-02 | 125d | finish no earlier than 2001-02-02 | N1 | 1000h | 1000h |  | Rel-4 | Frederic |  | 24.008, 23.009, 23.108, (29.002) | Motorola | Andrew Howell |
| 5144 | 49.1.4 | Codec Negotiation inter MSC | 125d | 2000-07-03 A | 2000-12-22 A |  | 100% | 2000-07-03 | 2000-12-22 | 125d | finish no earlier than 2000-12-22 | N4 | 1000h | 1000h |  | Rel-4 | Kimmo |  |  |  |  |
| 5145 | 49.1.5 | Bearer establishment inter MSC | 125d | 2000-07-03 A | 2000-12-22 A |  | 100% | 2000-07-03 | 2000-12-22 | 125d | finish no earlier than 2000-12-22 | N4 | 1000h | 1000h |  | Rel-4 | Kimmo |  | 23.153 |  |  |
| 5146 | 49.2 | **Speech Transcoder: Location and Control at the UMTS Core Network Border** | 125d | 2000-04-10 A | 2000-09-29 A |  | 100% | 2000-04-10 | 2000-09-29 | 125d |  | S2 | 2000h | 2000h | TrFO-STLC | Rel-4 | Maurice | TrFO-STLC |  |  |  |
| 5147 | 49.2.1 | Transcoder at Edge | 125d | 2000-04-10 A | 2000-09-29 A |  | 100% | 2000-04-10 | 2000-09-29 | 125d | finish no earlier than 2000-09-29 | NP | 1000h | 1000h |  | Rel-4 | Kimmo |  |  |  |  |

Notes:
- 5124: -
- 5125: postponed from R99 to R00, SP-000169
- 5126: -
- 5127: -
- 5128: -
- 5129: -
- 5130: -
- 5131: -
- 5132: Acronym changed from "MMS, Rel-4"
- 5133: -
- 5134: -
- 5135: -
- 5136: -
- 5137: e.g. minimum set of media formats, media format conversion, personalization of MMS.
- 5138: -
- 5139: Lead given to CN4 from CN / [DAB 28/11/00]
- 5140: -
- 5141: moved according to NP-000575
- 5142: e.g. study cascading TrFO/TFO/TrFO
- 5143: the link to NP-000085has been deleted because refering to a R99 status sheet / One common set of codec negotiation procedures will be specified as in ID1656.
- 5144: Bearer establishment inter MSC. TS 23.153 R99 part complete. capabilities moved to annex + list of open issues
- 5145: Bearer establishment inter MSC. TS 23.153 R99 part complete. capabilities moved to annex. / See NP-000127 / Open issues: / Handling of Conference Calls; / Handling of Multi Party Supplementary Services; / Handling of Handover UMTS to GSM; / Handling of Sending a ...
- 5146: WI description and Tdoc S2-99352 / Speech Transcoder: Location and Control at the UMTS Core Network Border
- 5147: WI description and Tdoc S2-99352...

| ID | WBS | Task | Duration | Start | Finish | Complete | Baseline start | Baseline finish | Baseline duration | Constraint | Resources | Work | Actual work | Acronym | Release | MCC resp | Acronym_3GU_Export | WI rapporteur name | WI rapporteur e-mail |
| --- | --- | --- | --- | --- | --- | --- | --- | --- | --- | --- | --- | --- | --- | --- | --- | --- | --- | --- | --- |
| 5148 | 50 | **GERAN improvements 1 (Gb over IP)** | 225d | 2000-05-09 A | 2001-03-19 A | 100% | 2000-05-09 | 2001-03-19 | 225d |  | GP | 6472h | 6472h | GEIMP1 | Rel-4 | Paolo | GEIMP1 |  |  |
| 5149 | 50.1 | **Gb over IP (Ip-fication of Gb)** | 225d | 2000-05-09 A | 2001-03-19 A | 100% | 2000-05-09 | 2001-03-19 | 225d |  | GP | 4672h | 4672h | GbIP | Rel-4 | Paolo | GbIP |  |  |
| 5150 | 50.1.1 | Concept of Gb over IP (Ip-fication of Gb) | 134d | 2000-05-09 A | 2000-11-10 A | 100% | 2000-05-09 | 2000-11-10 | 134d |  | GP | 1072h | 1072h |  | Rel-4 | Paolo |  |  |  |
| 5151 | 50.1.2 | Changes to 08.16, 08.18 | 225d | 2000-05-09 A | 2001-03-19 A | 100% | 2000-05-09 | 2001-03-19 | 225d |  | GP | 1800h | 1800h |  | Rel-4 | Paolo |  |  |  |
| 5152 | 51 | **GERAN improvements 2 (NACC)** | 677d | 2000-11-06 A | 2003-06-10 A | 100% | 2000-11-06 | 2003-06-10 | 677d |  | GP | 22408h | 22408h | GEIMP2 | Rel-4 | Paolo | GEIMP2 |  |  |
| 5153 | 51.1 | **Gb enhancements** | 155d | 2000-11-06 A | 2001-06-08 A | 100% | 2000-11-06 | 2001-06-08 | 155d |  | GP | 7440h | 7440h | Gben | Rel-4 | Paolo | Gben |  |  |
| 5154 | 51.1.1 | **Intra BSC NACC (Network Assisted Cell Change)** | 155d | 2000-11-06 A | 2001-06-08 A | 100% | 2000-11-06 | 2001-06-08 | 155d |  | GP | 6200h | 6200h |  | Rel-4 | Paolo |  |  |  |
| 5155 | 51.1.1.1 | Concept | 155d | 2000-11-06 A | 2001-06-08 A | 100% | 2000-11-06 | 2001-06-08 | 155d | finish no earlier than 2001-06-08 | GP | 1240h | 1240h |  | Rel-4 | Paolo |  |  |  |
| 5156 | 51.1.1.2 | Changes in 03.64 | 155d | 2000-11-06 A | 2001-06-08 A | 100% | 2000-11-06 | 2001-06-08 | 155d | finish no earlier than 2001-06-08 | GP | 1240h | 1240h |  | Rel-4 | Paolo |  |  |  |
| 5157 | 51.1.1.3 | Changes in 04.60 | 155d | 2000-11-06 A | 2001-06-08 A | 100% | 2000-11-06 | 2001-06-08 | 155d | finish no earlier than 2001-06-08 | GP | 1240h | 1240h |  | Rel-4 | Paolo |  |  |  |
| 5158 | 51.1.1.4 | Changes in 44.008 | 155d | 2000-11-06 A | 2001-06-08 A | 100% | 2000-11-06 | 2001-06-08 | 155d | finish no earlier than 2001-06-08 | GP | 1240h | 1240h |  | Rel-4 | Paolo |  |  |  |
| 5159 | 51.3 | **MS conformance test for Intra BSC NACC** | 398d | 2001-11-30 A | 2003-06-10 A | 100% | 2001-11-30 | 2003-06-10 | 398d |  | GP | 9552h | 9552h | GEIMP2-Msconf | Rel-4 | Paolo | GEIMP2-Msconf |  |  |
| 5160 | 51.3.1 | Changes in 51.010 | 398d | 2001-11-30 A | 2003-06-10 A | 100% | 2001-11-30 | 2003-06-10 | 398d | finish no earlier than 2003-12-19 | G5; G4 | 6368h | 6368h |  | Rel-4 | Paolo |  |  |  |
| 5161 | 52 | **GERAN improvements 4 (Delayed TBF)** | 105d | 2001-01-15 A | 2001-06-08 A | 100% | 2001-01-15 | 2001-06-08 | 105d |  | GP | 3960h | 3960h | GEIMP4 | Rel-4 | Paolo | GEIMP4 |  |  |
| 5162 | 52.1 | **Gb enhancements 2** | 105d | 2001-01-15 A | 2001-06-08 A | 100% | 2001-01-15 | 2001-06-08 | 105d |  | GP | 3120h | 3120h | GEIMP4-Gben2 | Rel-4 | Paolo | GEIMP4-Gben2 |  |  |
| 5163 | 52.1.1 | Stage 2 for Gb enhancements 2 | 105d | 2001-01-15 A | 2001-06-08 A | 100% | 2001-01-15 | 2001-06-08 | 105d | finish no earlier than 2001-06-08 | GP | 840h | 840h |  | Rel-4 | Paolo |  |  |  |
| 5164 | 52.1.2 | **Stage 3 (changes in 44.060)** | 60d | 2001-01-15 A | 2001-04-06 A | 100% | 2001-01-15 | 2001-04-06 | 60d |  | G2 | 1440h | 1440h |  | Rel-4 | Gert |  |  |  |
| 5165 | 52.1.2.1 | Definition of enhanced countdown procedure | 60d | 2001-01-15 A | 2001-04-06 A | 100% | 2001-01-15 | 2001-04-06 | 60d | finish no earlier than 2001-04-06 | G2 | 480h | 480h |  | Rel-4 | Gert |  |  |  |
| 5166 | 52.1.2.2 | Definition of enhanced TBF release procedure | 60d | 2001-01-15 A | 2001-04-06 A | 100% | 2001-01-15 | 2001-04-06 | 60d | finish no earlier than 2001-04-06 | G2 | 480h | 480h |  | Rel-4 | Gert |  |  |  |
| 5167 | 52.1.2.3 | Definition of USF=FREE type polling mechanism on PDCH | 60d | 2001-01-15 A | 2001-04-06 A | 100% | 2001-01-15 | 2001-04-06 | 60d | finish no earlier than 2001-04-06 | G2 | 480h | 480h |  | Rel-4 | Gert |  |  |  |
| 5168 | 53 | **Low Chip Rate TDD option** | 880d | 2000-07-19 A | 2003-12-02 A | 100% | 2000-07-19 | 2003-12-02 | 880d |  | R1 | 27488h | 27488h | LCRTDD | Rel-4 | Patrick | LCRTDD | CWTS | G. Yang |
| 5169 | 53.1 | Physical layer for Low Chip Rate TDD option | 183d | 2000-07-19 A | 2001-03-30 A | 100% | 2000-07-19 | 2001-03-30 | 183d | finish no earlier than 2001-03-30 | R1 | 1464h | 1464h | LCRTDD-Phys | Rel-4 | Patrick | LCRTDD-Phys | CWTS | G. Yang |
| 5170 | 53.2 | Layer 2 and layer 3 protocol aspects | 183d | 2000-07-19 A | 2001-03-30 A | 100% | 2000-07-19 | 2001-03-30 | 183d | finish no earlier than 2001-03-30 | R2 | 1464h | 1464h | LCRTDD-L23 | Rel-4 | Yong-Jun | LCRTDD-L23 | CWTS | Y. Liu |
| 5171 | 53.3 | RF radio transmission/reception, system performance requirements and conformance testing | 165d | 2000-08-14 A | 2001-03-30 A | 100% | 2000-08-14 | 2001-03-30 | 165d | finish no earlier than 2001-03-30 | R4 | 1320h | 1320h | LCRTDD-RF | Rel-4 | Issam | LCRTDD-RF | CWTS | D. Zhang |
| 5172 | 53.4 | UE radio access capability | 165d | 2000-08-14 A | 2001-03-30 A | 100% | 2000-08-14 | 2001-03-30 | 165d | finish no earlier than 2001-03-30 | R2 | 1320h | 1320h | LCRTDD-UErac | Rel-4 | Yong-Jun | LCRTDD-UErac | CWTS | Y. Liu |
| 5173 | 53.5 | Iub/Iur protocol aspects - for Low Chip Rate TDD option | 165d | 2000-08-14 A | 2001-03-30 A | 100% | 2000-08-14 | 2001-03-30 | 165d | finish no earlier than 2001-03-30 | R3 | 1320h | 1320h | LCRTDD-IubIur | Rel-4 | Juha | LCRTDD-IubIur | CWTS | Y. Liu |

Notes:
- 5148: -
- 5149: -
- 5150: -
- 5151: -
- 5152: -
- 5153: -
- 5154: -
- 5155: -
- 5156: -
- 5157: -
- 5158: -
- 5159: -
- 5160: az 05/08: duplicated UID_50099 => 50299. Marked as closed 12/2008 (was marked 50% complete)
- 5161: -
- 5162: -
- 5163: -
- 5164: -
- 5165: -
- 5166: -
- 5167: -
- 5168: -
- 5169: -
- 5170: -
- 5171: -
- 5172: -
- 5173: -

| ID | WBS | Task | Duration | Start | Finish | Predecessors | Complete | Baseline start | Baseline finish | Baseline duration | Constraint | Resources | Work | Actual work | Release | MCC resp | Impacted TSs and TRs | TSG stopped | Acronym | WI rapporteur name | WI rapporteur e-mail | Acronym_3GU_Export |
| --- | --- | --- | --- | --- | --- | --- | --- | --- | --- | --- | --- | --- | --- | --- | --- | --- | --- | --- | --- | --- | --- | --- |
| 5174 | 53.6 | **Low chiprate TDD interworking with GERAN** | 101d | 2000-09-01 A | 2001-01-19 A | 5173 | 100% | 2000-09-01 | 2001-01-19 | 101d |  | GP | 1616h | 1616h | Rel-4 | Paolo |  |  |  |  |  |  |
| 5175 | 53.6.1 | Handover and Cell Selection / Reselection to UTRA 1.28 Mcps TDD | 101d | 2000-09-01 A | 2001-01-19 A |  | 100% | 2000-09-01 | 2001-01-19 | 101d | finish no earlier than 2001-01-19 | GP | 808h | 808h | Rel-4 | Paolo |  |  |  |  |  |  |
| 5176 | 53.8 | **Conformance Test Aspects - Low Chip Rate TDD** | 577d | 2001-09-17 A | 2003-12-02 A | 5174 | 100% | 2001-09-17 | 2003-12-02 | 577d |  | T1 | 12088h | 12088h | Rel-4 | Ingbert |  |  |  |  |  |  |
| 5177 | 53.8.1 | Testing Layer 2 and layer 3 protocol aspects | 468d | 2001-09-17 A | 2003-07-02 A |  | 100% | 2001-09-17 | 2003-07-02 | 468d | finish no earlier than 2003-07-02 | T1 | 3744h | 3744h | Rel-4 | Ingbert | 34.123-1, 34.123-2 |  |  |  |  |  |
| 5178 | 53.8.2 | Deleted - Testing Layer 2 and layer 3 protocol aspects - TTCN | 261d | 2002-12-03 A | 2003-12-02 A |  | 100% | 2002-12-03 | 2003-12-02 | 261d | finish no earlier than 2003-12-02 | T1 | 2088h | 2088h | Rel-4 | Ingbert | 34.123-3 | TP-22 |  |  |  |  |
| 5179 | 53.8.3 | Testing RF Radio Transmission and Reception | 205d | 2001-09-17 A | 2002-06-28 A |  | 100% | 2001-09-17 | 2002-06-28 | 205d | finish no earlier than 2002-06-28 | T1 | 1640h | 1640h | Rel-4 | Ingbert |  |  |  |  |  |  |
| 5180 | 54 | **Enable bearer independent CS architecture** | 566d | 2000-01-03 A | 2002-03-01 A |  | 100% | 2000-01-03 | 2002-03-01 | 566d |  | S2; N3; N4 | 28008h | 28008h | Rel-4 | Maurice |  |  | CSSPLIT | Siemens | Alexander Milinski | CSSPLIT |
| 5181 | 54.1 | **Enable bearer-independent call control** | 425d | 2000-01-03 A | 2001-08-16 A |  | 100% | 2000-01-03 | 2001-08-16 | 425d |  | N4 | 12344h | 12344h | Rel-4 | Kimmo |  |  |  | Ericsson | Heinz-Peter.Keutmann@eed.ericsson.se |  |
| 5182 | 54.1.1 | Architecture and Stage 2 description | 181d | 2000-01-03 A | 2000-09-08 A |  | 100% | 2000-01-03 | 2000-09-08 | 181d | finish no earlier than 2000-09-08 | S2 | 1440h | 1440h | Rel-4 | Maurice | 23.002 |  |  |  |  |  |
| 5183 | 54.1.2 | Standardisation of protocols (control & user planes) over Nb interface | 64d | 2001-01-02 A | 2001-03-30 A |  | 100% | 2001-01-02 | 2001-03-30 | 64d | finish no earlier than 2001-03-30 | N3 | 512h | 512h | Rel-4 | Gwiho |  |  |  |  |  |  |
| 5184 | 54.1.3 | Standardisation of protocols over reference points between MSC server and Gateway MSC server | 130d | 2000-09-25 A | 2001-03-23 A |  | 100% | 2000-09-25 | 2001-03-23 | 130d | finish no earlier than 2001-03-23 | N4 | 1040h | 1040h | Rel-4 | Kimmo |  |  |  |  |  |  |
| 5185 | 54.1.4 | Standardisation of detailed stage 2 description | 180d | 2000-07-17 A | 2001-03-23 A |  | 100% | 2000-07-17 | 2001-03-23 | 180d | finish no earlier than 2001-03-23 | N4 | 1440h | 1440h | Rel-4 | Kimmo |  |  |  |  |  |  |
| 5186 | 54.1.5 | **Bearer control between MSC server and MGW** | 250d | 2000-09-01 A | 2001-08-16 A |  | 100% | 2000-09-01 | 2001-08-16 | 250d |  | N4 | 4512h | 4512h | Rel-4 | Kimmo |  |  |  |  |  |  |
| 5187 | 54.1.5.1 | stage 3 - protocol issues | 250d | 2000-09-01 A | 2001-08-16 A |  | 100% | 2000-09-01 | 2001-08-16 | 250d | finish no earlier than 2001-08-16 | N4 | 2000h | 2000h | Rel-4 | Kimmo |  |  |  |  |  |  |
| 5188 | 54.1.5.2 | stage 3 - parameter value issues | 64d | 2001-01-02 A | 2001-03-30 A |  | 100% | 2001-01-02 | 2001-03-30 | 64d | finish no earlier than 2001-03-30 | N3 | 512h | 512h | Rel-4 | Gwiho |  |  |  |  |  |  |
| 5189 | 54.4 | Deleted - Conformance Test Aspects - Enable bearer independent CS architecture | 260d | 2001-03-05 A | 2002-03-01 A |  | 100% | 2001-03-05 | 2002-03-01 | 260d |  | T1 | 2080h | 2080h | Rel-4 | Ingbert |  | TP-15 | CSSPLIT-TEST |  |  | CSSPLIT-TEST |
| 5190 | 55 | **MExE enhancements Rel-4** | 511d | 2000-01-03 A | 2001-12-14 A |  | 100% | 2000-01-03 | 2001-12-14 | 511d |  | T2; S3 | 26912h | 26912h | Rel-4 | Kimmo |  |  | MEXE |  |  | MEXE |
| 5191 | 55.1 | **MExE Security Analysis Activity** | 474d | 2000-02-22 A | 2001-12-14 A |  | 100% | 2000-02-22 | 2001-12-14 | 474d |  | S3; T2 | 12256h | 12256h | Rel-4 | Mirko |  |  | MEXE-SEC | BT | Andrew.Myers@bt.com | MEXE-SEC |
| 5192 | 55.1.1 | Stage 3 for MExE Security | 370d | 2000-07-17 A | 2001-12-14 A |  | 100% | 2000-07-17 | 2001-12-14 | 370d | finish no earlier than 2001-12-14 | S3 | 2960h | 2960h | Rel-4 | Mirko | 21.133, 33.102 |  |  | BT | Andrew.Myers@bt.com |  |
| 5193 | 55.1.2 | Terminal aspects for MExE Security | 214d | 2000-02-22 A | 2000-12-15 A |  | 100% | 2000-02-22 | 2000-12-15 | 214d | finish no earlier than 2000-12-15 | T2 | 1712h | 1712h | Rel-4 |  | 23.057 |  |  | BT | Andrew.Myers@bt.com |  |
| 5194 | 55.2 | **MExE Rel-4 Improvements and Investigations** | 251d | 2000-01-03 A | 2000-12-15 A |  | 100% | 2000-01-03 | 2000-12-15 | 251d |  | T2 | 6480h | 6480h | Rel-4 | Kimmo | 22.057, 23.057 |  | MEXE-ENHANC | Motorola | Mark Cataldo | MEXE-ENHANC |
| 5195 | 55.2.1 | 3rd MExE classmark | 251d | 2000-01-03 A | 2000-12-15 A |  | 100% | 2000-01-03 | 2000-12-15 | 251d | finish no earlier than 2000-12-15 | T2 | 2000h | 2000h | Rel-4 | Kimmo | 22.057, 23.057 |  |  | Motorola | Mark Cataldo |  |
| 5196 | 55.2.2 | FS on Secure download mechanism and capabilities to support SDR concepts | 225d | 2000-02-07 A | 2000-12-15 A |  | 100% | 2000-02-07 | 2000-12-15 | 225d | finish no earlier than 2000-12-15 | T2 | 1800h | 1800h | Rel-4 | Kimmo | 22.057, 23.057 |  |  | Motorola | Mark Cataldo |  |
| 5197 | 55.2.3 | FS on Support of MP3/MPEG4 content | 225d | 2000-02-07 A | 2000-12-15 A |  | 100% | 2000-02-07 | 2000-12-15 | 225d | finish no earlier than 2000-12-15 | T2 | 1800h | 1800h | Rel-4 | Kimmo | 22.057, 23.057 |  |  | Motorola | Mark Cataldo |  |

Notes:
- 5174: -
- 5175: -
- 5176: -
- 5177: Marked as closed 12/2008 (was marked 60% complete)
- 5178: Marked as stopped 12/2008
- 5179: duration set to 6 months (was 0), finish date set
- 5180: -
- 5181: DAB 12.12.01 should be 100% hence closed
- 5182: R00 stage 2 at least 80 % complete in TSGS #8 21.-23.6.2000
- 5183: -
- 5184: -
- 5185: -
- 5186: -
- 5187: -
- 5188: -
- 5189: Marked as stopped 12/2008
- 5190: -
- 5191: SP#12 updated WID
- 5192: -
- 5193: -
- 5194: -
- 5195: Additional features for MExE R2000
- 5196: -
- 5197: -

| ID | WBS | Task | Duration | Start | Finish | Complete | Baseline start | Baseline finish | Baseline duration | Constraint | Resources | Work | Actual work | Acronym | Release | MCC resp | Acronym_3GU_Export | Impacted TSs and TRs | WI rapporteur name | WI rapporteur e-mail |
| --- | --- | --- | --- | --- | --- | --- | --- | --- | --- | --- | --- | --- | --- | --- | --- | --- | --- | --- | --- | --- |
| 5198 | 56 | **Tandem Free aspects for 3G and between 2G and 3G systems** | 344d | 2000-02-22 A | 2001-06-15 A | 100% | 2000-02-22 | 2001-06-15 | 344d |  | S4 | 9696h | 9696h | TFO | Rel-4 | Paolo | TFO |  |  |  |
| 5199 | 56.1 | **Tandem Free AMR** | 344d | 2000-02-22 A | 2001-06-15 A | 100% | 2000-02-22 | 2001-06-15 | 344d |  | S4 | 6944h | 6944h | TFO-AMR | Rel-4 | Paolo | TFO-AMR |  |  |  |
| 5200 | 56.1.1 | Specification of Tandem Free AMR | 284d | 2000-02-22 A | 2001-03-23 A | 100% | 2000-02-22 | 2001-03-23 | 284d | start no earlier than 2000-02-22 | S4 | 2272h | 2272h |  | Rel-4 | Paolo |  | 28.062 |  |  |
| 5201 | 56.1.2 | **Impact of Tandem Free AMR on:** | 115d | 2001-01-08 A | 2001-06-15 A | 100% | 2001-01-08 | 2001-06-15 | 115d |  | NP | 1920h | 1920h |  | Rel-4 | Kimmo |  |  |  |  |
| 5202 | 56.1.2.1 | CN | 60d | 2001-03-26 A | 2001-06-15 A | 100% | 2001-03-26 | 2001-06-15 | 60d | finish no earlier than 2001-06-15 | NP | 480h | 480h |  | Rel-4 | Kimmo |  |  |  |  |
| 5203 | 56.1.2.2 | GERAN | 65d | 2001-01-08 A | 2001-04-06 A | 100% | 2001-01-08 | 2001-04-06 | 65d | finish no earlier than 2001-04-06 | GP | 520h | 520h |  | Rel-4 | Paolo |  |  |  |  |
| 5204 | 57 | **Advanced Speech Call Items enhancements_Rel-4** | 334d | 2000-12-03 A | 2002-03-14 A | 100% | 2000-12-03 | 2002-03-14 | 334d |  | N1 | 5925.6h | 5925.6h | ASCI4 | Rel-4 | Frederic | ASCI, Rel-4 |  | Nortel | sonia.garapaty@nortelnetworks.com |
| 5205 | 57.1 | Stage 2 for Advanced Speech Call Items enhancements_Rel-4 (ASCI) | 326.7d | 2000-12-03 A | 2002-03-14 A | 100% | 2000-12-03 | 2002-03-14 | 326.7d | finish no earlier than 2002-03-14 | N4 | 2613.6h | 2613.6h |  | Rel-4 | Kimmo |  | 23.067, 24.067 | Sagem | Vivien Perlic |
| 5206 | 57.2 | Stages 2 and 3 on A interface | 80d | 2000-12-03 A | 2001-03-23 A | 100% | 2000-12-03 | 2001-03-23 | 80d | finish no earlier than 2001-03-23 | N1 | 640h | 640h |  | Rel-4 | Frederic |  | 44.068, 44.069, 24.008 | Nortel | sonia.garapaty@nortelnetworks.com |
| 5207 | 58 | **700 MHz spectrum support** | 776d | 2000-01-03 A | 2002-12-20 A | 100% | 2000-01-03 | 2002-12-20 | 776d |  | GP | 20016h | 20016h | 700SS | Rel-4 | Paolo | 700SS |  |  |  |
| 5208 | 58.1 | **GERAN support for the 700 MHz band** | 276d | 2000-01-03 A | 2001-01-19 A | 100% | 2000-01-03 | 2001-01-19 | 276d |  | GP | 8808h | 8808h |  | Rel-4 | Paolo |  |  |  |  |
| 5209 | 58.1.1 | Signalling support | 276d | 2000-01-03 A | 2001-01-19 A | 100% | 2000-01-03 | 2001-01-19 | 276d | finish no earlier than 2001-01-19 | GP | 2200h | 2200h |  | Rel-4 | Paolo |  |  |  |  |
| 5210 | 58.1.2 | Physical layer definitions - for GERAN support for the 700 MHz band | 276d | 2000-01-03 A | 2001-01-19 A | 100% | 2000-01-03 | 2001-01-19 | 276d | finish no earlier than 2001-01-19 | GP | 2200h | 2200h |  | Rel-4 | Paolo |  |  |  |  |
| 5211 | 58.1.3 | Receiver performance and RF budget | 276d | 2000-01-03 A | 2001-01-19 A | 100% | 2000-01-03 | 2001-01-19 | 276d | finish no earlier than 2001-01-19 | GP | 2200h | 2200h |  | Rel-4 | Paolo |  |  |  |  |
| 5212 | 58.2 | GERAN MS Conformance test for 700 MHz band | 175d | 2001-04-02 A | 2001-11-30 A | 100% | 2001-04-02 | 2001-11-30 | 175d |  | GP | 1400h | 1400h |  | Rel-4 | Paolo |  |  |  |  |
| 5213 | 58.3 | GERAN BTS Conformance test for 700 MHz band | 450d | 2001-04-02 A | 2002-12-20 A | 100% | 2001-04-02 | 2002-12-20 | 450d |  | GP | 3600h | 3600h |  | Rel-4 | Paolo |  |  |  |  |
| 5214 | 59 | Operator Determined Barring for Packet Oriented Services | 208d | 2000-06-01 A | 2001-03-19 A | 100% | 2000-06-01 | 2001-03-19 | 208d | finish no earlier than 2001-03-19 | NP | 1664h | 1664h | ODB | Rel-4 | Kimmo | ODB |  | NEC | Toshiyuki Tamura (tamurato@aj.jp.nec.com) |
| 5215 | 60 | **UMTS QoS Architecture for PS Domain** | 759d | 2000-01-03 A | 2002-11-27 A | 100% | 2000-01-03 | 2002-11-27 | 759d |  | S2; S5; R3; GP | 72848h | 72848h | QoSPS | Rel-4 | Maurice | QoSPS |  | Ericsson | Ina.widegren@era.ericsson.se |
| 5216 | 60.1 | Architecture | 153d | 2000-06-05 A | 2001-01-03 A | 100% | 2000-06-05 | 2001-01-03 | 153d | finish no earlier than 2001-01-03 | S2 | 1224h | 1224h |  | Rel-4 | Maurice |  | 23.107 |  |  |
| 5217 | 60.2 | Charging and OAM&P for QoS Management | 201d | 2001-09-21 A | 2002-06-28 A | 100% | 2001-09-21 | 2002-06-28 | 201d | finish no earlier than 2002-06-28 | S5 | 1608h | 1608h | QoSPS-OAM | Rel-4 | Mirko | QoSPS-OAM | 32-series |  |  |
| 5218 | 60.3 | **RAB Quality of Service (re)Negotiation over Iu** | 155d | 2000-08-21 A | 2001-03-23 A | 100% | 2000-08-21 | 2001-03-23 | 155d |  | R3 | 3648h | 3648h | QoSPS-MAPEND-RABQoS | Rel-4 | Juha | QoSPS-MAPEND-RABQoS | 25.413 | Ericsson | anders.molander@ericsson.com |
| 5219 | 60.3.1 | RAB Quality of Service Negotiation over Iu | 155d | 2000-08-21 A | 2001-03-23 A | 100% | 2000-08-21 | 2001-03-23 | 155d | finish no earlier than 2001-03-23 | R3 | 1240h | 1240h | QoSPS-MAPEND-RABQoS-Negot | Rel-4 | Juha | QoSPS-MAPEND-RABQoS-Negot |  | Ericsson | anders.molander@ericsson.com |
| 5220 | 60.3.2 | RAB Quality of Service Negotiation over Iu during relocation | 16d | 2001-03-02 A | 2001-03-23 A | 100% | 2001-03-02 | 2001-03-23 | 16d | start no earlier than 2001-03-02 | R3 | 128h | 128h | QoSPS-MAPEND-RABQoS-NegotReloc | Rel-4 | Juha | QoSPS-MAPEND-RABQoS-NegotReloc |  |  |  |
| 5221 | 60.3.3 | RAB Quality of Service Re-Negotiation over Iu | 130d | 2000-09-25 A | 2001-03-23 A | 100% | 2000-09-25 | 2001-03-23 | 130d | finish no earlier than 2001-03-23 | R3 | 1040h | 1040h | QoSPS-MAPEND-RABQoS-ReNegot | Rel-4 | Juha | QoSPS-MAPEND-RABQoS-ReNegot |  | Motorola | S. Irwin |

Notes:
- 5198: RAN and CN to verify no problems for GSM terminals roaming in 3G R99
- 5199: RAN and CN to verify UMTS_AMR_2 support
- 5200: -
- 5201: "Implementation" changed to "Impact on:" by A. Sultan (for better wording)
- 5202: RAN and CN to verify UMTS_AMR_2 support
- 5203: End date Modified from June to March to have it in Rel4
- 5204: Approved at CN#10. Acronym changed from ASCI, Rel-4
- 5205: CN4#11 30/11/02: no inputs received in CN4
- 5206: -
- 5207: -
- 5208: -
- 5209: -
- 5210: -
- 5211: -
- 5212: -
- 5213: -
- 5214: Completed WI missing from the P-plan Added for tracking
- 5215: -
- 5216: -
- 5217: -
- 5218: -
- 5219: -
- 5220: -
- 5221: -

| ID | WBS | Task | Type | Duration | Start | Finish | Complete | Baseline start | Baseline finish | Baseline duration | Constraint | Resources | Work | Actual work | Acronym | Release | MCC resp | Acronym_3GU_Export | TSG stopped | WI rapporteur name | WI rapporteur e-mail | Impacted TSs and TRs |
| --- | --- | --- | --- | --- | --- | --- | --- | --- | --- | --- | --- | --- | --- | --- | --- | --- | --- | --- | --- | --- | --- | --- |
| 5222 | 60.4 | **GERAN QoS Aspects - Handovers: maintenance of real-time QoS while moving between cells in the PLMN including inter-SGSN and SRNS relocation or possibly other mechanisms** |  | 501d | 2000-01-03 A | 2001-11-30 A | 100% | 2000-01-03 | 2001-11-30 | 501d |  | GP | 14456h | 14456h | GERQoS | Rel-4 | Paolo | GERQoS |  |  |  |  |
| 5223 | 60.4.1 | **Handover Concept for the PS domain** |  | 501d | 2000-01-03 A | 2001-11-30 A | 100% | 2000-01-03 | 2001-11-30 | 501d |  | GP | 10448h | 10448h |  | Rel-4 | Paolo |  |  |  |  |  |
| 5224 | 60.4.1.1 | Stable RT handover report 25.936 including header removal |  | 14d | 2000-01-03 A | 2000-01-19 A | 100% | 2000-01-03 | 2000-01-19 | 14d | start no earlier than 2000-01-03 | GP | 104h | 104h |  | Rel-4 | Paolo |  |  |  |  |  |
| 5225 | 60.4.1.2 | Update of stage 2 |  | 293d | 2000-01-03 A | 2001-02-13 A | 100% | 2000-01-03 | 2001-02-13 | 293d | finish no earlier than 2001-02-13 | GP | 2336h | 2336h |  | Rel-4 | Paolo |  |  |  |  |  |
| 5226 | 60.4.1.3 | Update of relevant stage 3 specs -> RRC |  | 501d | 2000-01-03 A | 2001-11-30 A | 100% | 2000-01-03 | 2001-11-30 | 501d | finish no earlier than 2001-11-30 | G2 | 4000h | 4000h |  | Rel-4 | Gert |  |  |  |  |  |
| 5227 | 60.5 | **Deleted - GERAN MS Conformance test for inter-system and intra-system Packet data real-time Handover** |  | 324d | 2001-08-31 A | 2002-11-27 A | 100% | 2001-08-31 | 2002-11-27 | 324d |  | G4; R3 | 25920h | 25920h | GERQoS-Mstest | Rel-4 | Paolo | GERQoS-Mstest | GP-12 |  |  |  |
| 5228 | 60.5.1 | **Deleted - Handover for the PS domain** |  | 324d | 2001-08-31 A | 2002-11-27 A | 100% | 2001-08-31 | 2002-11-27 | 324d |  | G4; R3 | 20736h | 20736h |  | Rel-4 | Paolo |  | GP-12 |  |  |  |
| 5229 | 60.5.1.1 | Deleted - Stable RT handover report 25.936 including header removal |  | 324d | 2001-08-31 A | 2002-11-27 A | 100% | 2001-08-31 | 2002-11-27 | 324d | finish no earlier than 2002-11-27 | G4; R3 | 5184h | 5184h |  | Rel-4 | Paolo |  | GP-12 |  |  |  |
| 5230 | 60.5.1.2 | Deleted - Update of stage 2 |  | 324d | 2001-08-31 A | 2002-11-27 A | 100% | 2001-08-31 | 2002-11-27 | 324d | finish no earlier than 2002-11-27 | G4; R3 | 5184h | 5184h |  | Rel-4 | Paolo |  | GP-12 |  |  |  |
| 5231 | 60.5.1.3 | Deleted - Update of relevant stage 3 specs |  | 324d | 2001-08-31 A | 2002-11-27 A | 100% | 2001-08-31 | 2002-11-27 | 324d | finish no earlier than 2002-11-27 | G4; R3 | 5184h | 5184h |  | Rel-4 | Paolo |  | GP-12 |  |  |  |
| 5232 | 60.6 | PS-domain handover for real-time services |  | 155d | 2000-08-28 A | 2001-03-30 A | 100% | 2000-08-28 | 2001-03-30 | 155d | finish no earlier than 2001-03-30 | R3 | 1240h | 1240h | QoSPS-PSdoRTS | Rel-4 | Juha | QoSPS-PSdoRTS |  | Nokia | atte.lansisalmi@nokia.com |  |
| 5233 | 60.7 | Deleted - RAB QoS Renegotiation at Relocation |  | 58d | 2001-01-03 A | 2001-03-23 A | 100% | 2001-01-03 | 2001-03-23 | 58d | finish no earlier than 2001-03-23 | R3 | 464h | 464h |  | Rel-4 | Juha |  | RP-11 |  |  | 25.851, 25.946 |
| 5234 | 61 | (Small) Technical Enhancements and Improvements for Rel-4 | milestone | 0d? | 2000-01-03 A | 2000-01-03 A | 100% | 2000-01-03 | 2001-03-30 | 326d? |  | SP; CP; RP; GP |  |  | TEI4 | Rel-4 | all | TEI4 |  |  |  |  |
| 5235 | 1255 | Test - (Small) Technical Enhancements and Improvements for Rel-4 |  | 326d? | 2000-01-03 A | 2001-03-30 A | 100% | 2000-01-03 | 2001-03-30 | 326d? | finish no earlier than 2008-12-31 | R5; T1 | 5216h | 5216h | TEI4_Test | Rel-4 | Ingbert | TEI4_Test |  |  |  |  |
| 5236 | 62 | **Rel-4 Evolutions of the transport in the UTRAN** |  | 525d | 2000-08-21 A | 2002-08-23 A | 100% | 2000-08-21 | 2002-08-23 | 525d |  | RP | 8600h | 8600h | ETRAN | Rel-4 | Issam | ETRAN |  | Alcatel | Francois Courau |  |
| 5237 | 62.1 | QoS optimization for AAL2 connections over Iub and Iur interfaces |  | 160d | 2000-08-21 A | 2001-03-30 A | 100% | 2000-08-21 | 2001-03-30 | 160d | finish no earlier than 2001-03-30 | R3 | 1280h | 1280h | ETRAN-QoSAAL2 | Rel-4 | Juha | ETRAN-QoSAAL2 |  | Japan Telecom | T. Yoshimura |  |
| 5238 | 62.2 | Transport bearer modification procedure on Iub, Iur, and Iu |  | 130d | 2000-10-02 A | 2001-03-30 A | 100% | 2000-10-02 | 2001-03-30 | 130d | finish no earlier than 2001-03-30 | R3 | 1040h | 1040h | ETRAN-MigrMod | Rel-4 | Juha | ETRAN-MigrMod |  | Japan Telecom | T. Yoshimura |  |
| 5239 | 62.3 | **Deleted - Conformance Test Aspects of Rel-4 evolutions of the transport in UTRAN** |  | 130d | 2002-02-25 A | 2002-08-23 A | 100% | 2002-02-25 | 2002-08-23 | 130d |  | T1 | 2080h | 2080h |  | Rel-4 | Ingbert |  | TP-17 |  |  |  |
| 5240 | 62.3.1 | Deleted - Testing RAB support enhancements |  | 130d | 2002-02-25 A | 2002-08-23 A | 100% | 2002-02-25 | 2002-08-23 | 130d | finish no earlier than 2002-08-23 | T1 | 1040h | 1040h | CT-RABS? | Rel-4 | Ingbert | CT-RABS? | TP-17 |  |  | 34.108, 34. 121, 34.122, 34.123 p 1,2, 34.123 pt 3 |
| 5241 | 63 | **Rel-4 Evolutions of the transport in the CN** |  | 215d | 2000-05-29 A | 2001-03-23 A | 100% | 2000-05-29 | 2001-03-23 | 215d |  | N4; N1; N2; S2 | 13128h | 13128h | CNTRSP | Rel-4 | Kimmo | CNTRSP |  |  |  |  |
| 5242 | 63.1 | **IP Transport of CN protocols (e.g. CAP, MAP)** |  | 77d | 2000-12-07 A | 2001-03-23 A | 100% | 2000-12-07 | 2001-03-23 | 77d |  | N4 | 2808h | 2808h | SS7IP | Rel-4 | Kimmo | SS7IP |  |  |  |  |
| 5243 | 63.1.1 | **Stage 3 for IP Transport of CN protocols (e.g. CAP, MAP)** |  | 77d | 2000-12-07 A | 2001-03-23 A | 100% | 2000-12-07 | 2001-03-23 | 77d |  | N4 | 2192h | 2192h |  | Rel-4 | Kimmo |  |  |  |  |  |
| 5244 | 63.1.1.1 | CAP |  | 77d | 2000-12-07 A | 2001-03-23 A | 100% | 2000-12-07 | 2001-03-23 | 77d | finish no earlier than 2001-03-23 | N2 | 616h | 616h |  | Rel-4 | Kimmo |  |  |  |  |  |
| 5245 | 63.1.1.2 | MAP |  | 77d | 2000-12-07 A | 2001-03-23 A | 100% | 2000-12-07 | 2001-03-23 | 77d | finish no earlier than 2001-03-23 | N4 | 616h | 616h |  | Rel-4 | Kimmo |  |  |  |  | 29.202 |
| 5246 | 63.1.1.3 | BSSAP+ |  | 43d | 2001-01-15 A | 2001-03-14 A | 100% | 2001-01-15 | 2001-03-14 | 43d | finish no earlier than 2001-03-14 | N1 | 344h | 344h | SS7IP-BSSAP+ | Rel-4 | Frederic | SS7IP-BSSAP+ |  |  |  |  |

Notes:
- 5222: -
- 5223: -
- 5224: -
- 5225: -
- 5226: -
- 5227: Still exist? To be clarified by GERAN4/5. Marked as stopped 12/2008
- 5228: Marked as stopped 12/2008
- 5229: Marked as stopped 12/2008
- 5230: Marked as stopped 12/2008
- 5231: Marked as stopped 12/2008
- 5232: -
- 5233: Marked as stopped 12/2008
- 5234: "Joker" WI, to be used for a Rel 4 CR not related to any feature and with very limited impact on the system
- 5235: "Joker" WI, to be used for small modifications applicable to Rel 4 conformance testing. Moved in from the Stoyan/Testing WP
- 5236: -
- 5237: -
- 5238: -
- 5239: Marked as stopped 12/2008
- 5240: Marked as stopped 12/2008
- 5241: -
- 5242: -
- 5243: -
- 5244: -
- 5245: -
- 5246: -

| ID | WBS | Task | Duration | Start | Finish | Complete | Baseline start | Baseline finish | Baseline duration | Constraint | Resources | Work | Actual work | WI rapporteur name | WI rapporteur e-mail | Release | MCC resp | Acronym | Acronym_3GU_Export | Impacted TSs and TRs | TSG stopped |
| --- | --- | --- | --- | --- | --- | --- | --- | --- | --- | --- | --- | --- | --- | --- | --- | --- | --- | --- | --- | --- | --- |
| 5247 | 63.2 | **FS on Transport and control separation in the PS CN domain** | 215d | 2000-05-29 A | 2001-03-23 A | 100% | 2000-05-29 | 2001-03-23 | 215d |  | S2 | 3440h | 3440h | Ericsson | Juan-Antonio.Ibanez@eed.ericsson.se | Rel-4 | Maurice |  |  |  |  |
| 5248 | 63.2.1 | Architectural impacts | 215d | 2000-05-29 A | 2001-03-23 A | 100% | 2000-05-29 | 2001-03-23 | 215d | finish no earlier than 2001-03-23 | S2 | 1720h | 1720h |  |  | Rel-4 | Maurice |  |  |  |  |
| 5249 | 64 | **Rel-4 Improvements of Radio Interface** | 700d | 2000-07-10 A | 2003-03-14 A | 100% | 2000-07-10 | 2003-03-14 | 700d |  | RP | 28624h | 28624h |  |  | Rel-4 |  |  |  |  |  |
| 5250 | 64.1 | UTRA repeater specification (master) | 183d | 2000-07-10 A | 2001-03-21 A | 100% | 2000-07-10 | 2001-03-21 | 183d | finish no earlier than 2001-03-21 | R4 | 1464h | 1464h | Mikom, Allgon | T. Kummetz, Mikom; Alf Ahlström, Allgon | Rel-4 | Issam | RInImp-REP | RInImp-REP |  |  |
| 5251 | 64.2 | DSCH power control improvement in soft handover | 140d | 2000-09-11 A | 2001-03-23 A | 100% | 2000-09-11 | 2001-03-23 | 140d | finish no earlier than 2001-03-23 | R1 | 1120h | 1120h | Nokia | antti.toskala@nokia.com | Rel-4 | Patrick | RInImp-DSCHsho | RInImp-DSCHsho |  |  |
| 5252 | 64.3 | UMTS 1800 | 320d | 2000-09-25 A | 2001-12-14 A | 100% | 2000-09-25 | 2001-12-14 | 320d | finish no earlier than 2001-12-14 | R4 | 2560h | 2560h | Motorola | Howard Benn | Rel-4 | Issam | RInImp-UMTS18 | RInImp-UMTS18 |  |  |
| 5253 | 64.4 | UMTS 1900 | 195d | 2001-03-19 A | 2001-12-14 A | 100% | 2001-03-19 | 2001-12-14 | 195d | finish no earlier than 2001-12-14 | R4 | 1560h | 1560h | Motorola | Howard Benn | Rel-4 | Issam | RInImp-UMTS19 | RInImp-UMTS19 | 25.101 |  |
| 5254 | 64.5 | FS on High Speed downlink packet access | 155d | 2000-08-21 A | 2001-03-23 A | 100% | 2000-08-21 | 2001-03-23 | 155d | finish no earlier than 2001-03-23 | R2 | 1240h | 1240h | Motorola | Amitabha Ghosh (qa0047@email.mot.com) | Rel-4 | Yong-Jun | RInImp-HSDPA | RInImp-HSDPA |  |  |
| 5255 | 64.6 | Deleted - FS on improved common DL channel for Cell-FACH state | 340d | 2000-09-11 A | 2001-12-28 A | 100% | 2000-09-11 | 2001-12-28 | 340d | finish no earlier than 2001-12-28 | R2 | 2720h | 2720h | GBT | J. Kwak | Rel-4 | Yong-Jun | RInImp-DLCFACH | RInImp-DLCFACH |  | RP-14 |
| 5256 | 64.7 | **Conformance Test Spec. Rel-4 improvements in Radio Interface** | 375d | 2001-10-08 A | 2003-03-14 A | 100% | 2001-10-08 | 2003-03-14 | 375d |  | T1 | 12360h | 12360h |  |  | Rel-4 | Ingbert |  |  |  |  |
| 5257 | 64.7.1 | Deleted - Testing Improved usage of downlink resource in FDD for CCTrCHs of dedicated type | 140d | 2002-02-18 A | 2002-08-30 A | 100% | 2002-02-18 | 2002-08-30 | 140d | finish no earlier than 2002-08-30 | T1 | 1120h | 1120h |  |  | Rel-4 | Ingbert |  |  |  | TP-17 |
| 5258 | 64.7.2 | Deleted - Testing Terminal Power saving features | 140d | 2002-02-18 A | 2002-08-30 A | 100% | 2002-02-18 | 2002-08-30 | 140d | finish no earlier than 2002-08-30 | T1 | 1120h | 1120h |  |  | Rel-4 | Ingbert |  |  |  | TP-17 |
| 5259 | 64.7.3 | Deleted - Testing DSCH power control improvement in soft handover | 140d | 2002-02-18 A | 2002-08-30 A | 100% | 2002-02-18 | 2002-08-30 | 140d | finish no earlier than 2002-08-30 | T1 | 1120h | 1120h |  |  | Rel-4 | Ingbert |  |  |  | TP-17 |
| 5260 | 64.7.4 | Testing UMTS 1800 | 180d | 2001-10-08 A | 2002-06-14 A | 100% | 2001-10-08 | 2002-06-14 | 180d | finish no earlier than 2002-06-14 | T1 | 1440h | 1440h |  |  | Rel-4 | Ingbert |  |  | 34.108, 34,121, 34.122, 34.123-1 |  |
| 5261 | 64.7.5 | Testing UMTS 1900 | 180d | 2001-10-08 A | 2002-06-14 A | 100% | 2001-10-08 | 2002-06-14 | 180d | finish no earlier than 2002-06-14 | T1 | 1440h | 1440h |  |  | Rel-4 | Ingbert |  |  | 34.108, 34,121, 34.122, 34.123-1 |  |
| 5262 | 64.7.6 | Testing UMTS 1800 - TTCN | 195d | 2002-06-17 A | 2003-03-14 A | 100% | 2002-06-17 | 2003-03-14 | 195d | finish no earlier than 2003-03-14 | T1 | 1560h | 1560h |  |  | Rel-4 | Ingbert |  |  | 34.123-3 |  |
| 5263 | 64.7.7 | Testing UMTS 1900 - TTCN | 195d | 2002-06-17 A | 2003-03-14 A | 100% | 2002-06-17 | 2003-03-14 | 195d | finish no earlier than 2003-03-14 | T1 | 1560h | 1560h |  |  | Rel-4 | Ingbert |  |  | 34.123-3 |  |
| 5264 | 65 | **Rel-4 RAN improvements** | 938d? | 2000-08-14 A | 2004-03-17 A | 100% | 2000-08-14 | 2004-03-17 | 938d? |  | RP | 29336h | 29336h |  |  | Rel-4 |  |  |  |  |  |
| 5265 | 65.1 | Node B synchronization for TDD | 160d | 2000-08-14 A | 2001-03-23 A | 100% | 2000-08-14 | 2001-03-23 | 160d | finish no earlier than 2001-03-23 | R1 | 1280h | 1280h | Siemens | S. Oestreich | Rel-4 | Patrick | RANimp-NBsync | RANimp-NBsync |  |  |
| 5266 | 65.2 | RAB support enhancement for Rel-4 | 155d | 2000-08-21 A | 2001-03-23 A | 100% | 2000-08-21 | 2001-03-23 | 155d | finish no earlier than 2001-03-23 | R2 | 1240h | 1240h | Ericsson | M. Israelsson, A. Krishnarajah | Rel-4 | Yong-Jun | RANimp-RABSE | RANimp-RABSE |  |  |
| 5267 | 65.4 | **Deleted - Conformance Test Aspects - Rel-4 RAN Improvements** | 577d? | 2002-01-01 A | 2004-03-17 A | 100% | 2002-01-01 | 2004-03-17 | 577d? |  | T1 | 19312h | 19312h |  |  | Rel-4 | Ingbert |  |  |  | TP-23 |
| 5268 | 65.4.1 | Deleted - Testing Radio access bearer support enhancments | 175d | 2002-01-01 A | 2002-09-02 A | 100% | 2002-01-01 | 2002-09-02 | 175d | finish no earlier than 2002-09-02 | T1 | 1400h | 1400h |  |  | Rel-4 | Ingbert |  |  |  | TP-17 |
| 5269 | 65.4.2 | Deleted - Testing RAB support enhancements-Robust Header Compression | 332d | 2002-05-28 A | 2003-09-03 A | 100% | 2002-05-28 | 2003-09-03 | 332d | finish no earlier than 2003-09-03 | T1 | 2656h | 2656h |  |  | Rel-4 | Ingbert | RABimp-RoCH | RABimp-RoCH | 34.123-1, -2 | TP-21 |
| 5270 | 65.4.3 | Deleted - Testing RAB support enhancements-Robust Header Compression - TTCN | 472d | 2002-05-28 A | 2004-03-17 A | 100% | 2002-05-28 | 2004-03-17 | 472d | finish no earlier than 2004-03-17 | T1 | 3776h | 3776h |  |  | Rel-4 | Ingbert |  |  | 34.123-3 | TP-23 |
| 5271 | 65.4.4 | Testing of Extended Robut Header Compression | 270d | 2002-09-18 A | 2003-09-30 A | 100% | 2002-09-18 | 2003-09-30 | 270d | finish no earlier than 2003-09-30 | T1 | 2160h | 2160h |  |  | Rel-4 | Ingbert | Ext-RoHC | Ext-RoHC | 34.123-1, -2 |  |
| 5272 | 65.4.5 | Deleted - Testing of Extended Robut Header Compression - TTCN | 325d | 2002-09-18 A | 2003-12-16 A | 100% | 2002-09-18 | 2003-12-16 | 325d | finish no earlier than 2003-12-16 | T1 | 2600h | 2600h |  |  | Rel-4 | Ingbert |  |  | 34.123-3 | TP-22 |
| 5273 | 1259.3.6 | Deleted - General changes to TS34.121 corresponding to release 4 | 263d? | 2003-03-03 A | 2004-03-03 A | 100% | 2003-03-03 | 2004-03-03 | 263d? | finish no earlier than 2004-03-03 | T1 | 2104h | 2104h |  |  | Rel-4 | Ingbert | RANimp-test,TEI4 | RANimp-test, TEI4 | 34.108, 34.121 | TP-23 |

Notes:
- 5247: -
- 5248: -
- 5249: -
- 5250: -
- 5251: -
- 5252: -
- 5253: -
- 5254: -
- 5255: Stopped at RP#14
- 5256: -
- 5257: Marked as stopped 12/2008
- 5258: Marked as stopped 12/2008
- 5259: Marked as stopped 12/2008
- 5260: -
- 5261: -
- 5262: -
- 5263: -
- 5264: -
- 5265: -
- 5266: 29 Nov 2000: split into ROHC and non-ROHC part; 5 Mar 2001: splitting off of ROHC for Rel-4 agreed by R2
- 5267: Marked as stopped 12/2008
- 5268: Marked as stopped 12/2008
- 5269: UID changed. Marked as stopped 12/2008
- 5270: UID changed. Marked as stopped 12/2008
- 5271: Marked as closed 12/2008 (was marked 15% complete)
- 5272: Marked as stopped 12/2008
- 5273: Marked as stopped 12/2008

| ID | WBS | Task | Duration | Start | Finish | Complete | Baseline start | Baseline finish | Baseline duration | Constraint | Resources | Work | Actual work | Acronym | WI rapporteur name | Release | MCC resp | Special Focus Doc | Acronym_3GU_Export | TSG stopped | WI rapporteur e-mail | Status Report |
| --- | --- | --- | --- | --- | --- | --- | --- | --- | --- | --- | --- | --- | --- | --- | --- | --- | --- | --- | --- | --- | --- | --- |
| 5274 | 66 | **Rel-4 Emergency call enhancements** | 628d | 2000-01-03 A | 2002-05-28 A | 100% | 2000-01-03 | 2002-05-28 | 628d |  | N1; S1; T1 | 18672h | 18672h | EMC1-CS | Ericsson | Rel-4 | Frederic | Public Safety (I-A) | EMC1, EMC1-CS |  |  |  |
| 5275 | 66.1 | **For CS based calls** | 628d | 2000-01-03 A | 2002-05-28 A | 100% | 2000-01-03 | 2002-05-28 | 628d |  | N1 | 3600h | 3600h | EMC1-CS | Ericsson | Rel-4 | Frederic | Public Safety (I-A) | EMC1-CS |  |  |  |
| 5276 | 66.1.1 | Distinction in CS domain of emergency call types to different emergency services | 40d | 2000-05-01 A | 2000-06-23 A | 100% | 2000-05-01 | 2000-06-23 | 40d | finish no earlier than 2000-06-23 | S1 | 320h | 320h |  |  | Rel-4 | Alain | Public Safety (I-A) |  |  |  |  |
| 5277 | 66.1.2 | Distinction in CS domain of emergency calls to different emergency types | 22d | 2000-08-24 A | 2000-09-22 A | 100% | 2000-08-24 | 2000-09-22 | 22d | finish no earlier than 2000-09-22 | N1 | 176h | 176h |  |  | Rel-4 | Frederic | Public Safety (I-A) |  |  |  |  |
| 5278 | 66.1.3 | Deleted - Conformance Test Aspects - Emergency call enhancements | 151d | 2000-01-03 A | 2000-07-28 A | 100% | 2000-01-03 | 2000-07-28 | 151d |  | T1 | 1200h | 1200h |  |  | Rel-4 | Ingbert | Public Safety (I-A) |  | TP-08 |  |  |
| 5279 | 66.1.4 | Testing CS based emergency calls | 67d | 2002-02-25 A | 2002-05-28 A | 100% | 2002-02-25 | 2002-05-28 | 67d | finish no earlier than 2002-05-28 | T1 | 536h | 536h |  |  | Rel-4 | Ingbert | Public Safety (I-A) |  |  |  |  |
| 5280 | 66.1.5 | Testing CS based emergency calls - TTCN | 134d | 2001-11-22 A | 2002-05-28 A | 100% | 2001-11-22 | 2002-05-28 | 134d | finish no earlier than 2002-05-28 | T1 | 1072h | 1072h |  |  | Rel-4 | Ingbert | Public Safety (I-A) |  |  |  |  |
| 5281 | 67 | **Rel-4 Terminal interfaces** | 315d | 2000-01-03 A | 2001-03-15 A | 100% | 2000-01-03 | 2001-03-15 | 315d |  | T2 | 14296h | 14296h | TI |  | Rel-4 | Kimmo |  | TI |  |  |  |
| 5282 | 67.1 | **AT commands enhancements** | 314d | 2000-01-03 A | 2001-03-14 A | 100% | 2000-01-03 | 2001-03-14 | 314d |  | T2 | 5016h | 5016h | TI-ATC |  | Rel-4 | Kimmo |  | TI-ATC |  |  |  |
| 5283 | 67.1.1 | Specification of AT commands for new services | 314d | 2000-01-03 A | 2001-03-14 A | 100% | 2000-01-03 | 2001-03-14 | 314d | finish no earlier than 2001-03-14 | T2 | 2504h | 2504h |  |  | Rel-4 | Kimmo |  |  |  |  |  |
| 5284 | 67.2 | **Wide Area Data Synchronization** | 314d | 2000-01-03 A | 2001-03-14 A | 100% | 2000-01-03 | 2001-03-14 | 314d |  | T2 | 5016h | 5016h | TI-WADS |  | Rel-4 | Kimmo |  | TI-WADS |  |  |  |
| 5285 | 67.2.1 | Continues evolution of Synchronization protocol | 314d | 2000-01-03 A | 2001-03-14 A | 100% | 2000-01-03 | 2001-03-14 | 314d | finish no earlier than 2001-03-14 | T2 | 2504h | 2504h | TI-SYNC-EVOL |  | Rel-4 | Kimmo |  | TI-SYNC-EVOL |  |  |  |
| 5286 | 67.3 | Terminal local model | 218d | 2000-05-16 A | 2001-03-15 A | 100% | 2000-05-16 | 2001-03-15 | 218d | finish no earlier than 2001-03-15 | T2 | 1744h | 1744h | TLM | Ericsson | Rel-4 | Kimmo |  | TLM |  | Olga.Tome@ECS.ERICSSON.SE |  |
| 5287 | 68 | **Rel-4 Location Services enhancements** | 455d | 2000-04-03 A | 2001-12-28 A | 100% | 2000-04-03 | 2001-12-28 | 455d |  | S2; S1; T2; N1; N4; R3; R2 | 67671.2h | 67671.2h | LCS4 | Nokia | Rel-4 | Maurice |  | LCS1 |  | Jan Kall |  |
| 5288 | 68.1 | CBS interactions | 455d | 2000-04-03 A | 2001-12-28 A | 100% | 2000-04-03 | 2001-12-28 | 455d | finish no earlier than 2001-12-28 | T2 | 3640h | 3640h | LCS4-CBS |  | Rel-4 |  |  | LCS1-CBS |  |  |  |
| 5289 | 68.2 | LCS support in the CS domain | 180d | 2000-05-15 A | 2001-01-19 A | 100% | 2000-05-15 | 2001-01-19 | 180d | finish no earlier than 2001-01-19 | S2 | 1440h | 1440h | LCS4-CS |  | Rel-4 | Maurice |  | LCS1-CS |  |  |  |
| 5290 | 68.3 | **LCS support in the PS domain** | 435d | 2000-05-01 A | 2001-12-28 A | 100% | 2000-05-01 | 2001-12-28 | 435d |  | S2; S1; N1; N4 | 29880h | 29880h | LCS4-PS |  | Rel-4 | Maurice |  | LCS1-PS |  |  |  |
| 5291 | 68.3.1 | Stage 1 for LCS support in the PS domain | 40d | 2000-07-03 A | 2000-08-25 A | 100% | 2000-07-03 | 2000-08-25 | 40d | start no earlier than 2000-07-03 | S1 | 320h | 320h |  | Pacific Bell Wireless | Rel-4 | Alain |  |  |  | Randolph Wohlert (rwohlert@tri.sbc.com) |  |
| 5292 | 68.3.2 | Stage 2 for LCS support in the PS domain | 190d | 2000-05-01 A | 2001-01-19 A | 100% | 2000-05-01 | 2001-01-19 | 190d | finish no earlier than 2001-01-19 | S2; R2; G1 | 4560h | 4560h |  |  | Rel-4 | Maurice |  |  |  |  |  |
| 5293 | 68.3.3 | **Stage 3 for LCS support in the PS domain** | 355d | 2000-08-21 A | 2001-12-28 A | 100% | 2000-08-21 | 2001-12-28 | 355d |  | N1; N4 | 11080h | 11080h |  |  | Rel-4 | Frederic |  |  |  |  |  |
| 5294 | 68.3.3.1 | Layer 3 LCS signalling UE (MS) -SGSN (UMTS PS and and GSM-GPRS) | 355d | 2000-08-21 A | 2001-12-28 A | 100% | 2000-08-21 | 2001-12-28 | 355d | finish no earlier than 2001-12-28 | N1 | 2840h | 2840h |  | Nokia | Rel-4 | Frederic |  |  |  | Janne Muhonen |  |
| 5295 | 68.3.3.2 | MAP impacts of LCS | 160d | 2000-08-21 A | 2001-03-30 A | 100% | 2000-08-21 | 2001-03-30 | 160d | finish no earlier than 2001-03-30 | N4 | 1280h | 1280h |  |  | Rel-4 | Kimmo |  |  |  |  |  |
| 5296 | 68.3.3.3 | GTP signalling for LCS | 160d | 2000-08-21 A | 2001-03-30 A | 100% | 2000-08-21 | 2001-03-30 | 160d | finish no earlier than 2001-03-30 | N4 | 1280h | 1280h |  |  | Rel-4 | Kimmo |  |  |  |  |  |
| 5297 | 68.4 | **UE positioning Rel-4** | 260d | 2000-04-03 A | 2001-03-30 A | 100% | 2000-04-03 | 2001-03-30 | 260d |  | R3; R2 | 7231.2h | 7231.2h | LCS1-UEpos |  | Rel-4 | Issam |  | LCS1-UEpos |  |  | RP-010045 |
| 5298 | 68.4.1 | Iub/Iur interfaces for methods Rel 99 | 233.9d | 2000-04-03 A | 2001-03-30 A | 100% | 2000-04-03 | 2001-03-30 | 233.9d | finish no earlier than 2001-03-30 | R3 | 1871.2h | 1871.2h | LCS1-UEpos-IubIur | Ericsson | Rel-4 | Juha |  | LCS1-UEpos-IubIur |  | Yun-Chao Hu | RP-010045 |
| 5299 | 68.4.2 | UE positioning enhancements - IPDL for TDD | 150d | 2000-08-28 A | 2001-03-23 A | 100% | 2000-08-28 | 2001-03-23 | 150d | finish no earlier than 2001-03-23 | R2 | 1200h | 1200h | LCS1-UEpos-enh | Siemens | Rel-4 | Yong-Jun |  | LCS1-UEpos-enh |  | Armin Sitte | RP-010045 |

Notes:
- 5274: Acronym changed from EMC1, EMC1-CS
- 5275: WI approved in TSG_10
- 5276: -
- 5277: Calls to different emergency services such as ambulance, fire brigade, police, etc. can be routed to respective different emergency centres. / NP-000447 is the stage 3 changes for CS call control protocol. / Impacted TSs and TRs: 24.008
- 5278: UID changed. Marked as stopped 12/2008
- 5279: - / Impacted TSs and TRs: 34.123-1
- 5280: - / Impacted TSs and TRs: 34.123-3
- 5281: -
- 5282: - / Impacted TSs and TRs: 27.007
- 5283: goal not completely achieved because of missing input / Impacted TSs and TRs: 27.007
- 5284: AS: Rel5 changed to Rel4 according to SP#10 decision, milestone on testing added
- 5285: - / Impacted TSs and TRs: 27.903, 27.103
- 5286: - / Impacted TSs and TRs: 23.227
- 5287: Acronym changed form LCS1
- 5288: - / Impacted TSs and TRs: 23.041
- 5289: Only MAP impact foreseen so far. To be further split if needed.
- 5290: -
- 5291: To be also considered: External LCS client identity, and Privacy options when PDP-context and when no PDP-context is established / Impacted TSs and TRs: 22.071
- 5292: SP#10 completed / Impacted TSs and TRs: 25.305 (UTRAN part), new 23.271 (CN part by S2, 43.059 (GERAN part)
- 5293: -
- 5294: -
- 5295: -
- 5296: -
- 5297: -
- 5298: - / Impacted TSs and TRs: 25.401, 25.420, 25.423, 25.430, 25.433, new TR 25.850
- 5299: 5 Mar 2001: split of IPDL for TDD agreed by R2 / Impacted TSs and TRs: new TR 25.847

| ID | WBS | Task | Duration | Start | Finish | Complete | Baseline start | Baseline finish | Baseline duration | Constraint | Resources | Work | Actual work | Acronym | Release | MCC resp | Acronym_3GU_Export | Impacted TSs and TRs | WI rapporteur name | WI rapporteur e-mail | TSG stopped |
| --- | --- | --- | --- | --- | --- | --- | --- | --- | --- | --- | --- | --- | --- | --- | --- | --- | --- | --- | --- | --- | --- |
| 5300 | 69 | **Rel-4 UICC/(U)SIM enhancements and interworking** | 175d | 2000-07-24 A | 2001-03-23 A | 100% | 2000-07-24 | 2001-03-23 | 175d |  | T3 | 2800h | 2800h | UICC1 | Rel-4 | Xavier | UICC1, Rel-4 |  |  |  |  |
| 5301 | 69.1 | Common PCN Handset Specification (CPHS) | 175d | 2000-07-24 A | 2001-03-23 A | 100% | 2000-07-24 | 2001-03-23 | 175d | finish no earlier than 2001-03-23 | T3 | 1400h | 1400h | UICC1-CPHS | Rel-4 | Xavier | UICC1-CPHS | 27.103 | One2One |  |  |
| 5302 | 70 | **Rel-4 (U)SIM toolkit enhancements** | 210d | 2000-06-05 A | 2001-03-23 A | 100% | 2000-06-05 | 2001-03-23 | 210d |  | T3; S1 | 6720h | 6720h | USAT4 | Rel-4 | Xavier | USAT1, USAT1-LocLnk, USAT1APIJAVA, USAT1SM | 23.048 (USAT1SM), 43.019 (USAT1APIJAVA) | Gemplus | Jean-Francois Rubon |  |
| 5303 | 70.1 | USAT local link | 210d | 2000-06-05 A | 2001-03-23 A | 100% | 2000-06-05 | 2001-03-23 | 210d | finish no earlier than 2001-03-23 | T3; S1 | 3360h | 3360h | USAT1-LocLnk | Rel-4 | Xavier | USAT1-LocLnk | 22.038, 31.111 | Gemplus | Jean-Francois Rubon |  |
| 5304 | 71 | **Rel-4 Security enhancements** | 576d | 2000-01-03 A | 2002-03-15 A | 100% | 2000-01-03 | 2002-03-15 | 576d |  | S3; N4; N1 | 38112h | 38112h | SEC4 | Rel-4 | Mirko | SEC1 |  | Vodafone | Peter.Howard@vodafone.com |  |
| 5305 | 54.2 | Rel-4 Lawful Interception | 155d | 2000-08-21 A | 2001-03-23 A | 100% | 2000-08-21 | 2001-03-23 | 155d | finish no earlier than 2001-03-23 | S3 | 1240h | 1240h | SEC4-LI | Rel-4 | Mirko | SEC1-LI | 33.107 |  |  |  |
| 5306 | 71.1 | Evolution of GSM CS algorithms (e.g. A5/3 development and deployment) | 272d | 2000-01-03 A | 2001-01-15 A | 100% | 2000-01-03 | 2001-01-15 | 272d | finish no earlier than 2001-01-15 | S3 | 2168h | 2168h | SEC1-CSALGO1 | Rel-4 | Mirko | SEC1-CSALGO1 | 33.102, 33.103, 33.105 | DTI, BIS | cbrookson@iee.org |  |
| 5307 | 71.2 | **Evolution of GSM PS algorithms (e.g. GEA 2 deployment)** | 219d | 2000-02-22 A | 2000-12-22 A | 100% | 2000-02-22 | 2000-12-22 | 219d |  | S3; N4; N1 | 9528h | 9528h | SEC1-PSALGO1 | Rel-4 | Mirko | SEC1-PSALGO1 | 33.102, 33.103, 33.105 | DTI, BIS | cbrookson@iee.org |  |
| 5308 | 71.2.1 | Deleted - Main aspects of Evolution of GSM PS algorithms (e.g. GEA 2 deployment) | 199d | 2000-02-22 A | 2000-11-24 A | 100% | 2000-02-22 | 2000-11-24 | 199d | finish no earlier than 2000-11-24 | S3 | 1592h | 1592h |  | Rel-4 | Mirko |  |  | DTI, BIS | cbrookson@iee.org | SP-69 |
| 5309 | 71.2.2 | Impact on GTP | 200d | 2000-03-20 A | 2000-12-22 A | 100% | 2000-03-20 | 2000-12-22 | 200d | finish no earlier than 2000-12-22 | N4 | 1600h | 1600h |  | Rel-4 | Kimmo |  |  | DTI, BIS | cbrookson@iee.org |  |
| 5310 | 71.2.3 | GEA capability indication in MS CM | 135d | 2000-06-19 A | 2000-12-22 A | 100% | 2000-06-19 | 2000-12-22 | 135d | finish no earlier than 2000-12-22 | N1 | 1080h | 1080h | SEC1-PSALGO1-GEACAP | Rel-4 | Frederic | SEC1-PSALGO1-GEACAP |  | Vodafone Airtouch | Duncan Mills |  |
| 5311 | 71.3 | **Deleted - MAP application layer security** | 576d | 2000-01-03 A | 2002-03-15 A | 100% | 2000-01-03 | 2002-03-15 | 576d |  | S3 | 11352h | 11352h | SEC1-MAPAL | Rel-4 | Mirko | SEC1-MAPAL |  |  |  | SP-15 |
| 5312 | 71.3.1 | Deleted - Main aspects of MAP application layer security | 199d | 2000-02-21 A | 2001-03-29 A | 100% | 2000-02-21 | 2001-03-29 | 199d | start no earlier than 2000-02-21 | S3 | 1592h | 1592h |  | Rel-4 | Mirko |  |  |  |  | SP-11 |
| 5313 | 71.3.2 | Deleted - Other stage 3 aspects | 199d | 2000-02-22 A | 2000-11-24 A | 100% | 2000-02-22 | 2000-11-24 | 199d | finish no earlier than 2000-11-24 | N4 | 1592h | 1592h |  | Rel-4 | Kimmo |  |  |  |  | CP-10 |
| 5314 | 71.3.3 | Deleted - Visibility and Configurability of security | 576d | 2000-01-03 A | 2002-03-15 A | 100% | 2000-01-03 | 2002-03-15 | 576d | finish no earlier than 2002-03-15 | S3 | 4600h | 4600h | SEC1-VCS | Rel-4 | Mirko | SEC1-VCS |  | France Telecom | Sebastien.nguyenngoc@rd.francetelecom.com | SP-15 |
| 5315 | 72 | **Rel-4 Charging and OAM&P** | 221d | 2000-12-01 A | 2001-10-05 A | 100% | 2000-12-01 | 2001-10-05 | 221d |  | S5 | 10472h | 10472h | OAM4 | Rel-4 | Mirko | OAM4 |  |  |  |  |
| 5316 | 72.1 | Rel-4 Principles, high level Requirements and Architecture | 145d | 2000-12-01 A | 2001-06-21 A | 100% | 2000-12-01 | 2001-06-21 | 145d | finish no earlier than 2001-06-21 | S5 | 1160h | 1160h |  | Rel-4 | Mirko |  | 32.101, 32.102 | Motorola, Telia | Michael.Truss@motorola.com, Tommy.R.Berggren@TELIA.SE |  |
| 5317 | 72.2 | Rel-4 Performance Management | 216d | 2000-12-01 A | 2001-09-28 A | 100% | 2000-12-01 | 2001-09-28 | 216d | finish no earlier than 2001-06-21 | S5 | 1728h | 1728h |  | Rel-4 | Mirko |  | 32.4xy, 52.402 | T-Mobile | karl-heinz.nenner@t-mobile.de |  |
| 5318 | 72.3 | Fault Management | 221d | 2000-12-01 A | 2001-10-05 A | 100% | 2000-12-01 | 2001-10-05 | 221d | finish no earlier than 2001-06-21 | S5 | 1768h | 1768h |  | Rel-4 | Mirko |  | 32.111-1/4 | Lucent |  |  |
| 5319 | 72.4 | Configuration Management | 145d | 2000-12-01 A | 2001-06-21 A | 100% | 2000-12-01 | 2001-06-21 | 145d | finish no earlier than 2001-06-21 | S5 | 1160h | 1160h |  | Rel-4 | Mirko |  | 32.106-1/8 | Ericsson | thomas.tovinger@ericsson.com |  |
| 5320 | 72.5 | Rel-4 Charging Management | 216d | 2000-12-01 A | 2001-09-28 A | 100% | 2000-12-01 | 2001-09-28 | 216d | finish no earlier than 2001-06-21 | S5 | 1728h | 1728h |  | Rel-4 | Mirko |  | 32.200, 32.205, 32.215, 32.235 | T-Mobile | karl-heinz.nenner@t-mobile.de |  |
| 5321 | 72.6 | UTRAN Operations and Maintenance procedures | 145d | 2000-12-01 A | 2001-06-21 A | 100% | 2000-12-01 | 2001-06-21 | 145d | finish no earlier than 2001-06-21 | S5 | 1160h | 1160h | UOAM | Rel-4 | Mirko | UOAM | 32.800 | Mannesmann Mobilfunk | bert.boden@d2mannesmann.de |  |
| 5322 | 73 | **Global Text Telephony** | 317d? | 2000-01-03 A | 2001-03-19 A | 100% | 2000-01-03 | 2009-09-18 | 2537d? |  | S1; S2; S4; T1; R5 | 18528h | 18528h | GTT | Rel-4 | Maurice | GTT |  | Ericsson | gunnar.hellstrom@omnitor.se |  |
| 5323 | 73.1 | Stage 1 for Global Text Telephony | 188d | 2000-04-05 A | 2000-12-22 A | 100% | 2000-04-05 | 2000-12-22 | 188d | finish no earlier than 2000-12-22 | S1 | 1504h | 1504h |  | Rel-4 | Alain |  | 22.226 |  |  |  |
| 5324 | 73.2 | Stage 2 for Global Text Telephony | 206d | 2000-01-03 A | 2000-10-13 A | 100% | 2000-01-03 | 2000-10-13 | 206d |  | S2 | 1640h | 1640h |  | Rel-4 | Maurice |  | 23.226 |  |  |  |

Notes:
- 5300: Acronym changed from UICC1, Rel-4
- 5301: 28/5/2001: CRs approved at TP-11. WI complete.
- 5302: Acronym changed from USAT1, USAT1-LocLnk, USAT1APIJAVA, USAT1SM
- 5303: 25/5/2001:CR was approved at TP-11. WI is complete
- 5304: acronym changed from SEC1
- 5305: Requirements capture: S3#14 (Aug 00), Feature specification: S3#15 (Sep 00), Definition of architecture. Should be included in general LI work mentioned above.. Acronym changed from SEC1-LI
- 5306: SP#8 approved WID
- 5307: SP#8 approved WID
- 5308: Complete TSG#09 (09/2000). S3#17: Proposed for deletion. TO BE DELETED
- 5309: -
- 5310: -
- 5311: REPLACED BY NDS-MAP and NDS-IP. Completed Auto Key Management -> Rel-6. Marked as stopped 12/2008
- 5312: UID changed. Marked as stopped 12/2008
- 5313: UID changed. Marked as stopped 12/2008
- 5314: CR approved at SA3#21 awaiting comments from CN1. Marked as stopped 12/2008
- 5315: SP#13 approved WID
- 5316: -
- 5317: -
- 5318: -
- 5319: -
- 5320: -
- 5321: -
- 5322: SP#12 updated WID SP-000162=>SP-010340
- 5323: -
- 5324: -

| ID | WBS | Task | Type | Duration | Start | Finish | Complete | Baseline start | Baseline finish | Baseline duration | Constraint | Resources | Work | Actual work | Acronym | Release | MCC resp | Acronym_3GU_Export | PCG stopped | TSG stopped |
| --- | --- | --- | --- | --- | --- | --- | --- | --- | --- | --- | --- | --- | --- | --- | --- | --- | --- | --- | --- | --- |
| 5325 | 73.3 | **Specification of Cellular Text telephone Modem** |  | 136d | 2000-09-11 A | 2001-03-19 A | 100% | 2000-09-11 | 2001-03-19 | 136d |  | S4 | 2704h | 2704h | GTT-CTM | Rel-4 | Paolo | GTT-CTM |  |  |
| 5326 | 73.3.1 | General description and C-code |  | 66d | 2000-09-11 A | 2000-12-11 A | 100% | 2000-09-11 | 2000-12-11 | 66d | finish no earlier than 2000-12-11 | S4 | 528h | 528h |  | Rel-4 | Paolo |  |  |  |
| 5327 | 73.3.2 | Minimum Performance requirements |  | 136d | 2000-09-11 A | 2001-03-19 A | 100% | 2000-09-11 | 2001-03-19 | 136d | finish no earlier than 2001-03-19 | S4 | 1088h | 1088h |  | Rel-4 | Paolo |  |  |  |
| 5328 | 73.5 | Deleted - Conformance Test Aspects - Global Text Telephony | milestone | 0d? | 2000-09-21 A | 2000-09-21 A | 100% | 2000-09-21 | 2009-09-18 | 2348d? | finish no earlier than 2009-09-18 | R5; T1 |  |  | GTT_Test | Rel-4 | Ingbert | GTT_Test | PCG-23 | RP-45 |
| 5329 | 1268 | Release 1999 Features |  | 261d? | 2000-01-03 A | 2000-12-29 A | 100% | 2000-01-03 | 2000-12-29 | 261d? |  | NP; SP; TP; SMG | 8352h | 8352h |  | R99 | All |  |  |  |
| 5330 | 1269 | **UMTS Features** |  | 261d? | 1999-01-01 A | 1999-12-31 A | 100% | 1999-01-01 | 1999-12-31 | 261d? |  | S1; S2; S4; SMG; N3; N4; RP | 39672h | 39672h |  | R99 | Alain |  |  |  |
| 5331 | 1269.1 | UMTS_SERVICES |  | 261d? | 1999-01-01 A | 1999-12-31 A | 100% | 1999-01-01 | 1999-12-31 | 261d? | start no earlier than 1999-01-01 | S1 | 2088h | 2088h | UMTS_SERVICES | R99 | Alain | UMTS_SERVICES |  |  |
| 5332 | 1269.2 | UMTS phase 1 |  | 261d? | 1999-01-01 A | 1999-12-31 A | 100% | 1999-01-01 | 1999-12-31 | 261d? | start no earlier than 1999-01-01 | S1 | 2088h | 2088h | UMTS1 | R99 | Alain | UMTS1 |  |  |
| 5333 | 1269.3 | UMTS Capabilities |  | 261d? | 1999-01-01 A | 1999-12-31 A | 100% | 1999-01-01 | 1999-12-31 | 261d? | start no earlier than 1999-01-01 | S1 | 2088h | 2088h | UMTS_Capabil | R99 | Alain | UMTS_Capabil |  |  |
| 5334 | 1269.4 | Architecture of the GSM-UMTS platform |  | 261d? | 1999-01-01 A | 1999-12-31 A | 100% | 1999-01-01 | 1999-12-31 | 261d? | start no earlier than 1999-01-01 | S2; N4 | 4176h | 4176h |  | R99 | Maurice |  |  |  |
| 5335 | 1269.5 | UMTS Terrestrial Radio Access Network |  | 261d? | 1999-01-01 A | 1999-12-31 A | 100% | 1999-01-01 | 1999-12-31 | 261d? | start no earlier than 1999-01-01 | RP | 2088h | 2088h | UTRAN | R99 | Yong-Jun | UTRAN |  |  |
| 5336 | 1269.6 | UMTS 1800, UMTS 1900 |  | 261d? | 1999-01-01 A | 1999-12-31 A | 100% | 1999-01-01 | 1999-12-31 | 261d? | start no earlier than 1999-01-01 | R2 | 2088h | 2088h | Rlnlmp19,Rlnlmp18 | R99 | Yong-Jun | Rlnlmp19, Rlnlmp18 |  |  |
| 5337 | 1269.7 | Mandatory speech codec for narrowband telephony service |  | 261d? | 1999-01-01 A | 1999-12-31 A | 100% | 1999-01-01 | 1999-12-31 | 261d? | start no earlier than 1999-01-01 | S4 | 2088h | 2088h | Mandatory_Speech_Codec,AMR-NB,AMR | R99 | Paolo | Mandatory_Speech_Codec, AMR-NB, AMR |  |  |
| 5338 | 1269.8 | Codec for low bitrate multimedia telephony service |  | 261d? | 1999-01-01 A | 1999-12-31 A | 100% | 1999-01-01 | 1999-12-31 | 261d? | start no earlier than 1999-01-01 | S4 | 2088h | 2088h | Low_bit_rate_codec_for_MM_Tel.,H.324M | R99 | Paolo | Low_bit_rate_codec_for_MM_Tel., H.324M |  |  |
| 5339 | 1269.9 | 3G Audio-Visual Terminal characteristics |  | 261d? | 1999-01-01 A | 1999-12-31 A | 100% | 1999-01-01 | 1999-12-31 | 261d? | start no earlier than 1999-01-01 | S4 | 2088h | 2088h | WI5TAC,3G-AVT,Terminal_Acoustic_Characteristics | R99 | Paolo | WI5TAC, 3G-AVT, Terminal_Acoustic_Characteristics |  |  |
| 5340 | 1269.10 | Updates_for_UMTS |  | 261d? | 1999-01-01 A | 1999-12-31 A | 100% | 1999-01-01 | 1999-12-31 | 261d? | start no earlier than 1999-01-01 | N3 | 2088h | 2088h | Updates_for_UMTS | R99 | Gwiho | Updates_for_UMTS |  |  |
| 5341 | 1269.11 | UMTS |  | 261d? | 1999-01-01 A | 1999-12-31 A | 100% | 1999-01-01 | 1999-12-31 | 261d? | start no earlier than 1999-01-01 | N3 | 2088h | 2088h | UMTS | R99 | Gwiho | UMTS |  |  |
| 5342 | 1270 | **UMTS and GSM Features** |  | 261d? | 1999-01-01 A | 1999-12-31 A | 100% | 1999-01-01 | 1999-12-31 | 261d? |  | S1; S2; SMG; T2; N1; N2; N3; N4; R2; R3 | 219240h | 219240h |  | R99 | Alain |  |  |  |
| 5343 | 1270.1 | Multimedia Messaging Service |  | 261d? | 1999-01-01 A | 1999-12-31 A | 100% | 1999-01-01 | 1999-12-31 | 261d? | start no earlier than 1999-01-01 | T2 | 2088h | 2088h | MMS | R99 |  | MMS |  |  |
| 5344 | 1270.2 | Location Services |  | 261d? | 1999-01-01 A | 1999-12-31 A | 100% | 1999-01-01 | 1999-12-31 | 261d? | start no earlier than 1999-01-01 | S1; S2; S3; SMG1; SMG2; SMG12; N1; N2; N4; R2; R3 | 22968h | 22968h | LCS | R99 | Alain | LCS |  |  |
| 5345 | 1270.3 | **Customised Application for Mobile network Enhanced Logic Phase 3** |  | 261d? | 1999-01-01 A | 1999-12-31 A | 100% | 1999-01-01 | 1999-12-31 | 261d? |  | S1; S2; N2; N4 | 18792h | 18792h | CAMEL3 | R99 | Alain | CAMEL3 |  |  |
| 5346 | 1270.3.1 | Global view |  | 261d? | 1999-01-01 A | 1999-12-31 A | 100% | 1999-01-01 | 1999-12-31 | 261d? | start no earlier than 1999-01-01 | S1; S2; N2; N4 | 8352h | 8352h |  | R99 | Alain |  |  |  |
| 5347 | 1270.3.2 | Multiple Subscriber Profile (MSP) based on CAMEL phase 3 |  | 261d? | 1999-01-01 A | 1999-12-31 A | 100% | 1999-01-01 | 1999-12-31 | 261d? | start no earlier than 1999-01-01 | S1 | 2088h | 2088h |  | R99 | Alain |  |  |  |
| 5348 | 1270.4 | Short Message Service enhancements / Enhanced Messaging Service (EMS) |  | 261d? | 1999-01-01 A | 1999-12-31 A | 100% | 1999-01-01 | 1999-12-31 | 261d? | start no earlier than 1999-01-01 | T2 | 2088h | 2088h | EMS | R99 |  | EMS |  |  |
| 5349 | 1270.5 | Mobile Station Execution Environment |  | 261d? | 1999-01-01 A | 1999-12-31 A | 100% | 1999-01-01 | 1999-12-31 | 261d? | start no earlier than 1999-01-01 | S1; SMG1; T2 | 6264h | 6264h | MExE | R99 | Alain | MExE |  |  |
| 5350 | 1270.6 | MS_Classmark |  | 261d? | 1999-01-01 A | 1999-12-31 A | 100% | 1999-01-01 | 1999-12-31 | 261d? | start no earlier than 1999-01-01 | N1 | 2088h | 2088h | MS_Classmark | R99 | Frederic | MS_Classmark |  |  |

Notes:
- 5325: -
- 5326: - / Impacted TSs and TRs: 26.226, 26.230
- 5327: - / Impacted TSs and TRs: 26.231
- 5328: RP#45 work item abandoned/closed (it was never really started)
- 5329: -
- 5330: -
- 5331: - / Impacted TSs and TRs: 22.101
- 5332: - / Impacted TSs and TRs: 22.100
- 5333: Requirement for high quality speech in UMTS Phase 1 but not in R99 / Impacted TSs and TRs: 22.105
- 5334: wid Architecture overview of the GSM-UMTS System, Architecture the GSM-UMTS Platform and New Access Network to Core Network (BSS-NSS) interface / Impacted TSs and TRs: 23.002, 23.008, 23.060, 23.101, 23.110
- 5335: - / Impacted TSs and TRs: 22.011, 22.038, 22.060, 22.078, 22.100, 22.101, 22.105, 22.115, 22.129, 23.002, 23.060, 24.007, 24.008, 25.101, 25.102, 25.104, 25.105, 25.113, 25.123, 25.133, 25.141, 25.142, 25.201, 25.211, 25.212, 25.213, 25.214, 25.215, 25.221, 25.222, 25.223, 25.224,
- 5336: - / Impacted TSs and TRs: 25.307 CR#0002, 0003 Inclusion of release independent RF related information
- 5337: Define the default speech codec for UMTS (both for FDD and TDD). Definition limited to selection of one codec among several existing ones/proposed codecs: GSM AMR, IS127 EVRC, ITU G.729 and MPEG-4 speech codec. / Impacted TSs and TRs: 04.08, 05.01, 05.02, 05.03, 05.05, 05.08, 05.09, 05.09, 05.50, 08.60, 08.61, 11.21, 26.071, 26.073, 26.074, 26.090, 26.091, 26.092, 26.093, 26.094, 26.101, 26.102, 26.103, 26.104, 26.975
- 5338: - / Impacted TSs and TRs: 26.104, 26.110, 26.111, 26.911, 26.912, 26.915
- 5339: - / Impacted TSs and TRs: 26.131, 26.132
- 5340: - / Impacted TSs and TRs: 24.022, 27.001, 29.007
- 5341: - / Impacted TSs and TRs: 27.060, 29.061
- 5342: -
- 5343: MMS allows users to send/receive messages e.g. almost unlimited text length, images, audio and video clips and new content types. R99 only includes the concept. MMS stage 3 is not included in 23.140. Rel-4 adds detailed architecture and protocols. / Impacted TSs and TRs: 22.140, 23.040, 23.140
- 5344: LCS provide ability to localize a terminal / Impacted TSs and TRs: 02.07, 03.71, 04.31, 04.35, 04.71, 05.05, 08.08, 08.31, 08.71, 09.31, 22.071, 23.002, 23.003, 23.007, 23.008, 23.016, 23.018, 23.032, 23.171, 24.007, 24.008, 24.030, 24.080, 25.305, 25.306, 25.331, 25.413, 25.423, 29.002, 29.010
- 5345: CAMEL is a network feature providing mechanisms to support services of operators which are not covered by standardised services, even when roaming outside the HPLMN. / Impacted TSs and TRs: 22.101, 23.008, 23.012, 23.016, 23.018, 23.060, 23.072, 23.078, 23.079, 23.082, 23.093, 29.002, 29.078
- 5346: - / Impacted TSs and TRs: 22.078, 23.078, 29.078
- 5347: MSP is an optional service enabling mobile subscribers to have several profiles associated with a single IMSI, with each profile being a subscription option. Each profile may be used for mobile originated and mobile terminated calls. / Impacted TSs and TRs: 22.097 (Advanced Addressing)
- 5348: SMS for 3G terminals compatible with GSM SMS. Added Enhanced Messaging Service (EMS) allowing small pictures, sounds, animations to be transferred via SMS. / Impacted TSs and TRs: 23.038, 23.039, 23.040, 23.042
- 5349: MExE provides a standardized MS execution environment and ability to negotiate its supported capabilities with a MExE SP. R99 enhances SIM MExE certificate management, security clarifications, QoS and defines two MExE classmarks WAP/Personal-Java based. / Impacted TSs and TRs: 02.57, 22.057, 22.101, 23.057
- 5350: MExE classmark identifies a category of MExE UE supporting MExE functionality with a minimum level of processing, memory, display, and interactive capabilities. Several MExE classmarks may be defined. / Impacted TSs and TRs: 24.008

| ID | WBS | Task | Duration | Start | Finish | Complete | Baseline start | Baseline finish | Baseline duration | Constraint | Resources | Work | Actual work | Acronym | Release | MCC resp | Acronym_3GU_Export | TSG stopped |
| --- | --- | --- | --- | --- | --- | --- | --- | --- | --- | --- | --- | --- | --- | --- | --- | --- | --- | --- |
| 5351 | 1270.7 | **MultiCall** | 261d? | 1999-01-01 A | 1999-12-31 A | 100% | 1999-01-01 | 1999-12-31 | 261d? |  | S1; N1; N2; N4 | 10440h | 10440h | Multicall | R99 | Alain | Multicall |  |
| 5352 | 1270.7.1 | Stage 1 for Multicall | 261d? | 1999-01-01 A | 1999-12-31 A | 100% | 1999-01-01 | 1999-12-31 | 261d? | start no earlier than 1999-01-01 | S1 | 2088h | 2088h |  | R99 | Alain |  |  |
| 5353 | 1270.8 | Virtual Home Environment | 261d? | 1999-01-01 A | 1999-12-31 A | 100% | 1999-01-01 | 1999-12-31 | 261d? | start no earlier than 1999-01-01 | S1; SMG1; S2 | 6264h | 6264h | VHE | R99 | Alain | VHE |  |
| 5354 | 1270.9 | Open Service Access | 261d? | 1999-01-01 A | 1999-12-31 A | 100% | 1999-01-01 | 1999-12-31 | 261d? | start no earlier than 1999-01-01 | S1; S2; N5 | 6264h | 6264h | OSA | R99 | Alain | OSA |  |
| 5355 | 1270.10 | Super Charger mechanism for signalling traffic associated with mobility | 261d? | 1999-01-01 A | 1999-12-31 A | 100% | 1999-01-01 | 1999-12-31 | 261d? | start no earlier than 1999-01-01 | N2; N4 | 4176h | 4176h | Super_Charger | R99 | Kimmo | Super_Charger |  |
| 5356 | 1270.11 | Follow_Me service | 261d? | 1999-01-01 A | 1999-12-31 A | 100% | 1999-01-01 | 1999-12-31 | 261d? | start no earlier than 1999-01-01 | S1; N2; N4 | 6264h | 6264h | Follow_Me | R99 | Alain | Follow_Me |  |
| 5357 | 1270.12 | Wide area network Synchronization and object exchange | 261d? | 1999-01-01 A | 1999-12-31 A | 100% | 1999-01-01 | 1999-12-31 | 261d? | start no earlier than 1999-01-01 | T2 | 2088h | 2088h | SYNC | R99 |  | SYNC |  |
| 5358 | 1270.13 | **R99 Terminal Interfaces** | 261d? | 1999-01-01 A | 1999-12-31 A | 100% | 1999-01-01 | 1999-12-31 | 261d? |  | T2 | 8352h | 8352h |  | R99 |  |  |  |
| 5359 | 1270.13.1 | AT commands for 3GPP | 261d? | 1999-01-01 A | 1999-12-31 A | 100% | 1999-01-01 | 1999-12-31 | 261d? | start no earlier than 1999-01-01 | T2 | 2088h | 2088h |  | R99 |  |  |  |
| 5360 | 1270.13.2 | Physical interfaces | 261d? | 1999-01-01 A | 1999-12-31 A | 100% | 1999-01-01 | 1999-12-31 | 261d? | start no earlier than 1999-01-01 | T2 | 2088h | 2088h |  | R99 |  |  |  |
| 5361 | 1270.13.3 | Multiplexer | 261d? | 1999-01-01 A | 1999-12-31 A | 100% | 1999-01-01 | 1999-12-31 | 261d? | start no earlier than 1999-01-01 | T2 | 2088h | 2088h | MUXMS-TE | R99 |  | MUX MS-TE |  |
| 5362 | 1270.14 | **Bearer Services** | 261d? | 1999-01-01 A | 1999-12-31 A | 100% | 1999-01-01 | 1999-12-31 | 261d? |  | S1; T2; N1; N3 | 41760h | 41760h |  | R99 | Alain |  |  |
| 5363 | 1270.14.1 | **Circuit Switched Bearer Services** | 261d? | 1999-01-01 A | 1999-12-31 A | 100% | 1999-01-01 | 1999-12-31 | 261d? |  | S1; N3 | 16704h | 16704h | Circuit_switched_Bearer_Services | R99 | Alain | Circuit_switched_Bearer_Services |  |
| 5364 | 1270.14.1.1 | Stage 1 for Circuit Switched Bearer Services | 261d? | 1999-01-01 A | 1999-12-31 A | 100% | 1999-01-01 | 1999-12-31 | 261d? | start no earlier than 1999-01-01 | S1 | 2088h | 2088h | CS_Bearerss_in_UMTS | R99 | Alain | CS_Bearerss_in_UMTS |  |
| 5365 | 1270.14.1.2 | CS_Bearers | 261d? | 1999-01-01 A | 1999-12-31 A | 100% | 1999-01-01 | 1999-12-31 | 261d? | start no earlier than 1999-01-01 | N3 | 2088h | 2088h | CS_Bearers | R99 | Gwiho | CS_Bearers |  |
| 5366 | 1270.14.1.3 | CS_Bearerss | 261d? | 1999-01-01 A | 1999-12-31 A | 100% | 1999-01-01 | 1999-12-31 | 261d? | start no earlier than 1999-01-01 | N3 | 2088h | 2088h | CS_Bearerss | R99 | Gwiho | CS_Bearerss |  |
| 5367 | 1270.14.1.4 | CS_Data | 261d? | 1999-01-01 A | 1999-12-31 A | 100% | 1999-01-01 | 1999-12-31 | 261d? | start no earlier than 1999-01-01 | N3 | 2088h | 2088h | CS_Data | R99 | Gwiho | CS_Data |  |
| 5368 | 1270.14.1.5 | CS_Data_Bearers | 261d? | 1999-01-01 A | 1999-12-31 A | 100% | 1999-01-01 | 1999-12-31 | 261d? | start no earlier than 1999-01-01 | N3 | 2088h | 2088h | CS_Data_Bearers | R99 | Gwiho | CS_Data_Bearers |  |
| 5369 | 1270.14.1.6 | Deleted - CN3 poart of Circuit Switched Bearer Services | 261d? | 1999-01-01 A | 1999-12-31 A | 100% | 1999-01-01 | 1999-12-31 | 261d? | start no earlier than 1999-01-01 | N3 | 2088h | 2088h | CSBS | R99 | Gwiho | CSBS | NP-06 |
| 5370 | 1270.14.2 | Frame Tunnelling Mode | 261d? | 1999-01-01 A | 1999-12-31 A | 100% | 1999-01-01 | 1999-12-31 | 261d? | start no earlier than 1999-01-01 | T2; N1; N3 | 6264h | 6264h | FTM | R99 | Gwiho | FTM |  |
| 5371 | 1270.14.3 | Access to ISPs and Intranets – Wireless/Remote access to LANs | 261d? | 1999-01-01 A | 1999-12-31 A | 100% | 1999-01-01 | 1999-12-31 | 261d? | start no earlier than 1999-01-01 | N3 | 2088h | 2088h | InterworkingwithPDN(DHCP) | R99 | Gwiho | Interworking with PDN (DHCP) |  |
| 5372 | 1270.14.4 | **PHS Internet Access Forum Specification** | 261d? | 1999-01-01 A | 1999-12-31 A | 100% | 1999-01-01 | 1999-12-31 | 261d? |  | S1; N3 | 8352h | 8352h | PIAFS | R99 | Alain | PIAFS |  |
| 5373 | 1270.14.4.1 | Personal Handyphone System Internet Access Forum Standard (PIAFS) | 261d? | 1999-01-01 A | 1999-12-31 A | 100% | 1999-01-01 | 1999-12-31 | 261d? | start no earlier than 1999-01-01 | S1 | 2088h | 2088h |  | R99 | Alain |  |  |
| 5374 | 1270.14.4.2 | Support_of_PIAFS_in_UMTS | 261d? | 1999-01-01 A | 1999-12-31 A | 100% | 1999-01-01 | 1999-12-31 | 261d? | start no earlier than 1999-01-01 | N3 | 2088h | 2088h | Support_of_PIAFS_in_UMTS | R99 | Gwiho | Support_of_PIAFS_in_UMTS |  |

Notes:
- 5351: Multicall allows several simultaneous CS calls with dedicated bearers of independent traffic and performance characteristics. R99 Multicall was defined as a supplementary service limited to one CS bearer to be used for speech at any time. / Impacted TSs and TRs: 22.030, 22.083, 22.087, 23.008, 23.009, 23.016, 23.018, 23.108, 23.135, 24.008, 24.080, 24.135, 29.002, 29.010
- 5352: - / Impacted TSs and TRs: 22.030, 22.083, 22.087
- 5353: Information exists in SP#5-8 reports & in SP-99416,SP-000095,SP 000155. OSA allows service development by operators and 3rd parties by making use of network functionality through open, standardised, secure, extensible and scalable interfaces. / Impacted TSs and TRs: 02.01, 22.105, 22.121,23.127
- 5354: Open Service Architecture became in later Releases Open Service Access. Produced by Parlay, ETSI SPAN (TISPAN), 3GPP SA1 (Stage 1), SA2 (Stage 2) and CN5 (Stage 3), resulting in a single set of standard OSA APIs for the whole development community. / Impacted TSs and TRs: 22.121, 23.127, 29.198, 29.998
- 5355: Super Charger reduces mobility management cost by reducing the volume of location update signalling. It changes subscriber data management associated with inter-VLR and SGSN location updates. It also applies to packet services (SGSN replaces VLR and … / Impacted TSs and TRs: 21.905, 23.007, 23.008, 23.012, 23.016, 23.018, 23.040, 23.060, 23.116, 23.912, 29.002
- 5356: Follow Me enables a mobile subscriber A to manipulate the Follow Me data of a party B in such a way that - under certain conditions - subsequent calls directed to party B will be forwarded to subscriber A. It is PLMN-specific and control based on USSD / Impacted TSs and TRs: 21.905, 22.004, 22.030, 22.082, 22.090, 22.094, 23.090, 24.090, 22.094, 23.011, 23.015, 23.082, 29.002
- 5357: Allows data stored in ME/USIM to be synchronized with the outside world. TS 27.103 defines protocols based upon IrMC level 4 and will evaluate new technologies (XML) for inclusion. From Rel-4 IrMC was replaced by SyncML in 27.103. / Impacted TSs and TRs: 27.103, 27.903
- 5358: -
- 5359: AT commands to control a 3G ME via an external Terminal Equipment (TE), fully compatible with GSM AT commands. R99 adds new AT commands e.g. to control Advanced Speech Call Items (ASCI) services. / Impacted TSs and TRs: 27.005, 27.007
- 5360: Conclusion: 3GPP should not produce any technical specification for terminal interfaces other than radio interface and USIM interface. SDOs could develop own optional physical connector specification based on market requirements / Impacted TSs and TRs: 27.901
- 5361: Multiplexing protocol allowing a number of simultaneous sessions between a MS and a terminal; used to send any data (voice, SMS, USSD, fax etc.). 27.010 describes the protocol, but not the commands or data transported with it. / Impacted TSs and TRs: 27.010
- 5362: -
- 5363: CS and real-time data services provided for interworking with PSTN/ISDN so that user is unaware of access network used (UMTS, GSM or handover between ANs). Transparent(constant delay) & non-transparent(zero error with flow control) services are supported / Impacted TSs and TRs: 22.002, 23.910, 27.001, 29.007
- 5364: CS and real-time data services provided for interworking with PSTN/ISDN so that user is unaware of access network used (UMTS, GSM or handover between ANs). Transparent(constant delay) & non-transparent(zero error with flow control) services are supported / Impacted TSs and TRs: 22.002
- 5365: - / Impacted TSs and TRs: 29.007
- 5366: - / Impacted TSs and TRs: 04.21, 23.910, 27.001, 29.007
- 5367: - / Impacted TSs and TRs: 27.001, 27.002, 27.003, 29.007
- 5368: - / Impacted TSs and TRs: 23.910, 27.001, 29.007
- 5369: No CR or new TS/TR approved under this WI / Impacted TSs and TRs: 23.910, 27.001, 29.007
- 5370: FTM is a type of async non-transparent CS bearer service (22.002). Generic term for HDLC and HDLC-related transmission protocols. Converts async non-transp data stream towards mobile side & sync data stream using X.31 flag stuffing on fixed network side. / Impacted TSs and TRs: 22.002, 27.001, 27.007, 29.007
- 5371: Access to an Intranet or ISP by running DHCP between the TE and a server in the Intranet/ISP domain. / Impacted TSs and TRs: 29.061
- 5372: PIAFS is one type of CS bearer data service (22.002). It refers to async CS tx protocol over ISDN 64 kbit/s unrestricted digital line. Facilitates interworking between PHS-MS and UMTS-UE & UMTS-UE and existing PIAFS TA (Terminal Adapter). / Impacted TSs and TRs: 22.002, 27.001, 27.007, 29.007
- 5373: PIAFS was originally standardised by the PHS Internet Access Forum in Japan. More information can be found at: http://www.infopro.or.jp/piaf / Impacted TSs and TRs: 22.002
- 5374: - / Impacted TSs and TRs: 27.001, 27.007, 29.007

| ID | WBS | Task | Duration | Start | Finish | Complete | Baseline start | Baseline finish | Baseline duration | Constraint | Resources | Work | Actual work | Acronym | Release | MCC resp | Acronym_3GU_Export | TSG stopped |
| --- | --- | --- | --- | --- | --- | --- | --- | --- | --- | --- | --- | --- | --- | --- | --- | --- | --- | --- |
| 5375 | 1270.15 | **Universal Integrated Circuit Card (UICC) and Universal Subscriber Identity Module (USIM)** | 261d? | 1999-01-01 A | 1999-12-31 A | 100% | 1999-01-01 | 1999-12-31 | 261d? |  | T3 | 31320h | 31320h | UICC,USIM | R99 | Xavier | UICC, USIM |  |
| 5376 | 1270.15.1 | UICC / Terminal interface; Physical and logical characteristics | 261d? | 1999-01-01 A | 1999-12-31 A | 100% | 1999-01-01 | 1999-12-31 | 261d? | start no earlier than 1999-01-01 | T3 | 2088h | 2088h | UICC | R99 | Xavier | UICC |  |
| 5377 | 1270.15.2 | UICC/(U)SIM enhancements and interworking | 261d? | 1999-01-01 A | 1999-12-31 A | 100% | 1999-01-01 | 1999-12-31 | 261d? | start no earlier than 1999-01-01 | T3 | 2088h | 2088h | UICC99 | R99 | Xavier | UICC1 |  |
| 5378 | 1270.15.3 | Characteristics of the USIM application | 261d? | 1999-01-01 A | 1999-12-31 A | 100% | 1999-01-01 | 1999-12-31 | 261d? | start no earlier than 1999-01-01 | T3 | 2088h | 2088h | USIM | R99 | Xavier | USIM |  |
| 5379 | 1270.15.4 | UICC Application Identifiers | 261d? | 1999-01-01 A | 1999-12-31 A | 100% | 1999-01-01 | 1999-12-31 | 261d? | start no earlier than 1999-01-01 | T3 | 2088h | 2088h | AID,Application_Identifiers | R99 | Xavier | AID, Application_Identifiers |  |
| 5380 | 1270.15.5 | SIM Application Toolkit | 261d? | 1999-01-01 A | 1999-12-31 A | 100% | 1999-01-01 | 1999-12-31 | 261d? | start no earlier than 1999-01-01 | S1; T3 | 4176h | 4176h | SAT | R99 | Alain | SAT |  |
| 5381 | 1270.15.6 | USIM Application Toolkit | 261d? | 1999-01-01 A | 1999-12-31 A | 100% | 1999-01-01 | 1999-12-31 | 261d? | start no earlier than 1999-01-01 | T3 | 2088h | 2088h | USAT | R99 | Xavier | USAT |  |
| 5382 | 1270.15.7 | Bearer Independent Protocol for SAT applications to exchange data over the GSM network | 261d? | 1999-01-01 A | 1999-12-31 A | 100% | 1999-01-01 | 1999-12-31 | 261d? | start no earlier than 1999-01-01 | T3 | 2088h | 2088h | BIP | R99 | Xavier | BIP |  |
| 5383 | 1270.15.8 | Administrative commands and functions for IC cards | 261d? | 1999-01-01 A | 1999-12-31 A | 100% | 1999-01-01 | 1999-12-31 | 261d? | start no earlier than 1999-01-01 | T3 | 2088h | 2088h |  | R99 | Xavier |  |  |
| 5384 | 1270.15.9 | USIM and UICC requirements | 261d? | 1999-01-01 A | 1999-12-31 A | 100% | 1999-01-01 | 1999-12-31 | 261d? | start no earlier than 1999-01-01 | T3 | 2088h | 2088h |  | R99 | Xavier |  |  |
| 5385 | 1270.15.10 | SIM_API | 261d? | 1999-01-01 A | 1999-12-31 A | 100% | 1999-01-01 | 1999-12-31 | 261d? | start no earlier than 1999-01-01 | T3 | 2088h | 2088h | SIM_API | R99 | Xavier | SIM_API |  |
| 5386 | 1270.15.11 | SIM_toolkit_API | 261d? | 1999-01-01 A | 1999-12-31 A | 100% | 1999-01-01 | 1999-12-31 | 261d? | start no earlier than 1999-01-01 | SMG9; T3 | 4176h | 4176h | SIM_toolkit | R99 | Xavier | SIM_toolkit |  |
| 5387 | 1270.15.12 | Deleted - 1.8 Volt SIM ME interface | 261d? | 1999-01-01 A | 1999-12-31 A | 100% | 1999-01-01 | 1999-12-31 | 261d? | start no earlier than 1999-01-01 | SMG9 | 2088h | 2088h | SMIME_1.8V | R99 | Xavier | SMIME_1.8V | TP-06 |
| 5388 | 1270.16 | **USIM/UICC Testing** | 261d? | 1999-01-01 A | 1999-12-31 A | 100% | 1999-01-01 | 1999-12-31 | 261d? |  | T3 | 10440h | 10440h |  | R99 | Xavier |  |  |
| 5389 | 1270.16.1 | Terminal tests for the UICC Interface | 261d? | 1999-01-01 A | 1999-12-31 A | 100% | 1999-01-01 | 1999-12-31 | 261d? | start no earlier than 1999-01-01 | T3 | 2088h | 2088h |  | R99 | Xavier |  |  |
| 5390 | 1270.16.2 | USIM application test specification | 261d? | 1999-01-01 A | 1999-12-31 A | 100% | 1999-01-01 | 1999-12-31 | 261d? | start no earlier than 1999-01-01 | T3 | 2088h | 2088h |  | R99 | Xavier |  |  |
| 5391 | 1270.16.3 | USIM conformance test specification | 261d? | 1999-01-01 A | 1999-12-31 A | 100% | 1999-01-01 | 1999-12-31 | 261d? | start no earlier than 1999-01-01 | T3 | 2088h | 2088h |  | R99 | Xavier |  |  |
| 5392 | 1270.16.4 | SIM toolkit test specification | 261d? | 1999-01-01 A | 1999-12-31 A | 100% | 1999-01-01 | 1999-12-31 | 261d? | start no earlier than 1999-01-01 | T3 | 2088h | 2088h |  | R99 | Xavier |  |  |
| 5393 | 1270.17 | **Security for UMTS and GSM Features** | 261d? | 1999-01-01 A | 1999-12-31 A | 100% | 1999-01-01 | 1999-12-31 | 261d? |  | S3; N2; N4 | 16704h | 16704h | Security | R99 | Mirko | Security |  |
| 5394 | 1270.17.1 | Fraud Information Gathering Service (for connection-orientated services) | 261d? | 1999-01-01 A | 1999-12-31 A | 100% | 1999-01-01 | 1999-12-31 | 261d? | start no earlier than 1999-01-01 | S3 | 2088h | 2088h | FIGS | R99 | Mirko | FIGS |  |
| 5395 | 1270.17.2 | Immediate Service Termination / SECurity Immediate Service Termination | 261d? | 1999-01-01 A | 1999-12-31 A | 100% | 1999-01-01 | 1999-12-31 | 261d? | start no earlier than 1999-01-01 | S3; N2; N4 | 6264h | 6264h | IST,SECIST | R99 | Mirko | IST, SECIST |  |
| 5396 | 1270.17.3 | Core_Network_Security | 261d? | 1999-01-01 A | 1999-12-31 A | 100% | 1999-01-01 | 1999-12-31 | 261d? | start no earlier than 1999-01-01 | N4 | 2088h | 2088h | Core_Network_Security | R99 | Kimmo | Core_Network_Security |  |
| 5397 | 1271 | **GSM Features** | 261d? | 1999-01-01 A | 1999-12-31 A | 100% | 1999-01-01 | 1999-12-31 | 261d? |  | S1; S2; SMG; T2; N1; N2; N3; N4 | 164952h | 164952h |  | R99 | Alain |  |  |
| 5398 | 1271.1 | **Dual Transfer Mode within GSM and GPRS** | 261d? | 1999-01-01 A | 1999-12-31 A | 100% | 1999-01-01 | 1999-12-31 | 261d? |  | SMG; N1 | 10440h | 10440h | DTM | R99 | Frederic | DTM |  |
| 5399 | 1271.1.1 | Class A Dual Transfer Mode | 261d? | 1999-01-01 A | 1999-12-31 A | 100% | 1999-01-01 | 1999-12-31 | 261d? | start no earlier than 1999-01-01 | SMG | 2088h | 2088h | Class_A_Dual_Transfer_Mode_(DTM) | R99 | Frederic | Class_A_Dual_Transfer_Mode_(DTM) |  |
| 5400 | 1271.1.2 | Dual Transfer Mode | 261d? | 1999-01-01 A | 1999-12-31 A | 100% | 1999-01-01 | 1999-12-31 | 261d? | start no earlier than 1999-01-01 | SMG; N1 | 4176h | 4176h |  | R99 | Frederic |  |  |

Notes:
- 5375: For 3G, GSM 11.11 was divided into two parts: a platform comprised of basic physical, electrical and logical specification (31.101) and an application specification (31.102)
- 5376: Defines a generic Terminal/Integrated Circuit Card (ICC) interface. Is independent of 3G USIM application => platform for any IC card application. Ensures interoperability between ICC and terminal independently of manufacturer, card issuer or operator. / Impacted TSs and TRs: 31.101 (Since 10/2000, ETSI EP SCP is responsible for the generic Terminal/Integrated Circuit Card (ICC) interface TS 102 221)
- 5377: Acronym changed from UICC1 / Impacted TSs and TRs: 31.102, 31.900
- 5378: Defines Universal Subscriber Identity Module (USIM) application for 3G telecom network operation & resides on UICC, an IC card specified in 31.101. UICC can be used as a multi-application card: several USIMs and/or other applications can co-exist / Impacted TSs and TRs: 31.102
- 5379: Defines and administers Application IDentifiers (AID) for UICC. AID is used to address an application in the card. Consists of Registered application provider ID (RID) & Proprietary application ID exception (PIX - according to ISO/IEC 7816-5). / Impacted TSs and TRs: 21.111, 31.110
- 5380: - / Impacted TSs and TRs: 11.14, 22.030, 22.100, 22.101
- 5381: Defines UICC - ME interface, and mandatory ME procedures for USAT. Based on GSM 11.14 (SIM Application Toolkit). Commands and procedures defined in USIM and 3G Terminal for using USAT. Service and security requirements defined in 22.100 and 22.101. / Impacted TSs and TRs: 31.111
- 5382: Defines at SIM-ME interface a basic protocol allowing SIM Toolkit applications to determine available bearers and to exchange data by selecting using the most appropriate bearer available (CS data, GPRS, SMS, Unstructured Supplementary Service Data (USSD) / Impacted TSs and TRs: 03.48, 11.10, 11.14
- 5383: Defines function and syntax of administrative commands for telecommunication IC Card used during installation, activation and de-activation of applications. Compliant to ISO/IEC 7816 series. Handed over to ETSI Project Smart Card Platform (SCP) in 2000. / Impacted TSs and TRs: ETSI TS 102 222
- 5384: High level requirements for 3GPP IC card and its interface to 3GPP terminal (USIM&UICC reqs). Service&security reqs in 322.01,22.00. USIM is a 3GPP application on an IC card. Inter-operates with 3GPP terminals and provides access to 3GPP services / Impacted TSs and TRs: 21.111
- 5385: - / Impacted TSs and TRs: 03.19
- 5386: - / Impacted TSs and TRs: 03.48, 11.11, 11.14
- 5387: No CR or new TS/TR approved under this WI / Impacted TSs and TRs: 11.18
- 5388: -
- 5389: Test spec for the interface between UICC and terminal (originally based GSM 11.10-1 clause 27). Ensures UICC - terminal interoperability independently of manufacturer, card issuer or operator. Tests for applications residing on UICC are in 31.121 / Impacted TSs and TRs: 31.120
- 5390: Application test spec originally based on GSM 11.17. Aspects related to UICC administrative management phase are not defined. Any internal technical realisation of either UICC or terminal is only specified where these are reflected over the interface. / Impacted TSs and TRs: 31.121
- 5391: Conformance Test specification for UICC defined in 31.101 with USIM defined in 31.102. / Impacted TSs and TRs: 31.122
- 5392: SIM Application Toolkit (SAT) has major impact on ME design and enhances SIM/ME interface. Contains tests for SIM/ME interface optional features (no network related signalling issues involved). Doesn't form basis for any type approval or regulatory tests. / Impacted TSs and TRs: 11.10-4
- 5393: - / Impacted TSs and TRs: 02.09, 03.20, 21.133, 22.022, 23.003, 23.007, 23.008, 23.012, 23.018, 24.007, 24.008, 24.010, 24.011, 29.002, 29.060, New (33.102, 33.103, 33.105, 33.107, 35.201)
- 5394: HPLMN can monitor its subscribers in VPLMN, which collects info on a defined set of monitored subscribers activities & sends it to HPLMN, which can perform service limitation control eg Operator Determined Barring (ODB) and IST to limit financial exposure / Impacted TSs and TRs: New 22.031, 23.031
- 5395: HPLMN can terminate all activities of its subscriber in VPLMN, if decides (based on info via eg FIGS) that a roaming subscriber is behaving in fraudulent/suspicious way. HPLMN can terminate all subscriber activities including calls in progress. / Impacted TSs and TRs: 03.35, 22.032, 23.008, 23.016, 23.035, 29.002
- 5396: - / Impacted TSs and TRs: 29.002
- 5397: -
- 5398: 2-99-1780 (2-99-H80 from SMG2#32) WID on BSS co-ordination of Radio Resource allocation for class A GPRS services - GSM Radio Access (R99) / Impacted TSs and TRs: 03.55, 03.64, 04.18, 04.60, 05.01, 05.02, 05.08, 08.08, 23.060, 24.007, 24.008
- 5399: - / Impacted TSs and TRs: 05.10
- 5400: - / Impacted TSs and TRs: 03.55, 03.64, 04.18, 05.01, 05.02, 05.08, 24.008

| ID | WBS | Task | Duration | Start | Finish | Complete | Baseline start | Baseline finish | Baseline duration | Constraint | Resources | Work | Actual work | Acronym | Release | MCC resp | Acronym_3GU_Export | TSG stopped | WI rapporteur name | WI rapporteur e-mail |
| --- | --- | --- | --- | --- | --- | --- | --- | --- | --- | --- | --- | --- | --- | --- | --- | --- | --- | --- | --- | --- |
| 5401 | 1271.2 | **General Packet Radio Service enahancements** | 261d? | 1999-01-01 A | 1999-12-31 A | 100% | 1999-01-01 | 1999-12-31 | 261d? |  | S1; S2; SMG1; SMG2; SMG7; N1; N2; N3; N4; T2 | 50112h | 50112h | GPRSenhancements | R99 | Alain | GPRS enhancements |  |  |  |
| 5402 | 1271.2.1 | General Packet Radio Service | 261d? | 1999-01-01 A | 1999-12-31 A | 100% | 1999-01-01 | 1999-12-31 | 261d? | start no earlier than 1999-01-01 | S1; S2; SMG1; SMG2; SMG7; N1; N2; N3; N4; T2 | 20880h | 20880h | GPRS | R99 | Alain | GPRS |  |  |  |
| 5403 | 1271.2.2 | GPRS2 | 261d? | 1999-01-01 A | 1999-12-31 A | 100% | 1999-01-01 | 1999-12-31 | 261d? | start no earlier than 1999-01-01 | SMG1; N2 | 4176h | 4176h | GPRS2 | R99 |  | GPRS2 |  |  |  |
| 5404 | 1271.2.3 | GPRS Tunnelling Protocol enhancement | 261d? | 1999-01-01 A | 1999-12-31 A | 100% | 1999-01-01 | 1999-12-31 | 261d? | start no earlier than 1999-01-01 | N4; N2 | 4176h | 4176h | GTP_enhancement | R99 | Kimmo | GTP_enhancement |  |  |  |
| 5405 | 1271.3 | **Enhanced Data rates for GSM Evolution - Phase 1** | 261d? | 1999-01-01 A | 1999-12-31 A | 100% | 1999-01-01 | 1999-12-31 | 261d? |  | SMG2; SMG1; SMG3; SMG4; SMG7; SMG9; SMG10; N1; N3; T2 | 73080h | 73080h | EDGE-Phase1 | R99 | Maurice | EDGE - Phase 1 |  |  |  |
| 5406 | 1271.3.1 | Enhanced Data rates for GSM Evolution | 261d? | 1999-01-01 A | 1999-12-31 A | 100% | 1999-01-01 | 1999-12-31 | 261d? | start no earlier than 1999-01-01 | SMG2; SMG1; SMG3; SMG4; SMG7; SMG9; SMG10; N1; N3; T2 | 20880h | 20880h | EDGE | R99 | Maurice | EDGE |  |  |  |
| 5407 | 1271.3.2 | EDGE-Layer1 | 261d? | 1999-01-01 A | 1999-12-31 A | 100% | 1999-01-01 | 1999-12-31 | 261d? | start no earlier than 1999-01-01 | SMG2 | 2088h | 2088h | EDGE-Layer1 | R99 |  | EDGE-Layer1 |  |  |  |
| 5408 | 1271.3.3 | High Speed Circuit Switched Data | 261d? | 1999-01-01 A | 1999-12-31 A | 100% | 1999-01-01 | 1999-12-31 | 261d? | start no earlier than 1999-01-01 | SMG1; SMG2; SMG7 | 6264h | 6264h | HSCSD | R99 |  | HSCSD |  |  |  |
| 5409 | 1271.3.4 | Enhanced Circuit Switched Data - Phase 1 | 261d? | 1999-01-01 A | 1999-12-31 A | 100% | 1999-01-01 | 1999-12-31 | 261d? | start no earlier than 1999-01-01 | S1; SMG | 4176h | 4176h | ECSD | R99 | Alain | ECSD |  |  |  |
| 5410 | 1271.3.5 | EDGE-Enhanced Circuit Switched Data | 261d? | 1999-01-01 A | 1999-12-31 A | 100% | 1999-01-01 | 1999-12-31 | 261d? | start no earlier than 1999-01-01 | SMG2 | 2088h | 2088h | EDGE-ECSD | R99 |  | EDGE-ECSD |  |  |  |
| 5411 | 1271.3.6 | Enhanced GPRS - Phase 1 | 261d? | 1999-01-01 A | 1999-12-31 A | 100% | 1999-01-01 | 1999-12-31 | 261d? | start no earlier than 1999-01-01 | SMG; N1 | 4176h | 4176h | EGPRS | R99 |  | EGPRS |  |  |  |
| 5412 | 1271.3.7 | EDGE-EGPRS | 261d? | 1999-01-01 A | 1999-12-31 A | 100% | 1999-01-01 | 1999-12-31 | 261d? | start no earlier than 1999-01-01 | SMG2 | 2088h | 2088h | EDGE-EGPRS | R99 |  | EDGE-EGPRS |  |  |  |
| 5413 | 1271.3.8 | Packet Flow Context (PFC) | 261d? | 1999-01-01 A | 1999-12-31 A | 100% | 1999-01-01 | 1999-12-31 | 261d? | start no earlier than 1999-01-01 | SMG2 | 2088h | 2088h | PFC | R99 |  | PFC |  |  |  |
| 5414 | 1271.3.9 | Support for EGPRS in ANSI-136 networks and EDGE COMPACT | 261d? | 1999-01-01 A | 1999-12-31 A | 100% | 1999-01-01 | 1999-12-31 | 261d? | start no earlier than 1999-01-01 | SMG | 2088h | 2088h | EDGE-Compact | R99 |  | EDGE-Compact |  |  |  |
| 5415 | 1271.3.10 | EGPRS COMPACT | 261d? | 1999-01-01 A | 1999-12-31 A | 100% | 1999-01-01 | 1999-12-31 | 261d? | start no earlier than 1999-01-01 | SMG | 2088h | 2088h | EGPRS-Compact | R99 |  | EGPRS-Compact |  |  |  |
| 5416 | 1271.3.11 | COMPACT | 261d? | 1999-01-01 A | 1999-12-31 A | 100% | 1999-01-01 | 1999-12-31 | 261d? | start no earlier than 1999-01-01 | SMG; N1 | 4176h | 4176h | COMPACT | R99 |  | COMPACT |  |  |  |
| 5417 | 1271.4 | GSM_400 | 261d? | 1999-01-01 A | 1999-12-31 A | 100% | 1999-01-01 | 1999-12-31 | 261d? | start no earlier than 1999-01-01 | SMG2; SMG7; T2 | 6264h | 6264h | GSM_400 | R99 | Paolo | GSM_400 |  |  |  |
| 5418 | 1271.5 | GSM_450 | 261d? | 1999-01-01 A | 1999-12-31 A | 100% | 1999-01-01 | 1999-12-31 | 261d? | start no earlier than 1999-01-01 | SMG2 | 2088h | 2088h | GSM_450 | R99 |  | GSM_450 |  |  |  |
| 5419 | 1271.6 | GSM_700 | 261d? | 1999-01-01 A | 1999-12-31 A | 100% | 1999-01-01 | 1999-12-31 | 261d? | start no earlier than 1999-01-01 | SMG2 | 2088h | 2088h | GSM_700 | R99 |  | GSM_700 |  |  |  |
| 5420 | 1271.7 | Deleted - GERAN | 261d? | 1999-01-01 A | 1999-12-31 A | 100% | 1999-01-01 | 1999-12-31 | 261d? | start no earlier than 1999-01-01 | SMG2; S2 | 4176h | 4176h | GERAN | R99 | Maurice | GERAN | SP-06 |  |  |
| 5421 | 1272 | **GSM Features transposed to UMTS** | 261d? | 1999-01-01 A | 1999-12-31 A | 100% | 1999-01-01 | 1999-12-31 | 261d? |  | S1; S3; T2; N2; N4 | 31320h | 31320h |  | R99 | Alain |  |  |  |  |
| 5422 | 1272.1 | Cell Broadcast Service | 261d? | 1999-01-01 A | 1999-12-31 A | 100% | 1999-01-01 | 1999-12-31 | 261d? | start no earlier than 1999-01-01 | T2 | 2088h | 2088h | CBS | R99 |  | CBS |  |  |  |
| 5423 | 1272.2 | **GSM mobile number portability euro MNP / North American MNP** | 261d? | 1999-01-01 A | 1999-12-31 A | 100% | 1999-01-01 | 1999-12-31 | 261d? |  | S1; N2; N4 | 10440h | 10440h | MNP | R99 | Alain | MNP |  |  |  |
| 5424 | 1272.2.1 | Mobile Number Portability | 261d? | 1999-01-01 A | 1999-12-31 A | 100% | 1999-01-01 | 1999-12-31 | 261d? | start no earlier than 1999-01-01 | N2; N4 | 4176h | 4176h |  | R99 | Kimmo |  |  |  |  |
| 5425 | 1272.3 | Automatic establishment of roaming relations | 261d? | 1999-01-01 A | 1999-12-31 A | 100% | 1999-01-01 | 1999-12-31 | 261d? | start no earlier than 1999-01-01 | S1 | 2088h | 2088h |  | R99 | Alain |  |  | Telecom Italia | enrico.scarrone@telecomitalia.it |
| 5426 | 1272.4 | Advanced addressing | 261d? | 1999-01-01 A | 1999-12-31 A | 100% | 1999-01-01 | 1999-12-31 | 261d? | start no earlier than 1999-01-01 | S1 | 2088h | 2088h |  | R99 | Alain |  |  |  |  |
| 5427 | 1272.5 | UMTS numbering, addressing and identities | 261d? | 1999-01-01 A | 1999-12-31 A | 100% | 1999-01-01 | 1999-12-31 | 261d? | start no earlier than 1999-01-01 | S1 | 2088h | 2088h |  | R99 | Alain |  |  |  |  |
| 5428 | 1272.6 | Lawful Interception for GSM Features transposed to UMTS | 261d? | 1999-01-01 A | 1999-12-31 A | 100% | 1999-01-01 | 1999-12-31 | 261d? | start no earlier than 1999-01-01 | S3 | 2088h | 2088h | LI | R99 | Mirko | LI |  |  |  |

Notes:
- 5401: GPRS was introduced in Release 97. Release 99 brings a number of essential corrections e.g. on Downlink Power Control, Timing Advance procedure, Cell reselection delay time, PBCCH scheduling, PTCCH mapping, etc. / Impacted TSs and TRs: 05.02, 05.05, 05.08, 05.10, 05.50, 11.21, 23.064, 24.008, 24.060
- 5402: - / Impacted TSs and TRs: 02.60, 03.22, 03.64, 04.18, 04.60, 04.64, 04.65, 05.01, 05.02, 05.05, 05.08, 05.10, 08.08, 08.18, 11.10-1, 11.21, 22.041, 22.060, 23.003, 23.007, 23.060, 23.107, 23.122, 24.007, 24.008, 27.007, 27.060, 29.002, 29.016, 29.018, 29.060, 29.061
- 5403: Introduction of EGPRS (S1) + Introduction of Reserved Service Labels in the APN (N2) / Impacted TSs and TRs: 02.60, 23.003
- 5404: - / Impacted TSs and TRs: 23.003, 23.008, 29.060
- 5405: EDGE is independent of the frequency bands, so it can be deployed e.g. in 900 and 1900 MHz bands. The new physical layer based on 8-PSK modulation is introduced and EGPRS and ECSD facilitate the new modulation in single and multi slot constellation. / Impacted TSs and TRs: 10.59, 02.34, 02.60, 03.30, 05.10, 05.50, 11.26
- 5406: WID in SMG2 331/97, SMG 1147/97, SMG 1148/97 / Impacted TSs and TRs: 02.34, 03.10, 03.20, 03.64, 04.03, 04.04, 04.06, 04.08, 04.18, 04.21, 04.22, 04.60, 04.64, 05.01, 05.02, 05.03, 05.04, 05.05, 05.08, 05.10, 05.50, 07.01, 07.02, 07.03, 08.08, 08.20, 08.58, 08.60, 09.07, 09.18, 11.10-1, 11.11, 11.21, 11.26, 23.034, 24.008,
- 5407: WID in SMG2 331/97, SMG 1147/97, SMG 1148/97 / Impacted TSs and TRs: 05.05, 05.10, 05.50
- 5408: No additional features for R99. / Impacted TSs and TRs: 02.34, 04.18, 11.10-1
- 5409: ECSD supports both transparent and non-transparent services, up to 64 kbit/s and 57.6 kbit/s respectively. See Tdoc SMG2 670/99 ECSD Concept Evaluation for more info / Impacted TSs and TRs: 05.02, 08.58, 22.034
- 5410: - / Impacted TSs and TRs: 05.03
- 5411: - / Impacted TSs and TRs: 02.07, 03.64, 04.14, 04.18, 04.60, 05.05, 05.08, 24.008
- 5412: - / Impacted TSs and TRs: 05.03, 05.05, 05.08
- 5413: - / Impacted TSs and TRs: 04.18
- 5414: Support for EGPRS in ANSI-136 networks and EDGE Compact (for ANSI-136 networks only). COMPACT = Deployment of servicES in CP-150spectrum below 1 MHz / Impacted TSs and TRs: 03.22, 03.30, 03.64, 05.01, 05.02, 05.03, 05.05, 05.08, 05.10
- 5415: COMPACT = Deployment of servicES in CP-150spectrum below 1 MHz / Impacted TSs and TRs: 04.18, 05.02
- 5416: COMPACT = Deployment of servicES in CP-150spectrum below 1 MHz / Impacted TSs and TRs: 03.22, 04.18, 04.60, 05.08, 23.122, 24.008
- 5417: GSM in the 400 MHz bands allows to deploy GSM within frequency bands in the range 450 to 500 MHz, previously used for analogue cellular systems. See Tdoc SMG2 190/99 and 595/99 for further info. / Impacted TSs and TRs: 02.17, 03.22, 03.30, 04.04, 04.18, 04.60, 05.01, 05.02, 05.05, 05.08, 05.10, 05.50, 08.18, 08.58, 11.21, 24.008, 27.007
- 5418: - / Impacted TSs and TRs: 03.22, 03.30, 05.01, 05.05, 05.08
- 5419: - / Impacted TSs and TRs: 05.05
- 5420: No CR or new TS/TR approved under this WI / Impacted TSs and TRs: G2: 04.18 CR#A248 , 04.60 CR#B090
- 5421: -
- 5422: Moved to CT1 at TSG-T closure. Applicability of the Cell Broadcast Service (as defined for GSM network) to 3G networks / Impacted TSs and TRs: 23.041
- 5423: R98 MNP: mobile subscriber ability to change PLMN operator within the same country whilst retaining its original MS ISDN number (MSISDN). IMSI is changed, only MSISDN is kept. R99 adds requirements for North American Service Provider Number Portability. / Impacted TSs and TRs: 22.066
- 5424: - / Impacted TSs and TRs: 23.018, 23.066, 29.002
- 5425: framework for commercial and technical interworking between UMTS Home Environments and Serving Networks who have no direct prior commercial agreements with each other. / Impacted TSs and TRs: 22.101, 22.971
- 5426: - / Impacted TSs and TRs: 22.101, 22.75U, 22.975
- 5427: Also new requirements for Single and Multiple Numbering scheme was added (CR#20 and 21). Deleted the term International Mobile User Identifier (IMUI) and changed IMSI (International Mobile Station Identifier=>International Mobile Subscriber Identity. / Impacted TSs and TRs: 22.101
- 5428: Defines an interception system in UMTS that supports a number of regional interception regulations. Regional interception requirements shall be met in using specific (regional) mediation functions allowing only required information to be transported. / Impacted TSs and TRs: New 33.106, 33.107

| ID | WBS | Task | Duration | Start | Finish | Complete | Baseline start | Baseline finish | Baseline duration | Constraint | Resources | Work | Actual work | Release | MCC resp | Acronym | Acronym_3GU_Export | TSG stopped |
| --- | --- | --- | --- | --- | --- | --- | --- | --- | --- | --- | --- | --- | --- | --- | --- | --- | --- | --- |
| 5429 | 1273 | **Charging** | 261d? | 1999-01-01 A | 1999-12-31 A | 100% | 1999-01-01 | 1999-12-31 | 261d? |  | S1; S5 | 8352h | 8352h | R99 | Alain |  |  |  |
| 5430 | 1273.1 | R99 Charging | 261d? | 1999-01-01 A | 1999-12-31 A | 100% | 1999-01-01 | 1999-12-31 | 261d? | start no earlier than 1999-01-01 | S1 | 2088h | 2088h | R99 | Alain | Charging | Charging |  |
| 5431 | 1273.2 | R99 OAM Charging Management | 261d? | 1999-01-01 A | 1999-12-31 A | 100% | 1999-01-01 | 1999-12-31 | 261d? | start no earlier than 1999-01-01 | S5 | 2088h | 2088h | R99 | Mirko | OAMCH,CH | OAMCH, CH |  |
| 5432 | 1274 | **Operations, Administration, Maintenance and Provisioning (OAM&P)** | 261d? | 1999-01-01 A | 1999-12-31 A | 100% | 1999-01-01 | 1999-12-31 | 261d? |  | S5 | 12528h | 12528h | R99 | Mirko | OAM1999 | OAM1999 |  |
| 5433 | 1274.1 | OAM Principles and High-level Requirements | 261d? | 1999-01-01 A | 1999-12-31 A | 100% | 1999-01-01 | 1999-12-31 | 261d? | start no earlier than 1999-01-01 | S5 | 2088h | 2088h | R99 | Mirko | PR,Princs_&_Reqs_(PR) | PR, Princs_&_Reqs_(PR) |  |
| 5434 | 1274.2 | OAM Architecture | 261d? | 1999-01-01 A | 1999-12-31 A | 100% | 1999-01-01 | 1999-12-31 | 261d? | start no earlier than 1999-01-01 | S5 | 2088h | 2088h | R99 | Mirko | OAMAR,AR,Telecom_Management_Arch_(AR) | OAMAR, AR, Telecom_Management_Arch_(AR) |  |
| 5435 | 1274.3 | OAM Configuration Management | 261d? | 1999-01-01 A | 1999-12-31 A | 100% | 1999-01-01 | 1999-12-31 | 261d? | start no earlier than 1999-01-01 | S5 | 2088h | 2088h | R99 | Mirko | OAMCM,CM | OAMCM, CM |  |
| 5436 | 1274.4 | OAM Fault Management | 261d? | 1999-01-01 A | 1999-12-31 A | 100% | 1999-01-01 | 1999-12-31 | 261d? | start no earlier than 1999-01-01 | S5 | 2088h | 2088h | R99 | Mirko | OAMFM | OAMFM |  |
| 5437 | 1274.5 | OAM Performance Management | 261d? | 1999-01-01 A | 1999-12-31 A | 100% | 1999-01-01 | 1999-12-31 | 261d? | start no earlier than 1999-01-01 | S5 | 2088h | 2088h | R99 | Mirko | OAMPM,PM | OAMPM, PM |  |
| 5438 | 1275 | Vocabulary | 261d? | 1999-01-01 A | 1999-12-31 A | 100% | 1999-01-01 | 1999-12-31 | 261d? | start no earlier than 1999-01-01 | S1 | 2088h | 2088h | R99 | Alain | Vocabulary | Vocabulary |  |
| 5439 | 1276 | Emergency | 261d? | 1999-01-01 A | 1999-12-31 A | 100% | 1999-01-01 | 1999-12-31 | 261d? | start no earlier than 1999-01-01 | S1 | 2088h | 2088h | R99 | Alain | Emergency | Emergency |  |
| 5440 | 1277 | GSM General Bearer Services (GBS) and interworking scenarios support in UMTS | 261d? | 1999-01-01 A | 1999-12-31 A | 100% | 1999-01-01 | 1999-12-31 | 261d? | start no earlier than 1999-01-01 | S1 | 2088h | 2088h | R99 | Alain | GSM_to_UMTS_Evol | GSM_to_UMTS_Evol |  |
| 5441 | 1278 | GPRS_Mobile_IP_interworking | 261d? | 1999-01-01 A | 1999-12-31 A | 100% | 1999-01-01 | 1999-12-31 | 261d? | start no earlier than 1999-01-01 | N3 | 2088h | 2088h | R99 |  | GPRS_Mobile_IP_interworking | GPRS_Mobile_IP_interworking |  |
| 5442 | 1279 | GSM/UMTS interworking | 261d? | 1999-01-01 A | 1999-12-31 A | 100% | 1999-01-01 | 1999-12-31 | 261d? | start no earlier than 1999-01-01 | N1; N2; N4; R3; S1; SMG | 12528h | 12528h | R99 | Frederic | 2G3Ginterworking | 2G3Ginterworking |  |
| 5443 | 1280 | Handover | 261d? | 1999-01-01 A | 1999-12-31 A | 100% | 1999-01-01 | 1999-12-31 | 261d? | start no earlier than 1999-01-01 | S1; SMG2; N1; N2; N4 | 10440h | 10440h | R99 | Alain | Handover | Handover |  |
| 5444 | 1281 | 2G3Ghandover | 261d? | 1999-01-01 A | 1999-12-31 A | 100% | 1999-01-01 | 1999-12-31 | 261d? | start no earlier than 1999-01-01 | SMG2 | 2088h | 2088h | R99 |  | 2G3Ghandover | 2G3Ghandover |  |
| 5445 | 1282 | Service Provider Name Indication | 261d? | 1999-01-01 A | 1999-12-31 A | 100% | 1999-01-01 | 1999-12-31 | 261d? | start no earlier than 1999-01-01 | S1 | 2088h | 2088h | R99 | Alain | SPANME | SPANME |  |
| 5446 | 1283 | Data & Data_CleanUp | 261d? | 1999-01-01 A | 1999-12-31 A | 100% | 1999-01-01 | 1999-12-31 | 261d? | start no earlier than 1999-01-01 | SMG1 | 2088h | 2088h | R99 |  | Data,Data_CleanUp | Data, Data_CleanUp |  |
| 5447 | 1284 | Unstructured Supplementary Service Data (USSD) | 261d? | 1999-01-01 A | 1999-12-31 A | 100% | 1999-01-01 | 1999-12-31 | 261d? | start no earlier than 1999-01-01 | SMG1; N4 | 4176h | 4176h | R99 | Kimmo | USSD | USSD |  |
| 5448 | 1285 | Man-Machine Interface (MMI) of the User Equipment (UE) | 261d? | 1999-01-01 A | 1999-12-31 A | 100% | 1999-01-01 | 1999-12-31 | 261d? | start no earlier than 1999-01-01 | S1 | 2088h | 2088h | R99 | Alain | MMI | MMI |  |
| 5449 | 1286 | Network Identity and Timezone (NITZ) | 261d? | 1999-01-01 A | 1999-12-31 A | 100% | 1999-01-01 | 1999-12-31 | 261d? | start no earlier than 1999-01-01 | SMG1; SMG3 | 4176h | 4176h | R99 | Alain | NITZ | NITZ |  |
| 5450 | 1287 | Deleted - Operator Determined Barring for Packet Oriented Services | 261d? | 1999-01-01 A | 1999-12-31 A | 100% | 1999-01-01 | 1999-12-31 | 261d? | start no earlier than 1999-01-01 | S1 | 2088h | 2088h | R99 | Alain | ODB_Enh. | ODB_Enh. | SP-69 |
| 5451 | 1288 | Packet Flow Management | 261d? | 1999-01-01 A | 1999-12-31 A | 100% | 1999-01-01 | 1999-12-31 | 261d? | start no earlier than 1999-01-01 | SMG2 | 2088h | 2088h | R99 |  | Packet_Flow_Management | Packet_Flow_Management |  |
| 5452 | 1289 | GPRS_Point-To-Multipoint Group call | 261d? | 1999-01-01 A | 1999-12-31 A | 100% | 1999-01-01 | 1999-12-31 | 261d? | start no earlier than 1999-01-01 | SMG1 | 2088h | 2088h | R99 |  | GPRS_PTMG | GPRS_PTMG |  |

Notes:
- 5429: -
- 5430: - / Impacted TSs and TRs: 22.115, 23.121
- 5431: - / Impacted TSs and TRs: 32.005, 32.015
- 5432: -
- 5433: - / Impacted TSs and TRs: 32.101
- 5434: - / Impacted TSs and TRs: 32.101, 32.102
- 5435: - / Impacted TSs and TRs: 32.106, 32.106-1, 32.106-2, 32.106-3, 32.106-4, 32.106-5, 32.106-6, 32.106-7, 32.106-8
- 5436: - / Impacted TSs and TRs: 32.111, 32.111-1, 32.111-2, 32.111-3, 32.111-4
- 5437: - / Impacted TSs and TRs: 12.04, 32.104
- 5438: - / Impacted TSs and TRs: 21.905
- 5439: - / Impacted TSs and TRs: 22.101
- 5440: UMTS shall support GSM General Bearer Services (GBS) and interworking scenarios as specified in 02.02 / Impacted TSs and TRs: 22.105
- 5441: - / Impacted TSs and TRs: 29.061
- 5442: - / Impacted TSs and TRs: 03.22, 04.18, 04.60, 05.02, 05.08, 05.10, 08.08, 08.18, 08.58, 09.08, 22.011, 23.003, 23.009, 23.014, 23.034, 23.122, 24.007, 24.008, 24.011, 24.080, 29.108
- 5443: - / Impacted TSs and TRs: 04.18, 08.08, 08.58, 22.129, 23.009, 29.002, 29.010
- 5444: - / Impacted TSs and TRs: 04.18, 04.60, 05.02, 05.08, 05.10, 08.08, 29.010
- 5445: Service Provider Name Indication included in R98 (02.07) was not carried into R99 (22.101), but is in the SIM/USIM specification for R99 / Impacted TSs and TRs: 22.101
- 5446: - / Impacted TSs and TRs: 02.01, 02.02, 02.04, 02.34
- 5447: No additional features for R99. / Impacted TSs and TRs: 02.04, 02.90, 23.090, 29.002
- 5448: Data services streamlining + Support for Anonymous Call Rejection / Impacted TSs and TRs: 22.030
- 5449: - / Impacted TSs and TRs: 02.42, 04.08
- 5450: Remove ODB for Packet Oriented Services from R99 / Impacted TSs and TRs: 22.041
- 5451: - / Impacted TSs and TRs: 08.18
- 5452: - / Impacted TSs and TRs: 02.60

| ID | WBS | Task | Duration | Start | Finish | Complete | Baseline start | Baseline finish | Baseline duration | Constraint | Resources | Work | Actual work | Release | MCC resp | Acronym | Acronym_3GU_Export |
| --- | --- | --- | --- | --- | --- | --- | --- | --- | --- | --- | --- | --- | --- | --- | --- | --- | --- |
| 5453 | 1290 | **Call Forwarding** | 261d? | 1999-01-01 A | 1999-12-31 A | 100% | 1999-01-01 | 1999-12-31 | 261d? |  | SMG1; N2; N4 | 16704h | 16704h | R99 | Kimmo |  |  |
| 5454 | 1290.1 | Call Forwarding enhancements | 261d? | 1999-01-01 A | 1999-12-31 A | 100% | 1999-01-01 | 1999-12-31 | 261d? | start no earlier than 1999-01-01 | N4; N2 | 4176h | 4176h | R99 | Kimmo | CF_enhancements | CF_enhancements |
| 5455 | 1290.2 | Call_Forwarding | 261d? | 1999-01-01 A | 1999-12-31 A | 100% | 1999-01-01 | 1999-12-31 | 261d? | start no earlier than 1999-01-01 | SMG1; N2 | 4176h | 4176h | R99 | Kimmo | Call_Forwarding | Call_Forwarding |
| 5456 | 1290.3 | Call_Forwarding_Enhancements | 261d? | 1999-01-01 A | 1999-12-31 A | 100% | 1999-01-01 | 1999-12-31 | 261d? | start no earlier than 1999-01-01 | N4 | 2088h | 2088h | R99 | Kimmo | Call_Forwarding_Enhancements | Call_Forwarding_Enhancements |
| 5457 | 1291 | **Quality of Service** | 261d? | 1999-01-01 A | 1999-12-31 A | 100% | 1999-01-01 | 1999-12-31 | 261d? |  | S2; T2; N1; N2; N4 | 31320h | 31320h | R99 | Maurice |  |  |
| 5458 | 1291.1 | End-to-end UMTS Quality of Service management | 261d? | 1999-01-01 A | 1999-12-31 A | 100% | 1999-01-01 | 1999-12-31 | 261d? | start no earlier than 1999-01-01 | S2; T2; N1; N2; N4 | 10440h | 10440h | R99 | Maurice | QoS | QoS |
| 5459 | 1291.2 | End-to-end QoS for PS Domain including IMS | 261d? | 1999-01-01 A | 1999-12-31 A | 100% | 1999-01-01 | 1999-12-31 | 261d? | start no earlier than 1999-01-01 | S2 | 2088h | 2088h | R99 | Maurice | E2EQoS99 | E2EQoS |
| 5460 | 1291.3 | GPRS-enhanced_QoS | 261d? | 1999-01-01 A | 1999-12-31 A | 100% | 1999-01-01 | 1999-12-31 | 261d? | start no earlier than 1999-01-01 | T2 | 2088h | 2088h | R99 |  | GPRS-enhanced_QoS | GPRS-enhanced_QoS |
| 5461 | 1291.4 | QoS_enhancements | 261d? | 1999-01-01 A | 1999-12-31 A | 100% | 1999-01-01 | 1999-12-31 | 261d? | start no earlier than 1999-01-01 | N2; N1; N4 | 6264h | 6264h | R99 | Kimmo | QoS_enhancements | QoS_enhancements |
| 5462 | 1292 | Support of Localised Service Area | 261d? | 1999-01-01 A | 1999-12-31 A | 100% | 1999-01-01 | 1999-12-31 | 261d? | start no earlier than 1999-01-01 | SMG2; SMG3; SMG7; N2 | 8352h | 8352h | R99 | Maurice | SoLSA | SoLSA |
| 5463 | 1293 | Transcoder_location | 261d? | 1999-01-01 A | 1999-12-31 A | 100% | 1999-01-01 | 1999-12-31 | 261d? | start no earlier than 1999-01-01 | S2 | 2088h | 2088h | R99 | Maurice | Transcoder_location | Transcoder_location |
| 5464 | 1294 | Antenna_test_methods | 261d? | 1999-01-01 A | 1999-12-31 A | 100% | 1999-01-01 | 1999-12-31 | 261d? | start no earlier than 1999-01-01 | SMG2 | 2088h | 2088h | R99 |  | Antenna_test_methods | Antenna_test_methods |
| 5465 | 1295 | WBAMR / high quality speech in UMTS Phase 1 but not in R99 | 261d? | 1999-01-01 A | 1999-12-31 A | 100% | 1999-01-01 | 1999-12-31 | 261d? | start no earlier than 1999-01-01 | S1 | 2088h | 2088h | R99 | Alain | WBAMR | WBAMR |
| 5466 | 1296 | **Codec** | 261d? | 1999-01-01 A | 1999-12-31 A | 100% | 1999-01-01 | 1999-12-31 | 261d? |  | S4 | 27144h | 27144h | R99 | Paolo |  |  |
| 5467 | 1296.1 | **Codecs for Multimedia Telephony Service** | 261d? | 1999-01-01 A | 1999-12-31 A | 100% | 1999-01-01 | 1999-12-31 | 261d? |  | S4 | 14616h | 14616h | R99 | Paolo | Codec_for_Multimedia_Telephony | Codec_for_Multimedia_Telephony |
| 5468 | 1296.1.1 | Codecs for Multimedia Telephony Service | 261d? | 1999-01-01 A | 1999-12-31 A | 100% | 1999-01-01 | 1999-12-31 | 261d? | start no earlier than 1999-01-01 | S4 | 2088h | 2088h | R99 | Paolo | Multimedia_Codec | Multimedia_Codec |
| 5469 | 1296.1.2 | Codecs for Multimedia Telephony Service | 261d? | 1999-01-01 A | 1999-12-31 A | 100% | 1999-01-01 | 1999-12-31 | 261d? | start no earlier than 1999-01-01 | S4 | 2088h | 2088h | R99 | Paolo | CSM | CSM |
| 5470 | 1296.1.3 | Codecs for Multimedia Telephony Service | 261d? | 1999-01-01 A | 1999-12-31 A | 100% | 1999-01-01 | 1999-12-31 | 261d? | start no earlier than 1999-01-01 | S4 | 2088h | 2088h | R99 | Paolo | WI2MMC | WI2MMC |
| 5471 | 1296.1.4 | Codecs for Multimedia Telephony Service | 261d? | 1999-01-01 A | 1999-12-31 A | 100% | 1999-01-01 | 1999-12-31 | 261d? | start no earlier than 1999-01-01 | S4 | 2088h | 2088h | R99 | Paolo | Codec(s)_for_CS_MM_Tel._Serv | Codec(s)_for_CS_MM_Tel._Serv |
| 5472 | 1296.1.5 | Codecs for Multimedia Telephony Service | 261d? | 1999-01-01 A | 1999-12-31 A | 100% | 1999-01-01 | 1999-12-31 | 261d? | start no earlier than 1999-01-01 | S4 | 2088h | 2088h | R99 | Paolo | Codec(s)_for_MM_Tel_Service | Codec(s)_for_MM_Tel_Service |
| 5473 | 1296.1.6 | Codecs for Multimedia Telephony Service | 261d? | 1999-01-01 A | 1999-12-31 A | 100% | 1999-01-01 | 1999-12-31 | 261d? | start no earlier than 1999-01-01 | S4 | 2088h | 2088h | R99 | Paolo |  |  |
| 5474 | 1296.2 | QoS for Speech and Multimedia Codec | 261d? | 1999-01-01 A | 1999-12-31 A | 100% | 1999-01-01 | 1999-12-31 | 261d? | start no earlier than 1999-01-01 | S4 | 2088h | 2088h | R99 | Paolo | QoS_for_Speech_&_MM_Codecs_/_AMR | QoS_for_Speech_&_MM_Codecs_/_AMR |
| 5475 | 1296.3 | Tandem Free Operation - Adaptive Multi-Rate codec types | 261d? | 1999-01-01 A | 1999-12-31 A | 100% | 1999-01-01 | 1999-12-31 | 261d? | start no earlier than 1999-01-01 | S4 | 2088h | 2088h | R99 | Paolo | TFOAMR | TFOAMR |
| 5476 | 1296.4 | Noise Suppression for AMR | 261d? | 1999-01-01 A | 1999-12-31 A | 100% | 1999-01-01 | 1999-12-31 | 261d? | start no earlier than 1999-01-01 | S4 | 2088h | 2088h | R99 | Paolo | AMRNS | AMRNS |
| 5477 | 1296.5 | Out-of-Band Transcoder | 261d? | 1999-01-01 A | 1999-12-31 A | 100% | 1999-01-01 | 1999-12-31 | 261d? | start no earlier than 1999-01-01 | N1 | 2088h | 2088h | R99 | Frederic | OoBT | OoBT |
| 5478 | 1296.6 | Out-of-Band Transcoder Control | 261d? | 1999-01-01 A | 1999-12-31 A | 100% | 1999-01-01 | 1999-12-31 | 261d? | start no earlier than 1999-01-01 | N1 | 2088h | 2088h | R99 | Frederic | OoBTC | OoBTC |
| 5479 | 1297 | Advanced Speech Call Items enhancements | 261d? | 1999-01-01 A | 1999-12-31 A | 100% | 1999-01-01 | 1999-12-31 | 261d? | start no earlier than 1999-01-01 | SMG1; SMG2; SMG3; SMG7; SMG9; N1; N4; S1; T2 | 18792h | 18792h | R99 | Alain | ASCI | ASCI |
| 5480 | 1298 | Call Control improvements | 261d? | 1999-01-01 A | 1999-12-31 A | 100% | 1999-01-01 | 1999-12-31 | 261d? | start no earlier than 1999-01-01 | N1 | 2088h | 2088h | R99 | Frederic | CC_Related_items | CC_Related_items |
| 5481 | 1299 | Multimedia | 261d? | 1999-01-01 A | 1999-12-31 A | 100% | 1999-01-01 | 1999-12-31 | 261d? | start no earlier than 1999-01-01 | N1; N3 | 4176h | 4176h | R99 | Frederic | Multimedia | Multimedia |
| 5482 | 1300 | Sub-System Number allocation for RANAP, RNSAP | 261d? | 1999-01-01 A | 1999-12-31 A | 100% | 1999-01-01 | 1999-12-31 | 261d? | start no earlier than 1999-01-01 | N2 | 2088h | 2088h | R99 | Frederic | SSN_allocation | SSN_allocation |
| 5483 | 1301 | Intranet / ISP access with DHCP end-to-end | 261d? | 1999-01-01 A | 1999-12-31 A | 100% | 1999-01-01 | 1999-12-31 | 261d? | start no earlier than 1999-01-01 | N3 | 2088h | 2088h | R99 | Gwiho | ISPaccess | ISPaccess |
| 5484 | 1302 | Point_to_Multipoint_Services | 261d? | 1999-01-01 A | 1999-12-31 A | 100% | 1999-01-01 | 1999-12-31 | 261d? | start no earlier than 1999-01-01 | N3 | 2088h | 2088h | R99 | Gwiho | Point_to_Multipoint_Services | Point_to_Multipoint_Services |
| 5485 | 1303 | Facsimile | 261d? | 1999-01-01 A | 1999-12-31 A | 100% | 1999-01-01 | 1999-12-31 | 261d? | start no earlier than 1999-01-01 | S1 | 2088h | 2088h | R99 | Alain | FAX | FAX |
| 5486 | 1304 | Realtime_NT_FAX_in_UMTS | 261d? | 1999-01-01 A | 1999-12-31 A | 100% | 1999-01-01 | 1999-12-31 | 261d? | start no earlier than 1999-01-01 | N3 | 2088h | 2088h | R99 | Gwiho | Realtime_NT_FAX_in_UMTS | Realtime_NT_FAX_in_UMTS |
| 5487 | 1305 | Gateway Location Register (GLR) - Mobile Application Part (MAP) specification | 261d? | 1999-01-01 A | 1999-12-31 A | 100% | 1999-01-01 | 1999-12-31 | 261d? | start no earlier than 1999-01-01 | N4 | 2088h | 2088h | R99 | Kimmo | GLR | GLR |
| 5488 | 1306 | Multiple Subscriber Profile phase 2 | 261d? | 1999-01-01 A | 1999-12-31 A | 100% | 1999-01-01 | 1999-12-31 | 261d? | start no earlier than 1999-01-01 | S1; N4 | 4176h | 4176h | R99 | Alain | MSP2 | MSP2 |
| 5489 | 1307 | Prepaging | 261d? | 1999-01-01 A | 1999-12-31 A | 100% | 1999-01-01 | 1999-12-31 | 261d? | start no earlier than 1999-01-01 | N2; N4 | 4176h | 4176h | R99 | Kimmo | Prepaging | Prepaging |
| 5490 | 1308 | Re-definition of channel quality measure used for AMR link adaptation for Downlink Advanced Receiver Performance (DARP) MS | 261d? | 1999-01-01 A | 1999-12-31 A | 100% | 1999-01-01 | 1999-12-31 | 261d? | start no earlier than 1999-01-01 | SMG | 2088h | 2088h | R99 |  |  |  |
| 5491 | 1309 | Harmonized Standard | 261d? | 1999-01-01 A | 1999-12-31 A | 100% | 1999-01-01 | 1999-12-31 | 261d? | start no earlier than 1999-01-01 | SMG2 | 2088h | 2088h | R99 |  | HS | HS |
| 5492 | 1310 | Streamlining of specifications | 261d? | 1999-01-01 A | 1999-12-31 A | 100% | 1999-01-01 | 1999-12-31 | 261d? | start no earlier than 1999-01-01 | N3 | 2088h | 2088h | R99 | Gwiho | Streamlining | Streamlining |
| 5493 | 1311 | R99_Service_Clean_up | 261d? | 1999-01-01 A | 1999-12-31 A | 100% | 1999-01-01 | 1999-12-31 | 261d? | start no earlier than 1999-01-01 | N3 | 2088h | 2088h | R99 | Gwiho | R99_Service_Clean_up | R99_Service_Clean_up |

Notes:
- 5453: -
- 5454: No additional features for R99. / Impacted TSs and TRs: 23.078, 23.079, 23.082, 29.002, 29.078
- 5455: - / Impacted TSs and TRs: 02.82, 29.002
- 5456: - / Impacted TSs and TRs: 23.082
- 5457: WID SMG 98-0781 End To End UMTS QoS Management
- 5458: WID SMG 98-0781 End To End UMTS QoS Management / Impacted TSs and TRs: 23.107, 23.907, 24.008
- 5459: Acronym changed from E2EQos / Impacted TSs and TRs: 23.060, 23.170
- 5460: AT-commands for Enhanced QoS Support management / Impacted TSs and TRs: 27.007
- 5461: - / Impacted TSs and TRs: 23.008, 23.016, 24.008, 29.002, 29.060
- 5462: Mechanism which can be used as a platform for providing special tariffs and/or special set of service features for certain subscribers within a regionally restricted area or areas. No additional features for R99. / Impacted TSs and TRs: 04.08, 04.18, 08.08, 11.10-1, 29.002
- 5463: UE location identification: background information and associated primitives 2. Transcoder location at the core network and source depending coding belonging to the non-access stratum. / Impacted TSs and TRs: 23.110
- 5464: - / Impacted TSs and TRs: 03.30
- 5465: Add requirement for high quality speech in UMTS Phase 1 but not in R99 / Impacted TSs and TRs: 22.105
- 5466: -
- 5467: -
- 5468: - / Impacted TSs and TRs: 26.911, 26.104, 26.111
- 5469: - / Impacted TSs and TRs: 26.911, 26.104, 26.111
- 5470: - / Impacted TSs and TRs: 26.911, 26.104, 26.111
- 5471: - / Impacted TSs and TRs: 26.911, 26.104, 26.111
- 5472: - / Impacted TSs and TRs: 26.911, 26.104, 26.111
- 5473: - / Impacted TSs and TRs: 26.911, 26.104, 26.111
- 5474: - / Impacted TSs and TRs: 26.102, 26.912
- 5475: UMTS_AMR2 is default Codec Type in R99 dual_mode terminals / Impacted TSs and TRs: 26.103
- 5476: Combination of the AMR speech codec and the Noise Suppression function. TS 06.77 and TR 06.78 only apply to GSM. They apply to UMTS from Rel-4 onwards, when they were converted to TS 26.077 and TR 26.078. / Impacted TSs and TRs: 06.77, 06.78
- 5477: Transcoder handling in the CN at inter-system handover and relocation + Introduction of UMTS AMR / Impacted TSs and TRs: 23.009, 24.008
- 5478: 24.008 CR#0572 in NP-020220 was approved under this WI / Impacted TSs and TRs: 24.008 CR#0572 in NP-020220
- 5479: - / Impacted TSs and TRs: 02.30, 02.68, 03.68, 03.69, 04.18, 08.08, 11.10-1, 11.11, 23.067, 23.094, 24.008, 24.067, 27.007, 29.002
- 5480: Minor improvements to 24.007 and 24.008 to increase the number of simultaneous calls/sessions from the present 7: the TI value is increased (NP-99441). / Impacted TSs and TRs: 24.007, 24.008
- 5481: - / Impacted TSs and TRs: 24.008, 27.001, 29.007
- 5482: Sub-System Number allocation for Radio Access Network Application Part, Radio Network Subsystem Application Part / Impacted TSs and TRs: 23.003
- 5483: Access to an Intranet/ISP with DHCP end to end / Impacted TSs and TRs: 29.061
- 5484: Support for the IP-Multicast protocol / Impacted TSs and TRs: 29.061
- 5485: - / Impacted TSs and TRs: 22.003, 22.100
- 5486: Asynchronous Interface for real-time NT Fax + Introduction of Asynchronous interface for Real-time non-transparent FAX / Impacted TSs and TRs: 27.001, 27.003
- 5487: - / Impacted TSs and TRs: 29.120
- 5488: - / Impacted TSs and TRs: 22.097, 23.072, 23.083, 23.084, 23.091, 23.093, 23.097
- 5489: - / Impacted TSs and TRs: 23.018, 23.082, 29.002
- 5490: Re-definition of channel quality measure used for AMR link adaptation for DARP MS / Impacted TSs and TRs: 05.09
- 5491: - / Impacted TSs and TRs: 13.21
- 5492: - / Impacted TSs and TRs: 27.060, 29.061
- 5493: - / Impacted TSs and TRs: 03.10, 27.001, 27.002, 27.003, 27.060, 29.007, 29.061

| ID | WBS | Task | Type | Duration | Start | Finish | Complete | Baseline start | Baseline finish | Baseline duration | Constraint | Resources | Work | Actual work | Acronym | Release | MCC resp | Acronym_3GU_Export | Impacted TSs and TRs | TSG stopped | WI rapporteur name | WI rapporteur e-mail |
| --- | --- | --- | --- | --- | --- | --- | --- | --- | --- | --- | --- | --- | --- | --- | --- | --- | --- | --- | --- | --- | --- | --- |
| 5494 | 1312 | **(Small) Technical Enhancements and Improvements for R99** |  | 261d? | 1999-01-01 A | 1999-12-31 A | 100% | 1999-01-01 | 1999-12-31 | 261d? |  | N3 | 6264h | 6264h | TEI | R99 | Gwiho | TEI |  |  |  |  |
| 5495 | 1312.1 | TEI_[CS_Data] |  | 261d? | 1999-01-01 A | 1999-12-31 A | 100% | 1999-01-01 | 1999-12-31 | 261d? | start no earlier than 1999-01-01 | N3 | 2088h | 2088h | TEI_[CS_Data] | R99 | Gwiho | TEI_[CS_Data] |  |  |  |  |
| 5496 | 1312.2 | TEI_[GPRS] |  | 261d? | 1999-01-01 A | 1999-12-31 A | 100% | 1999-01-01 | 1999-12-31 | 261d? | start no earlier than 1999-01-01 | N3 | 2088h | 2088h | TEI_[GPRS] | R99 | Gwiho | TEI_[GPRS] |  |  |  |  |
| 5497 | 1313 | **R99 UE Conformance Testing** |  | 261d? | 1999-01-01 A | 1999-12-31 A | 100% | 1999-01-01 | 1999-12-31 | 261d? |  | R5; T1 | 6264h | 6264h | TEI_Test | R99 | Ingbert | TEI_Test | 34.108, 34.121, 34.122, 34.123-1, 34.123-2, 34.123-3 |  |  |  |
| 5498 | 1313.1 | Deleted - RTEI |  | 261d? | 1999-01-01 A | 1999-12-31 A | 100% | 1999-01-01 | 1999-12-31 | 261d? | start no earlier than 1999-01-01 | T1 | 2088h | 2088h | RTEI | R99 | Ingbert | RTEI | 34.123-1 CR#0650, 0651, 34.123-3 CR#0148, 0149, 0150 | TP-06 |  |  |
| 5499 | 1313.2 | Common test environments for User Equipment (UE); Conformance testing | milestone | 0d? | 1999-01-01 A | 1999-01-01 A | 100% | 1999-01-01 | 1999-01-01 | 0d? | start no earlier than 1999-01-01 | R5; T1 |  |  |  | R99 | Ingbert |  | 34.108 |  |  |  |
| 5500 | 1313.3 | Terminal conformance specification, Radio transmission and reception (FDD) | milestone | 0d? | 1999-01-01 A | 1999-01-01 A | 100% | 1999-01-01 | 1999-01-01 | 0d? | start no earlier than 1999-01-01 | R5; T1 |  |  |  | R99 | Ingbert |  | 34.121 |  |  |  |
| 5501 | 1313.4 | Terminal conformance specification, Radio transmission and reception (TDD) | milestone | 0d? | 1999-01-01 A | 1999-01-01 A | 100% | 1999-01-01 | 1999-01-01 | 0d? | start no earlier than 1999-01-01 | R5; T1 |  |  |  | R99 | Ingbert |  | 34.122 |  |  |  |
| 5502 | 1313.5 | UE conformance specification; Part 1: Protocol conformance specification | milestone | 0d? | 1999-01-01 A | 1999-01-01 A | 100% | 1999-01-01 | 1999-01-01 | 0d? | start no earlier than 1999-01-01 | R5; T1 |  |  |  | R99 | Ingbert |  | 34.123-1 |  |  |  |
| 5503 | 1313.6 | UE conformance specification; Part 2: Implementation Conformance Statement (ICS) specification | milestone | 0d? | 1999-01-01 A | 1999-01-01 A | 100% | 1999-01-01 | 1999-01-01 | 0d? | start no earlier than 1999-01-01 | R5; T1 |  |  |  | R99 | Ingbert |  | 34.123-2 |  |  |  |
| 5504 | 1313.7 | UE conformance specification; Part 3: Abstract test suites (ATSs) | milestone | 0d? | 1999-01-01 A | 1999-01-01 A | 100% | 1999-01-01 | 1999-01-01 | 0d? | start no earlier than 1999-01-01 | R5; T1 |  |  |  | R99 | Ingbert |  | 34.123-3 |  |  |  |
| 5505 | 1314 | Deleted - Dual Tone Multi-Frequency signalling : Support in the whole 3GPP system |  | 261d? | 1999-01-01 A | 1999-12-31 A | 100% | 1999-01-01 | 1999-12-31 | 261d? | start no earlier than 1999-01-01 | N1 | 2088h | 2088h | DTMF | R99 | Frederic | DTMF | 23.014 CR#0004 | NP-06 |  |  |
| 5506 | 1315 | Deleted - Intersystem_Change |  | 261d? | 1999-01-01 A | 1999-12-31 A | 100% | 1999-01-01 | 1999-12-31 | 261d? | start no earlier than 1999-01-01 | SMG | 2088h | 2088h | Intersystem_Change | R99 |  | Intersystem_Change | 04.18 CR#A243 | SMG |  |  |
| 5507 | 1316 | Deleted - Long_Forwardedto_Numbers |  | 261d? | 1999-01-01 A | 1999-12-31 A | 100% | 1999-01-01 | 1999-12-31 | 261d? | start no earlier than 1999-01-01 | N2 | 2088h | 2088h | Long_Forwardedto_Numbers | R99 | Kimmo | Long_Forwardedto_Numbers | 29.002 | NP-06 |  |  |
| 5508 | 1317 | Deleted - RANimp-FSEarlyUE |  | 261d? | 1999-01-01 A | 1999-12-31 A | 100% | 1999-01-01 | 1999-12-31 | 261d? | start no earlier than 1999-01-01 | R3 | 2088h | 2088h | RANimp-FSEarlyUE | R99 | Juha | RANimp-FSEarlyUE | 25.413 CR#0520, 0538, 0565, 0563, 0541, 0540, 0539, 0547 | RP-06 |  |  |
| 5509 | 1318 | Release 1999 Studies |  | 261d? | 1999-01-01 A | 1999-12-31 A | 100% | 1999-01-01 | 1999-12-31 | 261d? |  | S1; T2 | 4176h | 4176h |  | R99 | Alain |  |  |  |  |  |
| 5510 | 1319 | Advanced Addressing/Numbering |  | 261d? | 1999-01-01 A | 1999-12-31 A | 100% | 1999-01-01 | 1999-12-31 | 261d? | start no earlier than 1999-01-01 | S1 | 2088h | 2088h | Numbering | R99 | Alain | Numbering | 22.975 |  | Vodafone | mona.mustapha@vodafone.com |
| 5511 | 1320 | Combined GSM and Mobile IP mobility handling in UMTS IP CN |  | 261d? | 1999-01-01 A | 1999-12-31 A | 100% | 1999-01-01 | 1999-12-31 | 261d? | start no earlier than 1999-01-01 | S2 | 2088h | 2088h |  | R99 | Maurice |  | 23.923 |  |  |  |
| 5512 | 1321 | UE Capabilities Requirements |  | 261d? | 1999-01-01 A | 1999-12-31 A | 100% | 1999-01-01 | 1999-12-31 | 261d? | start no earlier than 1999-01-01 | T2 | 2088h | 2088h | UCR | R99 |  | UCR | 21.904 |  |  |  |
| 5513 | 1322 | Electrical safety requirements and regulations |  | 261d? | 1999-01-01 A | 1999-12-31 A | 100% | 1999-01-01 | 1999-12-31 | 261d? | start no earlier than 1999-01-01 | T2 | 2088h | 2088h |  | R99 |  |  | 34.907 |  |  |  |
| 5514 | 1323 | Specific Absorbtion Rate (SAR) requirements and regulations in different regions |  | 261d? | 1999-01-01 A | 1999-12-31 A | 100% | 1999-01-01 | 1999-12-31 | 261d? | start no earlier than 1999-01-01 | T2 | 2088h | 2088h |  | R99 |  |  | 34.925 |  |  |  |
| 5515 | 1324 | Multi-mode UE issues |  | 261d? | 1999-01-01 A | 1999-12-31 A | 100% | 1999-01-01 | 1999-12-31 | 261d? | start no earlier than 1999-01-01 | T2 | 2088h | 2088h |  | R99 |  |  | 21.810, 21.910 |  |  |  |
| 5516 | 1325 | Provision of fax service in GSM and UMTS |  | 261d? | 1999-01-01 A | 1999-12-31 A | 100% | 1999-01-01 | 1999-12-31 | 261d? | start no earlier than 1999-01-01 | T2 | 2088h | 2088h |  | R99 |  |  | 22.945 |  | Ericsson | peter.bleckert@ericsson.com |
| 5517 | 1326 | Separating Radio Resources and Mobility Management specific parts of the MS Classmark |  | 261d | 1999-01-01 A | 1999-12-31 A | 100% | 1999-01-01 | 1999-12-31 | 261d |  | T2 | 2088h | 2088h |  | R99 |  |  | 23.814 |  |  |  |

Notes:
- 5494: -
- 5495: -
- 5496: -
- 5497: Specifies Conformance Tests for a 3G UE to be recognised as 3GPP-standard compliant. A 3GPP-external body, GCF (Global Certification Forum), delivers certificates to prove that a UE has correctly passed tests and is then conform to the 3GPP standard.
- 5498: No CR or new TS/TR approved under this WI
- 5499: -
- 5500: measurement procedures for the conformance test of the UE that contain transmitting characteristics, receiving characteristics and performance requirements in addition to requirements for support of RRM (Radio Resource Management) in FDD mode.
- 5501: measurement procedures for the conformance test of the UE that contain transmitting characteristics, receiving characteristics and performance requirements in addition to requirements for support of RRM (Radio Resource Management) in TDD mode.
- 5502: TS 34.123, composed of three parts, actually specifies the protocol conformance testing for the 3G UE. Part 1 describes the overall test structure.
- 5503: Part 2 contains the applicability of each test case defined as the Implementation Conformance Statement (ICS) proforma, in compliance with the relevant requirements, and in accordance with the relevant guidance given in ISO/IEC 9646-7 and ETS 300 406.
- 5504: Part 3 specifies the protocol conformance testing in TTCN for the 3G UE at the Uu interface. It defines the TTCN test specification and design considerations in Abstract Test Suites based on the test cases specified in prose in part 1.
- 5505: No CR or new TS/TR approved under this WI
- 5506: No CR or new TS/TR approved under this WI
- 5507: -
- 5508: No CR or new TS/TR approved under this WI
- 5509: -
- 5510: Study on requirements for numbering and addressing for UMTS
- 5511: -
- 5512: Moved to CT1 at TSG-T closure
- 5513: Moved to RAN4 at TSG-T closure. TR summarizes differences between international and national standards relevant to IEC60950 and refers to regulations for conformity assessment due to different regulatory environments in different countries / regions.
- 5514: Moved to RAN4 at TSG-T closure.
- 5515: Moved to CT1 at TSG-T closure. Consequences on roaming capabilities and service availability (e.g. handover) of multi-mode UEs while roaming in various regions with various network configurations. Case studies for each of the possible scenarios in specs
- 5516: CP#27: Moved to C1 on closure of T2; see TP-050062. CP#28: C1->C3
- 5517: CP#27: change of WG as a result of closure of CN and T.
